# MOBILIZATION SCHEDULE baseline

Schedule from Primavera P6, 2012-12-07 to 2013-07-29, data date 2013-04-11, costs in QAR, A marks actual dates.
Must finish by 2013-08-31

## Calendars

- 7 Days / Week - 8 Hours / Day - DD: Mon-Fri 07:00-17:00; Sat 00:00-00:30, 07:00-17:00; Sun 07:00-17:00. Exceptions (off unless hours are given): 2013-01-01 to 2013-03-30 08:00-16:00, 2013-04-01 to 2013-05-31 08:00-16:00, 2013-06-01 to 2013-06-30 07:30-15:30, 2013-07-01 to 2013-07-29 08:00-16:00.
- * 7 Days Working 8hr: Mon-Sun 08:00-12:00, 13:00-17:00.

## Resources

| Resource | Group | Rate |
| --- | --- | --- |
| Aktogay Mobilization Team | labor |  |
| Mobilizasyon Yeni WBS | labor | 20 |

## Schedule

| ID | WBS | Activity | Type | Duration | Start | Finish | Predecessors | Complete | Remaining | Planned start | Planned finish | Total float | Free float | Constraint | Calendar | Resources | Cost | Actual cost | user_text7 | NOT |
| --- | --- | --- | --- | --- | --- | --- | --- | --- | --- | --- | --- | --- | --- | --- | --- | --- | --- | --- | --- | --- |
|  | 1 | **Milestones** |  |  | 2012-12-07 | 2013-07-29 |  |  |  |  |  |  |  |  |  |  |  |  |  |  |
| MOB-ST-PR-0010 |  | Main sing for notification of contract works | milestone | 0d | 2012-12-07 A | 2012-12-07 A |  | 100% |  |  |  |  |  |  | * 7 Days Working 8hr |  | 1 |  |  |  |
| MOB-ST-PR-0020 |  | Preliminary decisions on mobilization activities |  | 7d | 2012-12-08 A | 2012-12-14 A | MOB-ST-PR-0010 | 100% |  | 2012-12-08 | 2012-12-13 |  |  |  |  | Aktogay Mobilization Team [70 h] |  |  |  |  |
| MOB-ST-PR-0030 |  | Decision on the prefabricated buildings manufacturer |  | 20d | 2012-12-08 A | 2012-12-27 A | MOB-ST-PR-0010 | 100% |  | 2012-12-08 | 2012-12-23 |  |  |  |  | Aktogay Mobilization Team [200 h] |  |  |  |  |
| MOB-ST-PR-0050 |  | Decision on the mobilization desing company |  | 20d | 2012-12-08 A | 2012-12-27 A | MOB-ST-PR-0010 | 100% |  | 2012-12-08 | 2012-12-23 |  |  |  |  | Aktogay Mobilization Team [200 h] |  |  |  |  |
| MOB-ST-PR-0060 |  | Camp site desing, review and approvals |  | 45d | 2012-12-28 A | 2013-03-11 A | MOB-ST-PR-0050 | 100% |  | 2012-12-28 | 2013-02-10 |  |  |  |  | Aktogay Mobilization Team [450 h] |  |  |  |  |
| MOB-ST-PR-0011 |  | Mobilization completed (first party) | milestone | 0d | 2013-03-29 A | 2013-03-29 A | MOB-HS-HS-0025, MOB-PA-CO-120, MOB-WS-WH-140, A1690, MOB-TS-FS-120, MOB-HS-HS-0040, MOB-ST-PR-0020, MOB-ST-PR-0030, MOB-HS-HS-0170, MOB-ST-WH-0140 | 100% |  |  |  |  |  | finish on 2013-03-29 |  |  | 1 |  | baseline |  |
| MOB-ST-PR-0110 |  | Completion of Dining Facilities | milestone | 0d | 2013-06-22 | 2013-06-22 | MOB-OF-KT-220, MOB-OF-CE-220, MOB-OF-KT-180, MOB-OF-DH-180, MOB-OF-DH-220, MOB-OF-CE-180 |  |  |  |  | 7.25d | 36.62d |  |  |  | 1 |  |  |  |
| MOB-ST-PR-0070 |  | Completion of all Alarko Office Buildings | milestone | 0d | 2013-06-29 | 2013-06-29 | MOB-OF-AOB-IV-180, MOB-OF-AOB-170, MOB-OF-AOB-II-170 |  |  |  |  | 0d | 29.38d |  |  |  | 1 |  |  |  |
| MOB-ST-PR-0080 |  | Completion of all Alarko Accommodation | milestone | 0d | 2013-06-30 | 2013-06-30 | MOB-TA-ED-190, MOB-TA-DOT2-190, MOB-TA-WD-190, MOB-TA-WDR-190, MOB-TA-AMD-190, MOB-TA-DOT-190 |  |  |  |  | -1d | 28.38d |  |  |  | 1 |  |  |  |
| MOB-ST-PR-0090 |  | Handover of the Client Accommodations | milestone | 0d | 2013-06-30 | 2013-06-30 | MOB-TA-EED-190, MOB-TA-EMD-190 |  |  |  |  | -1d | 28.38d |  |  |  | 1 |  |  |  |
| MOB-ST-PR-0100 |  | Handover of the Client Offices | milestone | 0d | 2013-07-04 | 2013-07-04 | MOB-OF-KOB-180 |  |  | 2013-06-28 | 2013-06-28 | -5d | 24.38d |  |  |  | 1 |  |  |  |
| MOB-ST-PR-0120 |  | Completion of all Recreational Facilities | milestone | 0d | 2013-07-08 | 2013-07-08 | MOB-OF-AOB-180, MOB-RF-SF-230, MOB-RF-SC-230, MOB-RF-WR-230, MOB-RF-ER-230, MOB-RF-ER-190, MOB-RF-WR-190, MOB-RF-SF-190, MOB-RF-SC-190 |  |  | 2013-06-26 | 2013-06-26 | -9d | 20.38d |  |  |  | 1 |  |  |  |
| MOB-ST-PR-0130 |  | Site Communications Established | milestone | 0d | 2013-07-29 | 2013-07-29 | MOB-IT-NE-130, MOB-IT-CRN-130, MOB-IT-IN-120, MOB-IT-NE-150, MOB-IT-TL-110 |  |  | 2013-06-29 | 2013-06-29 | -29.38d | 0d |  |  |  | 1 |  |  |  |
|  | 2 | **Planning, Permits & Baseline Documentation** |  |  | 2012-12-07 | 2013-07-29 |  |  |  |  |  |  |  |  |  |  |  |  |  |  |
|  | 1 | **Site Planning Activities** |  |  | 2013-04-11 | 2013-07-29 |  |  |  |  |  |  |  |  |  |  |  |  |  |  |
| MOB-ST-OE-0019 |  | Start date of after fisrt part mobilization activities | milestone | 0d | 2013-04-11 | 2013-04-11 | MOB-ST-PR-0011 |  |  | 2013-03-11 | 2013-03-11 | -10d | 0d | mandatory start 2013-04-01 |  |  | 1 |  | baseline |  |
| MOB-ST-OE-0020 |  | Establish Office facilities (second party) |  | 45d | 2013-04-11 | 2013-05-25 | MOB-ST-OE-0019 |  |  | 2013-03-11 | 2013-04-24 | -10d | 0d |  |  | Mobilizasyon Yeni WBS [360 h] | 7,200 |  | baseline |  |
| MOB-ST-OE-0110 |  | Arrangement activities for 2. and 3. party buildings |  | 60d | 2013-04-21 | 2013-06-19 | MOB-ST-OE-0020 SS+10d |  |  | 2013-03-21 | 2013-05-19 | 10d | 39.38d |  |  | Mobilizasyon Yeni WBS [480 h] | 9,600 |  | baseline |  |
| MOB-ST-OE-0030 |  | Establish Office facilities (third party) |  | 45d | 2013-05-26 | 2013-07-09 | MOB-ST-OE-0020 |  |  | 2013-04-26 | 2013-06-09 | -10d | 19.38d | start on or after 2013-04-26 |  | Mobilizasyon Yeni WBS [360 h] | 7,200 |  | baseline |  |
| MOB-ST-PR-0012 |  | Mobilization completed (full) | milestone | 0d | 2013-07-29 | 2013-07-29 | MOB-ST-PR-0110, MOB-ST-OE-0110, MOB-ST-MC-0200, MOB-SE-PC-120, MOB-VH-DT-100, MOB-HE-WT-120, MOB-CF-WS-150, MOB-TS-LA-110, MOB-TS-FS-170, MOB-OF-KOB-180, MOB-TA-EMD-170, MOB-TA-EED-190, MOB-TA-DOT-190, MOB-TA-WDR-160, MOB-RF-SC-170, MOB-RF-ER-180, MOB-RF-ER-190, MOB-RF-WR-150, MOB-RF-WR-190, MOB-RF-SF-150, MOB-ST-PR-0090, MOB-TS-LS-120, MOB-TS-SS-120, MOB-ST-WH-0120, MOB-WS-WHE-170, MOB-WS-WWH-220, MOB-BP-TC-100, MOB-SE-FE-120, MOB-SE-SL-100, MOB-LE-FL-130, MOB-CE-CP-290, MOB-HE-DZR-110, MOB-HE-DZR-120, MOB-IT-NE-150, MOB-TU-SE-140, MOB-TU-SE-230, MOB-CF-WS-130, MOB-TS-FS-180, MOB-OR-TS-100, MOB-OF-AOB-180, MOB-OF-AOB-IV-170, MOB-TA-EMD-190, MOB-TA-DOT-180, MOB-TA-WD-190, MOB-TA-SC-140, MOB-TA-WDR-180, MOB-RF-SC-150, MOB-PPB-MCI-120, MOB-SE-SL-120, MOB-TR-TR-150, MOB-VH-PU-110, MOB-VH-HU-110, MOB-PM-BU-130, MOB-TU-ELC-170, MOB-TU-CW-210, MOB-QM-EP-100, MOB-TS-TO-130, MOB-TS-TO-110, MOB-OF-KOB-170, MOB-OF-KOB-150, MOB-TA-PA-100, MOB-TA-ED-180, MOB-TA-DOT2-170, MOB-TA-DOT2-190, MOB-OF-MF-170, MOB-OF-KT-170, MOB-OF-KT-180, MOB-OF-DH-170, MOB-OF-CE-180, MOB-RF-ER-230, MOB-RF-ER-150, MOB-ST-PR-0100, MOB-ST-PR-0120, MOB-PPB-GLI-120, MOB-PPB-PM-180, MOB-PPB-BD190, MOB-SE-TC-120, MOB-LE-FL-110, MOB-HE-TFB-120, MOB-HE-BL-120, MOB-IT-IN-120, MOB-TU-ELC-160, MOB-TU-PW-210, MOB-OR-TS-130, MOB-OF-AOB-II-150, MOB-OF-AOB-IV-180, MOB-TA-AMD-180, MOB-TA-WDR-170, MOB-OF-SF-190, MOB-RF-SF-190, MOB-PPB-WC-120, MOB-PPB-PM-170, MOB-HS-HS-0150, MOB-SE-SI-120, MOB-VH-ST-120, MOB-VH-CR-150, MOB-IT-TL-110, MOB-TU-CW-220, MOB-PA-FU-120, MOB-QR-AR-100, MOB-TA-AMD-190, MOB-TA-ED-170, MOB-TA-WD-170, MOB-TA-WDR-190, MOB-OF-SF-170, MOB-OF-DH-180, MOB-OF-CE-220, MOB-OF-CE-170, MOB-RF-SC-190, MOB-RF-ER-170, MOB-RF-SF-160, MOB-ST-PR-0080, MOB-PPB-PEO120, MOB-PPB-PM-150, MOB-PPB-PM-160, MOB-HS-HS-0050, MOB-VH-ST-110, MOB-IT-NE-130, MOB-TU-ELC-140, MOB-TU-PW-200, MOB-TU-PW-220, MOB-TU-SE-210, MOB-TS-FS-160, MOB-OF-AOB-170, MOB-TA-EED-180, MOB-TA-AMD-170, MOB-TA-ED-190, MOB-TA-DOT2-180, MOB-TA-WD-160, MOB-OF-SF-180, MOB-OF-KT-150, MOB-RF-SC-180, MOB-RF-SF-170, MOB-RF-SF-180, MOB-ST-PR-0130, A1240, MOB-ST-OE-0030, MOB-PPB-ALI-120, MOB-PPB-ULI120, MOB-PPB-ARI-120, MOB-ST-MC-0060, MOB-WS-WHE-150, MOB-SE-MG-130, MOB-HE-SDR-110, MOB-CE-EC-130, MOB-VH-CR-130, MOB-CF-WS-140, MOB-QR-AR-140, MOB-QR-PL-190, MOB-OF-AOB-II-170, MOB-OF-AOB-IV-150, MOB-TA-EED-170, MOB-TA-DOT-170, MOB-OF-MF-150, MOB-OF-MF-180, MOB-RF-WR-230, MOB-RF-WR-170, MOB-RF-SF-230, MOB-ST-PR-0070, MOB-PPB-PM-100, MOB-HS-HS-0200, MOB-TS-CS-120, MOB-WS-WWH-150, MOB-HE-BL-110, MOB-VH-CR-110, MOB-IT-CRN-130, MOB-TU-ELC-190, MOB-PA-OE120, MOB-QM-MP-110, MOB-OF-AOB-II-180, MOB-TA-EMD-180, MOB-TA-WD-180, MOB-OF-DH-150, MOB-RF-SC-230, MOB-RF-SC-160, MOB-RF-WR-180 |  |  | 2013-06-29 | 2013-06-29 | -29.38d | 0d | finish on 2013-06-29 |  |  | 1 |  | baseline |  |
|  | 2 | **Personnel Mobilization** |  |  | 2012-12-07 | 2013-07-03 |  |  |  |  |  |  |  |  |  |  |  |  |  |  |
| MOB-PPB-PM-100 |  | Recruitment of key Personnel for Alarko |  | 105d | 2012-12-07 A | 2013-03-16 A | MOB-ST-PR-0010 | 100% |  |  |  |  |  |  |  | Mobilizasyon Yeni WBS [840 h] | 16,800 | 16,800 |  |  |
| MOB-PPB-PM-120 |  | Contract Sign with Subcontractor for Mobilization Civil Works | milestone | 0d | 2013-03-01 A | 2013-03-01 A | MOB-ST-PR-0010 SS+80d | 100% |  | 2013-03-27 | 2013-03-27 |  |  |  |  |  | 1 |  |  |  |
| MOB-PPB-PM-150 |  | Civil Works Subcontractor Personnel are Mobilized on Site |  | 30d | 2013-03-20 A | 2013-05-03 | MOB-PPB-PM-120 FS+20d | 23% | 23d | 2013-03-27 | 2013-04-25 | 57d | 86.38d |  |  | Mobilizasyon Yeni WBS [240 h] | 4,800 |  |  |  |
| MOB-PPB-PM-110 |  | Receiving Work Visa for Key Personnel |  | 105d | 2013-04-11 | 2013-05-09 | MOB-PPB-PM-100 SS+30d |  |  | 2013-03-13 | 2013-06-25 | -4d | 0d |  |  | Mobilizasyon Yeni WBS [840 h] | 16,800 |  |  |  |
| MOB-PPB-PM-130 |  | Contract Sign with Subcontractor for Mobilization Mechanical Works | milestone | 0d | 2013-04-11 | 2013-04-11 | MOB-PPB-PM-120 FS+40d |  |  |  |  | 40d | 0d |  |  |  | 1 |  |  |  |
| MOB-PPB-PM-140 |  | Contract Sign with Subcontractor for Mobilization Electrical Works | milestone | 0d | 2013-04-11 | 2013-04-11 | MOB-PPB-PM-120 FS+40d, MOB-PPB-PM-130 SS |  |  |  |  | 40d | 0d |  |  |  | 1 |  |  |  |
| MOB-PPB-PM-160 |  | Mechanical Works Subcontractor Personnel are Mobilized on Site |  | 30d | 2013-04-21 | 2013-05-20 | MOB-PPB-PM-130 FS+10d |  |  |  |  | 40d | 69.38d |  |  | Mobilizasyon Yeni WBS [240 h] | 4,800 |  |  | Baþlangýçlarý 20 april |
| MOB-PPB-PM-170 |  | Electrical Works Subcontractor Personnel are Mobilized on Site |  | 30d | 2013-04-21 | 2013-05-20 | MOB-PPB-PM-140 FS+10d |  |  |  |  | 40d | 69.38d |  |  | Mobilizasyon Yeni WBS [240 h] | 4,800 |  |  | Baþlangýçlarý 20 april |
| MOB-PPB-PM-180 |  | All Required Alarko Personnel are Mobilized on Site |  | 40d | 2013-05-25 | 2013-07-03 | MOB-PPB-PM-110 FS+15d |  |  | 2013-05-18 | 2013-06-26 | -4d | 25.38d |  |  | Mobilizasyon Yeni WBS [320 h] | 6,400 |  |  |  |

Notes:
- MOB-ST-PR-0010: Expenses: (New Expense Item) 1
- MOB-ST-PR-0011: Expenses: (New Expense Item) 1
- MOB-ST-PR-0110: Expenses: (New Expense Item) 1
- MOB-ST-PR-0070: Expenses: (New Expense Item) 1
- MOB-ST-PR-0080: Expenses: (New Expense Item) 1
- MOB-ST-PR-0090: Expenses: (New Expense Item) 1
- MOB-ST-PR-0100: Expenses: (New Expense Item) 1
- MOB-ST-PR-0120: Expenses: (New Expense Item) 1
- MOB-ST-PR-0130: Expenses: (New Expense Item) 1
- MOB-ST-OE-0019: Expenses: (New Expense Item) 1
- MOB-ST-PR-0012: Expenses: (New Expense Item) 1
- MOB-PPB-PM-120: Expenses: (New Expense Item) 1
- MOB-PPB-PM-130: Expenses: (New Expense Item) 1
- MOB-PPB-PM-140: Expenses: (New Expense Item) 1

| ID | WBS | Activity | Type | Duration | Start | Finish | Predecessors | Complete | Planned start | Planned finish | Total float | Free float | Cost | NOT | Notlar |
| --- | --- | --- | --- | --- | --- | --- | --- | --- | --- | --- | --- | --- | --- | --- | --- |
|  | 3 | **Insurance** |  |  | 2013-03-04 | 2013-05-20 |  |  |  |  |  |  |  |  |  |
|  | 1 | **Work Compensation** |  |  | 2013-03-08 | 2013-04-04 |  |  |  |  |  |  |  |  |  |
| MOB-PPB-WC-100 |  | Obtain Permit | milestone | 0d | 2013-03-08 A | 2013-03-08 A | MOB-ST-PR-0020 FS+10d | 100% |  |  |  |  | 1 | 3 aþama step %50-%40-%10 |  |
| MOB-PPB-WC-110 |  | Transmit Permit to Client | milestone | 0d | 2013-03-25 A | 2013-03-25 A |  | 100% | 2013-03-27 | 2013-03-27 |  |  | 1 |  |  |
| MOB-PPB-WC-120 |  | Obtain Client Acceptance | milestone | 0d | 2013-04-04 A | 2013-04-04 A | MOB-PPB-WC-110 FS+5d | 100% | 2013-03-29 | 2013-03-29 |  |  | 1 |  |  |
|  | 2 | **Commercial General Liability Insurance** |  |  | 2013-03-15 | 2013-04-04 |  |  |  |  |  |  |  |  |  |
| MOB-PPB-GLI-100 |  | Obtain Insurance | milestone | 0d | 2013-03-15 A | 2013-03-15 A | MOB-PPB-WC-100 SS | 100% |  |  |  |  | 1 |  | Baþlangýç tarihi bilinmiyor |
| MOB-PPB-GLI-110 |  | Transmit Insurance to Client | milestone | 0d | 2013-03-25 A | 2013-03-25 A |  | 100% | 2013-03-27 | 2013-03-27 |  |  | 1 |  |  |
| MOB-PPB-GLI-120 |  | Obtain Client Acceptance | milestone | 0d | 2013-04-04 A | 2013-04-04 A | MOB-PPB-GLI-110 FS+5d | 100% | 2013-03-29 | 2013-03-29 |  |  | 1 |  |  |
|  | 3 | **Commercial Automobile Liability Insurance** |  |  | 2013-05-05 | 2013-05-20 |  |  |  |  |  |  |  |  |  |
| MOB-PPB-ALI-100 |  | Obtain Insurance | milestone | 0d | 2013-05-05 | 2013-05-05 | MOB-VH-PU-110 FS+15d, MOB-ST-PR-0010 SS |  |  |  | 40d | 0d | 1 |  | Baþlangýç tarihi bilinmiyor |
| MOB-PPB-ALI-110 |  | Transmit Insurance to Client | milestone | 0d | 2013-05-10 | 2013-05-10 | MOB-PPB-ALI-100 FS+5d |  |  |  | 40d | 0d | 1 |  |  |
| MOB-PPB-ALI-120 |  | Obtain Client Acceptance | milestone | 0d | 2013-05-20 | 2013-05-20 | MOB-PPB-ALI-110 FS+10d |  |  |  | 40d | 69.38d | 1 |  |  |
|  | 4 | **Umbrella Liability Insurance** |  |  | 2013-03-04 | 2013-03-25 |  |  |  |  |  |  |  |  |  |
| MOB-PPB-ULI120 |  | Obtain Client Acceptance | milestone | 0d | 2013-03-04 A | 2013-03-04 A | MOB-PPB-ULI110 FS+5d | 100% | 2013-03-30 | 2013-03-30 |  |  | 1 |  |  |
| MOB-PPB-ULI100 |  | Obtain Insurance | milestone | 0d | 2013-03-15 A | 2013-03-15 A | MOB-PPB-ALI-100 | 100% |  |  |  |  | 1 |  | Baþlangýç tarihi bilinmiyor |
| MOB-PPB-ULI110 |  | Transmit Insurance to Client | milestone | 0d | 2013-03-25 A | 2013-03-25 A |  | 100% |  |  |  |  | 1 |  |  |
|  | 5 | **Professional Errors and Omissions Insurance** |  |  | 2013-03-15 | 2013-04-04 |  |  |  |  |  |  |  |  |  |
| MOB-PPB-PEO100 |  | Obtain Insurance | milestone | 0d | 2013-03-15 A | 2013-03-15 A | MOB-PPB-ULI100 | 100% |  |  |  |  | 1 |  | Baþlangýç tarihi bilinmiyor |
| MOB-PPB-PEO110 |  | Transmit Insurance to Client | milestone | 0d | 2013-03-25 A | 2013-03-25 A | MOB-PPB-PEO100 FS+10d | 100% | 2013-03-27 | 2013-03-27 |  |  | 1 |  |  |
| MOB-PPB-PEO120 |  | Obtain Client Acceptance | milestone | 0d | 2013-04-04 A | 2013-04-04 A | MOB-PPB-PEO110 FS+5d | 100% | 2013-03-29 | 2013-03-29 |  |  | 1 |  |  |
|  | 6 | **All Risk Insurance** |  |  | 2013-03-15 | 2013-04-04 |  |  |  |  |  |  |  |  |  |
| MOB-PPB-ARI-100 |  | Obtain Insurance | milestone | 0d | 2013-03-15 A | 2013-03-15 A | MOB-PPB-PEO100 | 100% |  |  |  |  | 1 |  | Baþlangýç tarihi bilinmiyor |
| MOB-PPB-ARI-110 |  | Transmit Insurance to Client | milestone | 0d | 2013-03-25 A | 2013-03-25 A | MOB-PPB-ARI-100 FS+10d | 100% | 2013-03-27 | 2013-03-27 |  |  | 1 |  |  |
| MOB-PPB-ARI-120 |  | Obtain Client Acceptance | milestone | 0d | 2013-04-04 A | 2013-04-04 A | MOB-PPB-ARI-110 FS+5d | 100% | 2013-03-29 | 2013-03-29 |  |  | 1 |  |  |

Notes:
- MOB-PPB-WC-100: Expenses: (New Expense Item) 1
- MOB-PPB-WC-110: Expenses: (New Expense Item) 1
- MOB-PPB-WC-120: Expenses: (New Expense Item) 1
- MOB-PPB-GLI-100: Expenses: (New Expense Item) 1
- MOB-PPB-GLI-110: Expenses: (New Expense Item) 1
- MOB-PPB-GLI-120: Expenses: (New Expense Item) 1
- MOB-PPB-ALI-100: Expenses: (New Expense Item) 1
- MOB-PPB-ALI-110: Expenses: (New Expense Item) 1
- MOB-PPB-ALI-120: Expenses: 1 1
- MOB-PPB-ULI120: Expenses: (New Expense Item) 1
- MOB-PPB-ULI100: Expenses: (New Expense Item) 1
- MOB-PPB-ULI110: Expenses: (New Expense Item) 1
- MOB-PPB-PEO100: Expenses: (New Expense Item) 1
- MOB-PPB-PEO110: Expenses: (New Expense Item) 1
- MOB-PPB-PEO120: Expenses: (New Expense Item) 1
- MOB-PPB-ARI-100: Expenses: (New Expense Item) 1
- MOB-PPB-ARI-110: Expenses: (New Expense Item) 1
- MOB-PPB-ARI-120: Expenses: (New Expense Item) 1

| ID | WBS | Activity | Type | Duration | Start | Finish | Predecessors | Complete | Remaining | Planned start | Planned finish | Total float | Free float | Constraint | Resources | Cost | Actual cost | NOT |
| --- | --- | --- | --- | --- | --- | --- | --- | --- | --- | --- | --- | --- | --- | --- | --- | --- | --- | --- |
|  | 7 | **Marine Cargo Insurance** |  |  | 2013-03-15 | 2013-04-04 |  |  |  |  |  |  |  |  |  |  |  |  |
| MOB-PPB-MCI-100 |  | Obtain Insurance | milestone | 0d | 2013-03-15 A | 2013-03-15 A | MOB-PPB-ARI-100 | 100% |  |  |  |  |  |  |  | 1 |  |  |
| MOB-PPB-MCI-110 |  | Transmit Insurance to Client | milestone | 0d | 2013-03-25 A | 2013-03-25 A | MOB-PPB-MCI-100 | 100% |  | 2013-03-27 | 2013-03-27 |  |  |  |  | 1 |  |  |
| MOB-PPB-MCI-120 |  | Obtain Client Acceptance | milestone | 0d | 2013-04-04 A | 2013-04-04 A | MOB-PPB-MCI-110 FS+5d | 100% |  | 2013-03-29 | 2013-03-29 |  |  |  |  | 1 |  |  |
|  | 4 | **Permits** |  |  | 2013-06-29 | 2013-06-29 |  |  |  |  |  |  |  |  |  |  |  |  |
| A1240 |  | RoK/Akimat licences, license owners & accountabilities | milestone | 0d | 2013-06-29 | 2013-06-29 | MOB-ST-PR-0010 |  |  |  |  | 0d | 30.38d | finish on 2013-06-28 |  | 1 |  |  |
|  | 5 | **HSE** |  |  | 2013-02-26 | 2013-05-05 |  |  |  |  |  |  |  |  |  |  |  |  |
| MOB-HS-HS-0020 |  | Submission of Environment Management Plan | milestone | 0d | 2013-02-26 A | 2013-02-26 A | MOB-HS-HS-0010 SS | 100% |  | 2013-02-01 | 2013-02-01 |  |  |  |  | 1 |  |  |
| MOB-HS-HS-0025 |  | Submission of Winterization Management Plan | milestone | 0d | 2013-02-26 A | 2013-02-26 A | MOB-HS-HS-0020 | 100% |  | 2013-02-01 | 2013-02-01 |  |  |  |  | 1 |  |  |
| MOB-HS-HS-0010 |  | Submission of Health & Safety Management Plan | milestone | 0d | 2013-02-28 A | 2013-02-28 A | MOB-ST-PR-0010 FS+56d | 100% |  | 2013-02-01 | 2013-02-01 |  |  |  |  | 1 |  |  |
| MOB-HS-HS-0200 |  | Agreement with Local Authorities for the disposal of Wastes |  | 24.62d | 2013-03-02 A | 2013-05-05 | MOB-HS-HS-0190 |  | 24.62d | 2013-03-02 | 2013-03-26 | 55.38d | 84.75d |  | Mobilizasyon Yeni WBS [197 h] | 3,940 |  |  |
| MOB-HS-HS-0050 |  | Installation safety signs on site |  | 8.38d | 2013-03-09 A | 2013-04-19 | MOB-HS-HS-0030 |  | 8.38d | 2013-02-11 | 2013-02-19 | 71.62d | 101d |  | Mobilizasyon Yeni WBS [67 h] | 1,340 |  |  |
| MOB-HS-HS-0160 |  | Emergency Drills (Fire) |  | 2.12d | 2013-03-14 A | 2013-03-15 A | MOB-HS-HS-0050 FS+25d | 100% |  | 2013-03-08 | 2013-03-10 |  |  |  | Mobilizasyon Yeni WBS [17 h] | 340 |  |  |
| MOB-HS-HS-0170 |  | Emergency Drills (First Aid) |  | 2.12d | 2013-03-18 A | 2013-03-20 A | MOB-HS-HS-0160 SS | 100% |  | 2013-03-27 | 2013-03-29 |  |  |  | Mobilizasyon Yeni WBS [17 h] | 340 | 340 |  |
| MOB-HS-HS-0150 |  | Preparation of Emergency Response Plan |  | 19.62d | 2013-04-11 | 2013-04-30 | MOB-HS-HS-0030 SS |  |  |  |  | 60.38d | 89.75d |  | Mobilizasyon Yeni WBS [157 h] | 3,140 |  |  |
| MOB-HS-HS-0180 |  | Monthly HS & ENV Reports | milestone | 0d | 2013-04-11 | 2013-04-11 | MOB-ST-PR-0010 FS+88d |  |  |  |  | 142d | 3d |  |  | 1 |  |  |
| MOB-HS-HS-0190 |  | Monthly H&S Committee Meeting | milestone | 0d | 2013-04-11 | 2013-04-11 | MOB-HS-HS-0180 SS-3d |  |  |  |  | 142d | 109.38d |  |  | 1 |  |  |
|  | 6 | **Baseline Documentation** |  |  | 2013-01-15 | 2013-04-11 |  |  |  |  |  |  |  |  |  |  |  |  |
| MOB-PPB-BD100 |  | Submission of Document Management Procedure | milestone | 0d | 2013-01-15 A | 2013-01-15 A | MOB-ST-PR-0010 FS+40d | 100% |  |  |  |  |  |  |  | 1 |  |  |
| MOB-PPB-BD110 |  | Submission of Logistic Plan | milestone | 0d | 2013-01-23 A | 2013-01-23 A | MOB-PPB-BD100 FS+7d | 100% |  | 2013-03-21 | 2013-03-21 |  |  |  |  | 1 |  |  |
| MOB-PPB-BD120 |  | Submission of Scope of Facilities | milestone | 0d | 2013-01-24 A | 2013-01-24 A | MOB-PPB-BD110 | 100% |  | 2013-03-21 | 2013-03-21 |  |  |  |  | 1 |  |  |
| MOB-PPB-BD130 |  | Submission of Progress Management System | milestone | 0d | 2013-01-24 A | 2013-01-24 A | MOB-PPB-BD120 FF | 100% |  | 2013-03-21 | 2013-03-21 |  |  |  |  | 1 |  |  |
| MOB-PPB-BD140 |  | Submission of Quality Assurance Management Plan | milestone | 0d | 2013-01-25 A | 2013-01-25 A | MOB-PPB-BD130 | 100% |  |  |  |  |  |  |  | 1 |  |  |
| MOB-PPB-BD150 |  | Submission of Project Execution Plan | milestone | 0d | 2013-01-27 A | 2013-01-27 A |  | 100% |  | 2013-03-21 | 2013-03-21 |  |  |  |  | 1 |  |  |
| MOB-PPB-BD160 |  | Submission of Change Management System | milestone | 0d | 2013-04-11 | 2013-04-11 | MOB-PPB-BD150 FS+20d, MOB-PPB-BD100 FS+85d |  |  |  |  | 80d | 0d |  |  | 1 |  | 10 Nisan |
| MOB-PPB-BD170 |  | Submission of Project Space Plan | milestone | 0d | 2013-04-11 | 2013-04-11 | MOB-PPB-BD160 |  |  |  |  | 80d | 0d |  |  | 1 |  | 10 Nisan |
| MOB-PPB-BD180 |  | Submission of Scope of Services | milestone | 0d | 2013-04-11 | 2013-04-11 | MOB-PPB-BD170 |  |  |  |  | 80d | 0d |  |  | 1 |  | 10 Nisan |
| MOB-PPB-BD190 |  | Submission of Project Numbering Plan | milestone | 0d | 2013-04-11 | 2013-04-11 | MOB-PPB-BD180 |  |  |  |  | 80d | 109.38d |  |  | 1 |  | 10 Nisan |

Notes:
- MOB-PPB-MCI-100: Expenses: (New Expense Item) 1 / Notlar: Successors atanacak
- MOB-PPB-MCI-110: Expenses: (New Expense Item) 1
- MOB-PPB-MCI-120: Expenses: (New Expense Item) 1
- A1240: Expenses: (New Expense Item) 1 / Notlar: Baþlangýç ve sona baðlandý baþka iliþki bulabilirsen iyi olur.
- MOB-HS-HS-0020: Expenses: (New Expense Item) 1
- MOB-HS-HS-0025: Expenses: (New Expense Item) 1
- MOB-HS-HS-0010: Expenses: (New Expense Item) 1
- MOB-HS-HS-0180: Expenses: (New Expense Item) 1
- MOB-HS-HS-0190: Expenses: (New Expense Item) 1
- MOB-PPB-BD100: Expenses: (New Expense Item) 1
- MOB-PPB-BD110: Expenses: (New Expense Item) 1
- MOB-PPB-BD120: Expenses: (New Expense Item) 1
- MOB-PPB-BD130: Expenses: (New Expense Item) 1
- MOB-PPB-BD140: Expenses: (New Expense Item) 1
- MOB-PPB-BD150: Expenses: (New Expense Item) 1
- MOB-PPB-BD160: Expenses: (New Expense Item) 1
- MOB-PPB-BD170: Expenses: (New Expense Item) 1
- MOB-PPB-BD180: Expenses: (New Expense Item) 1
- MOB-PPB-BD190: Expenses: (New Expense Item) 1

| ID | WBS | Activity | Duration | Start | Finish | Predecessors | Complete | Remaining | Planned start | Planned finish | Total float | Free float | Resources | Cost | Actual cost | Notlar |
| --- | --- | --- | --- | --- | --- | --- | --- | --- | --- | --- | --- | --- | --- | --- | --- | --- |
|  | 7 | **Site Preparation** |  | 2013-02-12 | 2013-05-10 |  |  |  |  |  |  |  |  |  |  |  |
|  | 1 | **Grading / Earthworks** |  | 2013-02-12 | 2013-04-30 |  |  |  |  |  |  |  |  |  |  |  |
| MOB-ST-SE-0010 |  | Determine laydown & dressing areas | 18.75d | 2013-02-12 A | 2013-02-26 A | MOB-ST-PR-0060 SS+21d | 100% |  | 2013-03-21 | 2013-04-08 |  |  | Mobilizasyon Yeni WBS [150 h] | 3,000 | 3,000 |  |
| MOB-SP-GE-110 |  | Strip top soil | 20d | 2013-03-10 A | 2013-04-19 | MOB-ST-SE-0010 | 55% | 9d | 2013-03-21 | 2013-04-09 | -29.38d | 0d | Mobilizasyon Yeni WBS [160 h] | 3,200 | 1,760 |  |
| MOB-SP-GE-120 |  | Eartworks Cut/Fill | 20d | 2013-04-05 A | 2013-04-30 | MOB-SP-GE-110 |  | 20d | 2013-04-04 | 2013-04-24 | 31d | 89.38d | Mobilizasyon Yeni WBS [160 h] | 3,200 |  |  |
| MOB-SP-GE-130 |  | Grading and Compaction | 10d | 2013-04-09 A | 2013-04-20 | MOB-SP-GE-120 |  | 10d | 2013-04-24 | 2013-05-04 | 132d | 99.38d | Mobilizasyon Yeni WBS [80 h] | 1,600 |  | Successor Yok |
|  | 2 | **Drainage** |  | 2013-02-25 | 2013-05-10 |  |  |  |  |  |  |  |  |  |  |  |
| MOB-SP-DR-100 |  | Drainage Design | 15d | 2013-02-25 A | 2013-03-11 A | MOB-ST-PR-0060 SS+30d | 100% |  | 2013-03-21 | 2013-04-04 |  |  | Mobilizasyon Yeni WBS [120 h] | 2,400 | 2,400 |  |
| MOB-SP-DR-110 |  | Construction of Drainage Trenches (For Storm Water) | 30d | 2013-04-11 | 2013-05-10 | MOB-SP-DR-100 FS+30d |  |  |  |  | 112d | 79.38d | Mobilizasyon Yeni WBS [240 h] | 4,800 |  | Baþladý mý Baþlamadý mý????? |
|  | 3 | **Temporary Utilities** |  | 2013-02-22 | 2013-07-16 |  |  |  |  |  |  |  |  |  |  |  |
|  | 1 | **Construction Water** |  | 2013-02-27 | 2013-07-03 |  |  |  |  |  |  |  |  |  |  |  |
| MOB-TU-CW-100 |  | Determine Construction Water Connection Point & Design | 15d | 2013-02-27 A | 2013-03-11 A | MOB-ST-PR-0060 SS+25d | 100% |  | 2013-02-27 | 2013-03-13 |  |  | Mobilizasyon Yeni WBS [120 h] | 2,400 |  |  |
| MOB-TU-CW-110 |  | Piping Material Purchase Order Including Pumps | 15d | 2013-04-11 | 2013-04-25 | MOB-TU-CW-100 FS+25d |  |  | 2013-04-04 | 2013-04-18 | -4d | 0d | Mobilizasyon Yeni WBS [120 h] | 2,400 |  |  |
| MOB-TU-CW-120 |  | Piping Material Delivery to Site Including Pumps | 30d | 2013-04-26 | 2013-05-25 | MOB-TU-CW-110 |  |  | 2013-04-19 | 2013-05-18 | -4d | 0d | Mobilizasyon Yeni WBS [240 h] | 4,800 |  |  |
| MOB-TU-CW-130 |  | Excavation for Underground Pipeline | 20d | 2013-05-06 | 2013-05-25 | MOB-TU-CW-120 FS-20d |  |  | 2013-04-30 | 2013-05-19 | -4d | 0d | Mobilizasyon Yeni WBS [160 h] | 3,200 |  |  |
| MOB-TU-CW-140 |  | Pump Foundation | 7d | 2013-05-16 | 2013-05-22 | MOB-TU-CW-130 SS+10d |  |  | 2013-05-09 | 2013-05-15 | 13d | 17d | Mobilizasyon Yeni WBS [56 h] | 1,120 |  |  |
| MOB-TU-CW-150 |  | Installation of Pipeline | 20d | 2013-05-26 | 2013-06-14 | MOB-TU-CW-130, MOB-TU-CW-120 |  |  | 2013-05-19 | 2013-06-07 | -4d | 0d | Mobilizasyon Yeni WBS [160 h] | 3,200 |  |  |
| MOB-TU-CW-160 |  | Pumps Installation | 6d | 2013-06-09 | 2013-06-14 | MOB-TU-CW-140, MOB-TU-CW-150 FF |  |  | 2013-06-02 | 2013-06-07 | -4d | 0d | Mobilizasyon Yeni WBS [48 h] | 960 |  |  |
| MOB-TU-CW-210 |  | Electrical Power Supply for Pumps | 14d | 2013-06-15 | 2013-06-28 | MOB-TU-CW-160 |  |  | 2013-06-08 | 2013-06-21 | -4d | 0d | Mobilizasyon Yeni WBS [112 h] | 2,240 |  |  |
| MOB-TU-CW-220 |  | Test | 5d | 2013-06-29 | 2013-07-03 | MOB-TU-CW-210 |  |  | 2013-06-22 | 2013-06-26 | -4d | 25.38d | Mobilizasyon Yeni WBS [40 h] | 800 |  |  |
|  | 2 | **Potable Water** |  | 2013-02-22 | 2013-06-30 |  |  |  |  |  |  |  |  |  |  |  |
| MOB-TU-PW-100 |  | Determine Potable Water Connection Point & Design | 15d | 2013-02-22 A | 2013-03-11 A | MOB-TU-CW-100 SS | 100% |  | 2013-02-27 | 2013-03-13 |  |  | Mobilizasyon Yeni WBS [120 h] | 2,400 |  |  |
| MOB-TU-PW-170 |  | Potable Water Tank Design | 10d | 2013-04-11 | 2013-04-20 | MOB-TU-PW-100 SS+40d |  |  |  |  | 12d | 0d | Mobilizasyon Yeni WBS [80 h] | 1,600 |  |  |
| MOB-TU-PW-110 |  | Piping Material Purchase Order Including Pumps | 15d | 2013-04-14 | 2013-04-29 | MOB-TU-PW-100 FS+35d |  |  |  |  | -0.75d | 0d | Mobilizasyon Yeni WBS [120 h] | 2,400 |  |  |
| MOB-TU-PW-180 |  | Potable Water Tank Purchase Order | 15d | 2013-04-21 | 2013-05-05 | MOB-TU-PW-170 |  |  |  |  | 12d | 0d | Mobilizasyon Yeni WBS [120 h] | 2,400 |  |  |
| MOB-TU-PW-120 |  | Piping Material Delivery to Site Including Pumps | 30d | 2013-04-29 | 2013-05-29 | MOB-TU-PW-110 |  |  |  |  | -0.75d | 0d | Mobilizasyon Yeni WBS [240 h] | 4,800 |  |  |
| MOB-TU-PW-190 |  | Potable Water Tank Delivery | 30d | 2013-05-06 | 2013-06-04 | MOB-TU-PW-180 |  |  |  |  | 12d | 0d | Mobilizasyon Yeni WBS [240 h] | 4,800 |  |  |
| MOB-TU-PW-130 |  | Excavation for Underground Pipeline | 20d | 2013-05-09 | 2013-05-29 | MOB-TU-PW-120 FS-20d |  |  |  |  | -0.75d | 0d | Mobilizasyon Yeni WBS [160 h] | 3,200 |  |  |
| MOB-TU-PW-140 |  | Pump Foundation | 7d | 2013-05-19 | 2013-05-26 | MOB-TU-PW-130 SS+10d |  |  |  |  | 16.25d | 17d | Mobilizasyon Yeni WBS [56 h] | 1,120 |  |  |
| MOB-TU-PW-150 |  | Installation of Pipeline | 20d | 2013-05-29 | 2013-06-18 | MOB-TU-PW-120, MOB-TU-PW-130 |  |  |  |  | -0.75d | 0d | Mobilizasyon Yeni WBS [160 h] | 3,200 |  |  |
| MOB-TU-PW-160 |  | Pumps Installation | 6d | 2013-06-12 | 2013-06-18 | MOB-TU-PW-150 FF, MOB-TU-PW-140 |  |  |  |  | -0.75d | 0d | Mobilizasyon Yeni WBS [48 h] | 960 |  |  |
| MOB-TU-PW-200 |  | Potable Water Tank Installation | 3d | 2013-06-15 | 2013-06-17 | MOB-TU-PW-190 FS+10d |  |  |  |  | 12d | 41.38d | Mobilizasyon Yeni WBS [24 h] | 480 |  |  |
| MOB-TU-PW-210 |  | Electrical Power Supply for Pumps | 7d | 2013-06-18 | 2013-06-25 | MOB-TU-PW-160 |  |  |  |  | -0.75d | 0d | Mobilizasyon Yeni WBS [56 h] | 1,120 |  |  |
| MOB-TU-PW-220 |  | Test of Potable Water System | 5d | 2013-06-25 | 2013-06-30 | MOB-TU-PW-210 |  |  |  |  | -0.75d | 28.62d | Mobilizasyon Yeni WBS [40 h] | 800 |  |  |

| ID | WBS | Activity | Duration | Start | Finish | Predecessors | Complete | Remaining | Planned start | Planned finish | Total float | Free float | Resources | Cost | NOT |
| --- | --- | --- | --- | --- | --- | --- | --- | --- | --- | --- | --- | --- | --- | --- | --- |
|  | 3 | **Electricity** |  | 2013-02-23 | 2013-07-04 |  |  |  |  |  |  |  |  |  |  |
| MOB-TU-ELC-100 |  | Temporary Camp Facility Electricity Design | 15d | 2013-02-23 A | 2013-03-11 A | MOB-TU-PW-100 SS | 100% |  | 2013-03-21 | 2013-04-04 |  |  | Mobilizasyon Yeni WBS [120 h] | 2,400 |  |
| MOB-TU-ELC-110 |  | Purchase Order for Camp Facility Electrical Material ( Will be Purchased From Almaty) | 10d | 2013-04-11 | 2013-04-20 | MOB-TU-ELC-100 FS+20d |  |  | 2013-04-04 | 2013-04-13 | -12d | 0d | Mobilizasyon Yeni WBS [80 h] | 1,600 | 15 april bitiþ |
| MOB-TU-ELC-120 |  | Camp Facility Electrical Material Delivery to Site | 15d | 2013-04-21 | 2013-05-05 | MOB-TU-ELC-110 |  |  | 2013-04-14 | 2013-04-28 | -12d | 0d | Mobilizasyon Yeni WBS [120 h] | 2,400 | 3 hafta sürecek |
| MOB-TU-ELC-180 |  | Generator Supply for Temporary Power | 50d | 2013-05-01 | 2013-06-19 | MOB-TU-ELC-120 SS+10d |  |  | 2013-04-24 | 2013-06-12 | 5d | 10d | Mobilizasyon Yeni WBS [400 h] | 8,000 |  |
| MOB-TU-ELC-130 |  | Electrical Cable Installation for Camp Buildings | 50d | 2013-05-06 | 2013-06-24 | MOB-TU-ELC-120 |  |  | 2013-04-30 | 2013-06-18 | -12d | 0d | Mobilizasyon Yeni WBS [400 h] | 8,000 |  |
| MOB-TU-ELC-170 |  | Earthing | 50d | 2013-05-11 | 2013-06-29 | MOB-TU-ELC-130 SS+5d |  |  | 2013-05-04 | 2013-06-22 | -5d | 0d | Mobilizasyon Yeni WBS [400 h] | 8,000 |  |
| MOB-TU-ELC-140 |  | Mounting Electrical Accessiories | 50d | 2013-05-16 | 2013-07-04 | MOB-TU-ELC-130 SS+10d |  |  | 2013-05-09 | 2013-06-27 | -5d | 0d | Mobilizasyon Yeni WBS [400 h] | 8,000 |  |
| MOB-TU-ELC-150 |  | Electrical Control Panel Foundation | 7d | 2013-05-16 | 2013-05-22 | MOB-TU-ELC-120 FS+10d |  |  | 2013-05-09 | 2013-05-15 | 25d | 0d | Mobilizasyon Yeni WBS [56 h] | 1,120 |  |
| MOB-TU-ELC-160 |  | Electrical Control Panel Installation | 10d | 2013-05-26 | 2013-06-04 | MOB-TU-ELC-150 FS+3d |  |  | 2013-05-19 | 2013-05-28 | 25d | 54.38d | Mobilizasyon Yeni WBS [80 h] | 1,600 |  |
| MOB-TU-ELC-190 |  | Test | 5d | 2013-06-30 | 2013-07-04 | MOB-TU-ELC-170, MOB-TU-ELC-180 |  |  | 2013-06-23 | 2013-06-27 | -5d | 24.38d | Mobilizasyon Yeni WBS [40 h] | 800 |  |
|  | 4 | **Sewage** |  | 2013-02-23 | 2013-07-16 |  |  |  |  |  |  |  |  |  |  |
| MOB-TU-SE-100 |  | Temporary Camp Sewage System Design | 15d | 2013-02-23 A | 2013-03-11 A | MOB-TU-ELC-100 SS | 100% |  | 2013-03-21 | 2013-04-04 |  |  | Mobilizasyon Yeni WBS [120 h] | 2,400 |  |
| MOB-TU-SE-150 |  | Sewage Treatment Plant Design | 15d | 2013-04-01 A | 2013-04-25 | MOB-TU-SE-100 FS+20d |  | 15d | 2013-03-31 | 2013-04-14 | -17d | 0d | Mobilizasyon Yeni WBS [120 h] | 2,400 |  |
| MOB-TU-SE-130 |  | Pipe Material Supply and Delivery to Site for Connections | 35d | 2013-04-11 | 2013-05-15 | MOB-TU-SE-100 FS+25d |  |  | 2013-04-04 | 2013-05-08 | -5d | 0d | Mobilizasyon Yeni WBS [280 h] | 5,600 |  |
| MOB-TU-SE-110 |  | Excavation for Sewage Pit | 3d | 2013-04-24 | 2013-04-27 | MOB-TU-SE-100 FS+45d |  |  | 2013-04-17 | 2013-04-19 | 31.25d | 0d | Mobilizasyon Yeni WBS [24 h] | 480 |  |
| MOB-TU-SE-160 |  | Purchase Order of Sewage Treatment Plant | 15d | 2013-04-26 | 2013-05-10 | MOB-TU-SE-150 |  |  | 2013-04-19 | 2013-05-03 | -17d | 0d | Mobilizasyon Yeni WBS [120 h] | 2,400 |  |
| MOB-TU-SE-120 |  | Concrete Works of Sewage Pit | 20d | 2013-04-27 | 2013-05-17 | MOB-TU-SE-110 |  |  | 2013-04-20 | 2013-05-09 | 31.25d | 45.25d | Mobilizasyon Yeni WBS [160 h] | 3,200 |  |
| MOB-TU-SE-170 |  | Sewage Treatment Plant Delivery to Site | 30d | 2013-05-11 | 2013-06-09 | MOB-TU-SE-160 |  |  | 2013-05-04 | 2013-06-02 | -17d | 0d | Mobilizasyon Yeni WBS [240 h] | 4,800 |  |
| MOB-TU-SE-140 |  | Sewage Systems Connections to Camp Buildings, Offices etc. | 50d | 2013-05-16 | 2013-07-04 | MOB-TU-SE-130 |  |  | 2013-05-09 | 2013-06-27 | -5d | 3d | Mobilizasyon Yeni WBS [400 h] | 8,000 | June sonuna kadar gitsin |
| MOB-TU-SE-180 |  | Foundation for Sewage Treatment Plant | 10d | 2013-06-15 | 2013-06-24 | MOB-TU-SE-170 FS+5d |  |  | 2013-06-01 | 2013-06-10 | -17d | 0d | Mobilizasyon Yeni WBS [80 h] | 1,600 |  |
| MOB-TU-SE-190 |  | Sewage Treatment Plant Installation | 7d | 2013-06-25 | 2013-07-01 | MOB-TU-SE-180 |  |  | 2013-06-11 | 2013-06-17 | -17d | 0d | Mobilizasyon Yeni WBS [56 h] | 1,120 |  |
| MOB-TU-SE-200 |  | Electrical Power Supply for Treatment Plant | 10d | 2013-07-02 | 2013-07-11 | MOB-TU-SE-190 |  |  | 2013-06-18 | 2013-06-27 | -17d | 0d | Mobilizasyon Yeni WBS [80 h] | 1,600 |  |
| MOB-TU-SE-220 |  | Sewage Pit Connection to Treatment Plant | 7d | 2013-07-02 | 2013-07-08 | MOB-TU-SE-120, MOB-TU-SE-190 |  |  | 2013-06-18 | 2013-06-24 | -14d | 0d | Mobilizasyon Yeni WBS [56 h] | 1,120 |  |
| MOB-TU-SE-230 |  | Test of Sewage System | 5d | 2013-07-09 | 2013-07-13 | MOB-TU-SE-220 |  |  | 2013-06-24 | 2013-06-28 | -14d | 15.38d | Mobilizasyon Yeni WBS [40 h] | 800 |  |
| MOB-TU-SE-210 |  | Test of Sewage Treatment Plant | 5d | 2013-07-12 | 2013-07-16 | MOB-TU-SE-200 |  |  | 2013-06-20 | 2013-06-24 | -17d | 12.38d | Mobilizasyon Yeni WBS [40 h] | 800 |  |

| ID | WBS | Activity | Duration | Start | Finish | Predecessors | Complete | Remaining | Planned start | Planned finish | Total float | Free float | Resources | Cost | Actual cost | NOT |
| --- | --- | --- | --- | --- | --- | --- | --- | --- | --- | --- | --- | --- | --- | --- | --- | --- |
|  | 6 | **Communication and IT** |  | 2013-03-01 | 2013-07-29 |  |  |  |  |  |  |  |  |  |  |  |
|  | 1 | **Telephone** |  | 2013-03-01 | 2013-05-30 |  |  |  |  |  |  |  |  |  |  |  |
| MOB-IT-TL-100 |  | Telephone Exchange System Delivery to Site | 40d | 2013-03-01 A | 2013-04-30 | MOB-ST-PR-0060 FS-15d | 50% | 20d | 2013-03-21 | 2013-04-29 | 55d | 25d | Mobilizasyon Yeni WBS [320 h] | 6,400 |  |  |
| MOB-IT-TL-110 |  | Establishment of Telephone Exchange System | 5d | 2013-05-26 | 2013-05-30 | MOB-OF-AOB-II-160, MOB-OF-AOB-IV-160, MOB-IT-TL-100 |  |  |  |  | 30d | 59.38d | Mobilizasyon Yeni WBS [40 h] | 800 |  |  |
|  | 2 | **Internet** |  | 2013-03-18 | 2013-07-29 |  |  |  |  |  |  |  |  |  |  |  |
| MOB-IT-IN-100 |  | Establish Satellite 4+4 Mbit System for Internet transmissions | 12.12d | 2013-03-18 A | 2013-04-05 A | MOB-ST-PR-0010 FS+100d | 100% |  | 2013-03-21 | 2013-04-01 |  |  | Mobilizasyon Yeni WBS [97 h] | 1,940 | 1,940 |  |
| MOB-IT-IN-110 |  | SMATV Establishment for Dormitories | 18.38d | 2013-07-01 | 2013-07-19 | MOB-TA-WD-190, MOB-TA-DOT2-190, MOB-TA-DOT-190, MOB-TA-SC-140, MOB-TA-WDR-190 |  |  | 2013-06-01 | 2013-06-19 | -29.38d | 0d | Mobilizasyon Yeni WBS [147 h] | 2,940 |  |  |
| MOB-IT-IN-120 |  | Establishment of Wifi Internet for Dormitories | 10d | 2013-07-19 | 2013-07-29 | MOB-IT-IN-110, MOB-IT-IN-100 |  |  | 2013-06-19 | 2013-06-28 | -29.38d | 0d | Mobilizasyon Yeni WBS [80 h] | 1,600 |  |  |
|  | 3 | **IT Server and network equipment** |  | 2013-03-01 | 2013-06-22 |  |  |  |  |  |  |  |  |  |  |  |
| MOB-IT-NE-100 |  | Delivery of First 20 Computer for Mobilization First Party | 37.12d | 2013-03-01 A | 2013-04-01 A | MOB-ST-PR-0010 FS+90d | 100% |  | 2013-03-21 | 2013-04-26 |  |  | Mobilizasyon Yeni WBS [297 h] | 5,940 | 5,940 |  |
| MOB-IT-NE-140 |  | UPS Power System Delivery to Site | 49.38d | 2013-03-01 A | 2013-05-05 | MOB-ST-PR-0060 FS-10d | 51% | 24.38d | 2013-03-21 | 2013-05-09 | 28.5d | 20.62d | Mobilizasyon Yeni WBS [395 h] | 7,900 | 3,950 |  |
| MOB-IT-NE-120 |  | Delivery of Palo Alto Firewall | 36.88d | 2013-03-15 A | 2013-05-10 | MOB-IT-NE-100 SS+15d | 20% | 29.38d | 2013-03-21 | 2013-04-26 | 16d | 0d | Mobilizasyon Yeni WBS [295 h] | 5,900 | 1,180 |  |
| MOB-IT-NE-110 |  | Establish Network for First 20 Computer | 14.62d | 2013-03-18 A | 2013-04-16 | MOB-IT-NE-100 FF | 60% | 5.88d | 2013-03-21 | 2013-04-04 | 59.5d | 43.5d | Mobilizasyon Yeni WBS [117 h] | 2,340 | 1,384.9 |  |
| MOB-IT-NE-130 |  | Establishment of Palo Alto Firewall | 14.62d | 2013-05-30 | 2013-06-13 | MOB-OF-AOB-IV-160, MOB-IT-NE-110, MOB-OF-AOB-II-160, MOB-IT-NE-120 FS+20d |  |  |  |  | 16d | 45.38d | Mobilizasyon Yeni WBS [117 h] | 2,340 |  |  |
| MOB-IT-NE-150 |  | Establishment of UPS Power System | 12.12d | 2013-06-10 | 2013-06-22 | MOB-IT-NE-140 FS+15d, MOB-OF-AOB-IV-180 FS+10d, MOB-OF-AOB-II-180 FS+10d |  |  |  |  | 7.88d | 37.25d | Mobilizasyon Yeni WBS [97 h] | 1,940 |  |  |
|  | 4 | **Construction Radio Network** |  | 2013-03-15 | 2013-06-12 |  |  |  |  |  |  |  |  |  |  |  |
| MOB-IT-CRN-100 |  | Inquriy Period for Radio System | 20d | 2013-03-15 A | 2013-04-18 | MOB-IT-TL-100 SS+15d | 60% | 8d | 2013-03-27 | 2013-04-15 | 17d | 0d | Mobilizasyon Yeni WBS [160 h] | 3,200 |  |  |
| MOB-IT-CRN-110 |  | Purchase Order of Radio Network | 15d | 2013-04-19 | 2013-05-03 | MOB-IT-CRN-100 |  |  |  |  | 17d | 0d | Mobilizasyon Yeni WBS [120 h] | 2,400 |  |  |
| MOB-IT-CRN-120 |  | Radio System Delivery to Site | 30d | 2013-05-04 | 2013-06-02 | MOB-IT-CRN-110 |  |  |  |  | 17d | 0d | Mobilizasyon Yeni WBS [240 h] | 4,800 |  |  |
| MOB-IT-CRN-130 |  | Establishment of Radio System | 10d | 2013-06-03 | 2013-06-12 | MOB-IT-CRN-120, MOB-TU-ELC-130 SS+15d |  |  |  |  | 17d | 46.38d | Mobilizasyon Yeni WBS [80 h] | 1,600 |  | üstüne araþtýrýlmasý ve satýn alýnmasýný yaz |
|  | 5 | **Batch Plant** |  | 2013-04-01 | 2013-07-09 |  |  |  |  |  |  |  |  |  |  |  |
|  | 1 | **Assembly and Construction** |  | 2013-04-01 | 2013-07-04 |  |  |  |  |  |  |  |  |  |  |  |
|  | 1 | **Earthworks and Civils** |  | 2013-04-01 | 2013-05-05 |  |  |  |  |  |  |  |  |  |  |  |
| MOB-BP-EC-100 |  | Determine Batching Plants Location and Access | 7d | 2013-04-01 A | 2013-04-08 A | MOB-ST-PR-0060 SS+50d | 100% |  | 2013-03-27 | 2013-04-02 |  |  | Mobilizasyon Yeni WBS [56 h] | 1,120 | 1,120 |  |
| MOB-BP-EC-110 |  | Earthworks on Batching Plant Area (120m3) | 10d | 2013-04-10 A | 2013-04-20 | MOB-SP-GE-110 FS-4d, MOB-BP-EC-100 |  | 10d | 2013-04-02 | 2013-04-12 | -5d | 0d | Mobilizasyon Yeni WBS [80 h] | 1,600 |  | 1 nisan 10 nisan |
| MOB-BP-EC-130 |  | Earthworks on Batching Plant Area (105m3) | 10d | 2013-04-10 A | 2013-04-20 | MOB-BP-EC-100, MOB-BP-EC-110 SS |  | 10d | 2013-04-09 | 2013-04-19 | -10d | 0d | Mobilizasyon Yeni WBS [80 h] | 1,600 |  |  |
| MOB-BP-EC-120 |  | Foundation of Batching Plant (120 m3) | 15d | 2013-04-21 | 2013-05-05 | MOB-BP-EC-110 |  |  |  |  | -5d | 0d | Mobilizasyon Yeni WBS [120 h] | 2,400 |  | 15 gün sürecek |
| MOB-BP-EC-140 |  | Foundation of Batching Plant (105 m3) | 15d | 2013-04-21 | 2013-05-05 | MOB-BP-EC-130 |  |  |  |  | -10d | 0d | Mobilizasyon Yeni WBS [120 h] | 2,400 |  | 15 gün sürecek |

| ID | WBS | Activity | Type | Duration | Start | Finish | Predecessors | Planned start | Planned finish | Total float | Free float | Resources | Cost | Notlar |
| --- | --- | --- | --- | --- | --- | --- | --- | --- | --- | --- | --- | --- | --- | --- |
|  | 2 | **Structural and Platework** |  |  | 2013-05-06 | 2013-05-30 |  |  |  |  |  |  |  |  |
| MOB-BP-SP-100 |  | Installation of Structural work and Silo's (120m3) |  | 25d | 2013-05-06 | 2013-05-30 | MOB-HE-CBP-110, MOB-BP-EC-120 |  |  | -5d | 0d | Mobilizasyon Yeni WBS [200 h] | 4,000 |  |
| MOB-BP-SP-110 |  | Installation of Structural work and Silo's (105m3) |  | 25d | 2013-05-06 | 2013-05-30 | MOB-BP-EC-140, MOB-HE-CBP-130 |  |  | -10d | 0d | Mobilizasyon Yeni WBS [200 h] | 4,000 |  |
|  | 3 | **Mechanical and Piping** |  |  | 2013-05-21 | 2013-06-19 |  |  |  |  |  |  |  |  |
| MOB-BP-MP-100 |  | Installation of Mechanical Equipment and Piping (120m3) |  | 25d | 2013-05-21 | 2013-06-14 | MOB-BP-SP-100 SS+15d |  |  | -5d | 5d | Mobilizasyon Yeni WBS [200 h] | 4,000 |  |
| MOB-BP-MP-110 |  | Installation of Mechanical Equipment and Piping (105m3) |  | 25d | 2013-05-26 | 2013-06-19 | MOB-BP-SP-110 SS+20d |  |  | -10d | 0d | Mobilizasyon Yeni WBS [200 h] | 4,000 |  |
| MOB-BP-MP-120 |  | Ensure Water Supply is available for Batching Plants | milestone | 0d | 2013-06-19 | 2013-06-19 | MOB-BP-MP-100 FF, MOB-BP-MP-110 FF |  |  | -10d | 0d |  | 1 |  |
|  | 4 | **Electrical and Instrumentation** |  |  | 2013-06-20 | 2013-07-04 |  |  |  |  |  |  |  |  |
| MOB-BP-EI-100 |  | Installation of Electrical and Instrumentation work for 120 m3 Batch Plant |  | 15d | 2013-06-20 | 2013-07-04 | MOB-BP-MP-120, MOB-BP-MP-100 SS+10d | 2013-06-13 | 2013-06-27 | -10d | 0d | Mobilizasyon Yeni WBS [120 h] | 2,400 |  |
| MOB-BP-EI-110 |  | Installation of Electrical and Instrumentation work for 105 m3 Batch Plant |  | 15d | 2013-06-20 | 2013-07-04 | MOB-BP-MP-110 SS+20d, MOB-BP-MP-120 | 2013-06-13 | 2013-06-27 | -10d | 0d | Mobilizasyon Yeni WBS [120 h] | 2,400 |  |
|  | 2 | **Testing and Certification** |  |  | 2013-07-05 | 2013-07-09 |  |  |  |  |  |  |  |  |
| MOB-BP-TC-100 |  | Commissioning for Batching Plants |  | 5d | 2013-07-05 | 2013-07-09 | MOB-BP-EI-110, MOB-BP-EI-100 | 2013-06-24 | 2013-06-28 | -10d | 19.38d | Mobilizasyon Yeni WBS [40 h] | 800 | Successor Yok |
|  | 1 | **Permits** |  |  |  |  |  |  |  |  |  |  |  |  |
|  | 4 | **Quarry and Mining (for Batch Plant aggregate and sand)** |  |  | 2013-04-20 | 2013-07-09 |  |  |  |  |  |  |  |  |
|  | 2 | **Mining Plan** |  |  | 2013-04-21 | 2013-07-09 |  |  |  |  |  |  |  |  |
| MOB-QM-MP-100 |  | Mining Operation Plan/Location and Feasibility |  | 30d | 2013-04-21 | 2013-05-20 | MOB-ST-OE-0019 FS+10d |  |  | -10d | 0d | Mobilizasyon Yeni WBS [8 h] | 160 |  |
| MOB-QM-MP-120 |  | Mining Safety Plan&Trainings |  | 30d | 2013-05-16 | 2013-06-14 | MOB-QM-MP-100 FS-5d |  |  | 10d | 0d | Mobilizasyon Yeni WBS [240 h] | 4,800 |  |
| MOB-QM-MP-130 |  | Risk Assesment for Mining |  | 10d | 2013-05-16 | 2013-05-25 | MOB-QM-MP-120 SS |  |  | 35d | 45d | Mobilizasyon Yeni WBS [80 h] | 1,600 |  |
| MOB-QM-MP-110 |  | Start of Quarry and Mining Activities | milestone | 0d | 2013-07-09 | 2013-07-09 | MOB-QM-EP-110, MOB-QM-MP-120 FS+5d, MOB-QM-PR-100 FS+15d, MOB-QM-EP-100, MOB-QM-MP-130 | 2013-06-29 | 2013-06-29 | -10d | 19.38d |  | 1 |  |
|  | 1 | **Permit** |  |  | 2013-05-11 | 2013-06-24 |  |  |  |  |  |  |  |  |
| MOB-QM-PR-100 |  | Local Permisions for Mining |  | 45d | 2013-05-11 | 2013-06-24 | MOB-QM-MP-100 FS-10d |  |  | -10d | 0d | Mobilizasyon Yeni WBS [8 h] | 160 |  |
|  | 3 | **Equipment and Personnel** |  |  | 2013-04-20 | 2013-04-25 |  |  |  |  |  |  |  |  |
| MOB-QM-EP-100 |  | Equipments for Mining on site | milestone | 0d | 2013-04-20 | 2013-04-20 | MOB-ST-OE-0019 FS+10d |  |  | 65d | 0d |  | 1 |  |
| MOB-QM-EP-110 |  | Mining Personel on site |  | 5d | 2013-04-21 | 2013-04-25 | MOB-QM-EP-100 |  |  | 65d | 75d | Mobilizasyon Yeni WBS [40 h] | 800 |  |

Notes:
- MOB-BP-MP-120: Expenses: (New Expense Item) 1
- MOB-QM-MP-110: Expenses: (New Expense Item) 1
- MOB-QM-EP-100: Expenses: (New Expense Item) 1

| ID | WBS | Activity | Type | Duration | Start | Finish | Predecessors | Complete | Planned start | Planned finish | Total float | Free float | Constraint | Resources | Cost | user_text7 | NOT |
| --- | --- | --- | --- | --- | --- | --- | --- | --- | --- | --- | --- | --- | --- | --- | --- | --- | --- |
|  | 8 | **Temporary Roads (on site)** |  |  | 2013-04-11 | 2013-07-04 |  |  |  |  |  |  |  |  |  |  |  |
| MOB-TR-TR-110 |  | Surveying Works for Temporary Roads |  | 80d | 2013-04-11 | 2013-06-29 | MOB-ST-OE-0019 |  |  |  | -5d | 0d |  | Mobilizasyon Yeni WBS [640 h] | 12,800 | baseline |  |
| MOB-TR-TR-120 |  | Strip Top Soil for Temporary Roads |  | 15d | 2013-05-06 | 2013-05-20 | MOB-TR-TR-110 SS+25d |  | 2013-04-30 | 2013-05-14 | -5d | 0d | start on or after 2013-04-30 | Mobilizasyon Yeni WBS [120 h] | 2,400 | baseline |  |
| MOB-TR-TR-130 |  | Compacted Subgrade |  | 15d | 2013-05-21 | 2013-06-04 | MOB-TR-TR-120 |  | 2013-05-14 | 2013-05-28 | -5d | 0d | start on or after 2013-05-14 | Mobilizasyon Yeni WBS [120 h] | 2,400 | baseline |  |
| MOB-TR-TR-140 |  | Subbase Course |  | 15d | 2013-06-05 | 2013-06-19 | MOB-TR-TR-130 |  | 2013-05-29 | 2013-06-12 | -5d | 0d | start on or after 2013-05-29 | Mobilizasyon Yeni WBS [120 h] | 2,400 | baseline |  |
| MOB-TR-TR-150 |  | Roadbase |  | 15d | 2013-06-20 | 2013-07-04 | MOB-TR-TR-140, MOB-TR-TR-110 FF |  | 2013-06-13 | 2013-06-27 | -5d | 24.38d | start on or after 2013-06-13 | Mobilizasyon Yeni WBS [120 h] | 2,400 | baseline |  |
|  | 9 | **Off-Site Facilities, Roads, Services** |  |  | 2013-03-06 | 2013-07-09 |  |  |  |  |  |  |  |  |  |  |  |
|  | 1 | **Train Station** |  |  | 2013-04-11 | 2013-05-15 |  |  |  |  |  |  |  |  |  |  |  |
| MOB-OR-TS-100 |  | Train Station Activation (by Kazakhmys) | milestone | 0d | 2013-04-11 | 2013-04-11 | MOB-ST-OE-0019 FS-15d |  |  |  | -28.25d | 10d | finish on 2013-03-13 |  | 1 |  | 13 mart'a constraint |
| MOB-OR-TS-110 |  | Locomotive Delivery |  | 30d | 2013-04-11 | 2013-05-10 | MOB-OR-TS-100 FS-10d |  |  |  | 45d | 0d |  | Mobilizasyon Yeni WBS [240 h] | 4,800 |  |  |
| MOB-OR-TS-120 |  | Appoint the Locomotive Operator | milestone | 0d | 2013-05-06 | 2013-05-06 | MOB-OR-TS-110 FS-5d |  |  |  | 45d | 0d |  |  | 1 |  |  |
| MOB-OR-TS-130 |  | Transportation Start by Railway to Jobsite | milestone | 0d | 2013-05-15 | 2013-05-15 | MOB-OR-TS-120 FS+10d |  |  |  | 45d | 74.38d |  |  | 1 |  |  |
|  | 2 | **Access Road to Site** |  |  | 2013-03-06 | 2013-07-09 |  |  |  |  |  |  |  |  |  |  |  |
| MOB-QR-AR-000 |  | Issue of Off-Site Infrastructure Drawings (by Kazakhmys) | milestone | 0d | 2013-03-06 A | 2013-03-06 A |  | 100% | 2013-03-27 | 2013-03-27 |  |  | mandatory finish 2013-01-04 |  | 1 | baseline |  |
| MOB-QR-AR-100 |  | Design of Off Site Roads (by Kazakhmys) | milestone | 0d | 2013-04-11 | 2013-04-11 | MOB-ST-PR-0010 FS+80d |  | 2013-04-04 | 2013-04-04 | -22.25d | 0d | finish on 2013-03-20 |  | 1 | baseline |  |
| MOB-QR-AR-110 |  | Inquiry Period for Material |  | 15d | 2013-04-21 | 2013-05-05 | MOB-QR-AR-100 FS+10d |  | 2013-04-07 | 2013-04-21 | -10d | 0d |  | Mobilizasyon Yeni WBS [120 h] | 2,400 | baseline |  |
| MOB-QR-AR-120 |  | Material Supply |  | 30d | 2013-05-11 | 2013-06-09 | MOB-QR-AR-110 FS+5d |  | 2013-04-27 | 2013-05-26 | -10d | 0d | start on or after 2013-04-27 | Mobilizasyon Yeni WBS [240 h] | 4,800 | baseline |  |
| MOB-QR-AR-130 |  | Material Deliverable on Site |  | 30d | 2013-06-10 | 2013-07-09 | MOB-QR-AR-120 |  | 2013-05-26 | 2013-06-24 | -10d | 0d | start on or after 2013-05-26 | Mobilizasyon Yeni WBS [240 h] | 4,800 | baseline |  |
| MOB-QR-AR-140 |  | Off Site Road Construction ( Till Boundry Limit by Kazakmys) | milestone | 0d | 2013-07-09 | 2013-07-09 | MOB-QR-AR-130 |  | 2013-06-24 | 2013-06-24 | -10d | 19.38d |  |  | 1 | baseline |  |
|  | 3 | **Electric Power Line from Station to site substation** |  |  | 2013-04-11 | 2013-06-24 |  |  |  |  |  |  |  |  |  |  |  |
| MOB-QR-PL-150 |  | Design of Off Site Off Site Electrical Power Lines (by Kazakhmys) | milestone | 0d | 2013-04-11 | 2013-04-11 | MOB-ST-PR-0010 FS+80d, MOB-ST-OE-0019 FS-15d |  |  |  | 10d | 5d |  |  | 1 |  |  |
| MOB-QR-PL-160 |  | Inquiry Period for Material for Elc. Power Lines |  | 15d | 2013-04-16 | 2013-04-30 | MOB-TU-ELC-110 SS+5d, MOB-QR-PL-150 |  |  |  | 5d | 0d |  | Mobilizasyon Yeni WBS [120 h] | 2,400 |  |  |
| MOB-QR-PL-170 |  | Material Supply Elc. Power Lines |  | 15d | 2013-05-06 | 2013-05-20 | MOB-QR-PL-160 FS+5d |  |  |  | 5d | 0d |  | Mobilizasyon Yeni WBS [120 h] | 2,400 |  |  |
| MOB-QR-PL-180 |  | Material Deliverable on Site |  | 30d | 2013-05-21 | 2013-06-19 | MOB-QR-PL-170 |  |  |  | 5d | 0d |  | Mobilizasyon Yeni WBS [240 h] | 4,800 |  |  |
| MOB-QR-PL-190 |  | Start Off Site Power Line Construction | milestone | 0d | 2013-06-24 | 2013-06-24 | MOB-QR-PL-180 FS+5d, MOB-TU-ELC-130 SF+40d |  |  |  | 5d | 34.38d |  |  | 1 |  |  |

Notes:
- MOB-OR-TS-100: Expenses: (New Expense Item) 1
- MOB-OR-TS-120: Expenses: (New Expense Item) 1
- MOB-OR-TS-130: Expenses: (New Expense Item) 1
- MOB-QR-AR-000: Expenses: (New Expense Item) 1
- MOB-QR-AR-100: Expenses: (New Expense Item) 1
- MOB-QR-AR-140: Expenses: (New Expense Item) 1
- MOB-QR-PL-150: Expenses: (New Expense Item) 1
- MOB-QR-PL-190: Expenses: (New Expense Item) 1

| ID | WBS | Activity | Duration | Start | Finish | Predecessors | Complete | Remaining | Planned start | Planned finish | Total float | Free float | Resources | Cost |
| --- | --- | --- | --- | --- | --- | --- | --- | --- | --- | --- | --- | --- | --- | --- |
|  | 10 | **Temporary Accommodations** |  | 2013-01-20 | 2013-07-08 |  |  |  |  |  |  |  |  |  |
|  | 1 | **Accommodations** |  | 2013-01-20 | 2013-07-08 |  |  |  |  |  |  |  |  |  |
|  | 1 | **Managment and VIP Accommodation** |  | 2013-02-10 | 2013-06-30 |  |  |  |  |  |  |  |  |  |
|  | 1 | **Alarko Manager Dormitory Buildings (606 m2)** |  | 2013-02-10 | 2013-06-17 |  |  |  |  |  |  |  |  |  |
| MOB-TA-AMD-100 |  | Design for Alarko Manager Dormitory Building | 20d | 2013-02-10 A | 2013-03-01 A | MOB-ST-PR-0060 SS+15d | 100% |  | 2013-03-21 | 2013-04-09 |  |  | Mobilizasyon Yeni WBS [160 h] | 3,200 |
| MOB-TA-AMD-110 |  | Alarko Manager Dormitory Building Delivery | 40d | 2013-03-15 A | 2013-05-08 | MOB-TA-AMD-100 FS+20d | 30% | 28d | 2013-03-21 | 2013-04-29 | 12d | 0d | Mobilizasyon Yeni WBS [320 h] | 6,400 |
| MOB-TA-AMD-120 |  | Site Preperation-Earthworks for Manager Dormitory Building | 7d | 2013-04-25 | 2013-05-01 | MOB-SP-GE-110 FS+5d, MOB-TA-AMD-100 FS+50d |  |  |  |  | 0d | 3.75d | Mobilizasyon Yeni WBS [56 h] | 1,120 |
| MOB-TA-AMD-130 |  | Concrete Foundation of Alarko Manager Dormitory Building | 7d | 2013-05-07 | 2013-05-13 | MOB-TA-AMD-110 FF+5d, MOB-TA-AMD-120 |  |  |  |  | 12d | 0d | Mobilizasyon Yeni WBS [56 h] | 1,120 |
| MOB-TA-AMD-140 |  | Installation of Demounted Panels and Connection | 15d | 2013-05-19 | 2013-06-02 | MOB-TA-AMD-130 FS+5d |  |  |  |  | 12d | 0d | Mobilizasyon Yeni WBS [120 h] | 2,400 |
| MOB-TA-AMD-150 |  | Floor Covering for Alarko Manager Dormitory Building | 7d | 2013-06-03 | 2013-06-09 | MOB-TA-AMD-140 |  |  |  |  | 12d | 0d | Mobilizasyon Yeni WBS [56 h] | 1,120 |
| MOB-TA-AMD-160 |  | Electrical Cable Installation for Alarko Manager Dormitory Building | 10d | 2013-06-03 | 2013-06-12 | MOB-TU-ELC-130 SS+20d, MOB-TA-AMD-140 |  |  |  |  | 12d | 0d | Mobilizasyon Yeni WBS [80 h] | 1,600 |
| MOB-TA-AMD-170 |  | Mounting Electrical Accessiories for Alarko Manager Dormitory Building | 10d | 2013-06-08 | 2013-06-17 | MOB-TA-AMD-160 SS+5d, MOB-TU-ELC-140 SS+20d |  |  |  |  | 12d | 41.38d | Mobilizasyon Yeni WBS [80 h] | 1,600 |
| MOB-TA-AMD-180 |  | Installation of WC+Shower | 7d | 2013-06-08 | 2013-06-14 | MOB-TA-AMD-150 SS+5d, MOB-TU-SE-140 SS+20d |  |  |  |  | 12d | 0d | Mobilizasyon Yeni WBS [56 h] | 1,120 |
| MOB-TA-AMD-190 |  | Installation of Heating System | 10d | 2013-06-08 | 2013-06-17 | MOB-TA-AMD-180 SS |  |  |  |  | 12d | 13d | Mobilizasyon Yeni WBS [80 h] | 1,600 |
|  | 2 | **Employer Manager Dormitory Building (378 m2)** |  | 2013-02-10 | 2013-06-17 |  |  |  |  |  |  |  |  |  |
| MOB-TA-EMD-100 |  | Design for Employer Manager Dormitory Building | 20d | 2013-02-10 A | 2013-03-01 A | MOB-ST-PR-0060 SS+15d | 100% |  | 2013-03-21 | 2013-04-09 |  |  | Mobilizasyon Yeni WBS [160 h] | 3,200 |
| MOB-TA-EMD-110 |  | Employer Manager Dormitory Building Delivery | 40d | 2013-03-15 A | 2013-05-08 | MOB-TA-EMD-100 FS+20d | 30% | 28d | 2013-03-21 | 2013-04-29 | -3.75d | 0d | Mobilizasyon Yeni WBS [320 h] | 6,400 |
| MOB-TA-EMD-120 |  | Site Preperation-Earthworks for Employer Manager Dormitory Building | 7d | 2013-04-28 | 2013-05-05 | MOB-SP-GE-110 FS+7d, MOB-TA-EMD-110 SS+45d |  |  |  |  | -3.75d | 0d | Mobilizasyon Yeni WBS [56 h] | 1,120 |
| MOB-TA-EMD-130 |  | Concrete Foundation of Employer Manager Dormitory Building | 7d | 2013-05-07 | 2013-05-13 | MOB-TA-EMD-110 FF+5d, MOB-TA-EMD-120 |  |  |  |  | 12d | 0d | Mobilizasyon Yeni WBS [56 h] | 1,120 |
| MOB-TA-EMD-140 |  | Installation of Demounted Panels and Connection | 15d | 2013-05-19 | 2013-06-02 | MOB-TA-EMD-130 FS+5d |  |  |  |  | 12d | 0d | Mobilizasyon Yeni WBS [120 h] | 2,400 |
| MOB-TA-EMD-150 |  | Floor Covering for Manager Dormitory Building | 10d | 2013-06-03 | 2013-06-12 | MOB-TA-EMD-140 |  |  |  |  | 14d | 0d | Mobilizasyon Yeni WBS [80 h] | 1,600 |
| MOB-TA-EMD-160 |  | Electrical Cable Installation for Employer Manager Dormitory Building | 10d | 2013-06-03 | 2013-06-12 | MOB-TU-ELC-130 SS+20d, MOB-TA-EMD-140 |  |  |  |  | 12d | 0d | Mobilizasyon Yeni WBS [80 h] | 1,600 |
| MOB-TA-EMD-170 |  | Mounting Electrical Accessiories for Employer Manager Dormitory Building | 10d | 2013-06-08 | 2013-06-17 | MOB-TA-EMD-160 SS+5d, MOB-TU-ELC-140 SS+20d |  |  |  |  | 12d | 41.38d | Mobilizasyon Yeni WBS [80 h] | 1,600 |
| MOB-TA-EMD-180 |  | Installation of WC+Shower | 7d | 2013-06-08 | 2013-06-14 | MOB-TU-SE-140 SS+20d, MOB-TA-EMD-150 SS+5d |  |  |  |  | 14d | 0d | Mobilizasyon Yeni WBS [56 h] | 1,120 |
| MOB-TA-EMD-190 |  | Installation of Heating System | 8d | 2013-06-08 | 2013-06-15 | MOB-TA-EMD-180 SS |  |  |  |  | 14d | 15d | Mobilizasyon Yeni WBS [64 h] | 1,280 |

| ID | WBS | Activity | Duration | Start | Finish | Predecessors | Complete | Remaining | Planned start | Planned finish | Total float | Free float | Resources | Cost |
| --- | --- | --- | --- | --- | --- | --- | --- | --- | --- | --- | --- | --- | --- | --- |
|  | 3 | **Employer Executive Dormitory Buildings (1929 m2)** |  | 2013-02-10 | 2013-06-30 |  |  |  |  |  |  |  |  |  |
| MOB-TA-EED-100 |  | Design for Employer Executive Dormitory Building | 20d | 2013-02-10 A | 2013-03-01 A | MOB-ST-PR-0060 SS+15d | 100% |  | 2013-03-21 | 2013-04-09 |  |  | Mobilizasyon Yeni WBS [160 h] | 3,200 |
| MOB-TA-EED-110 |  | Employer Executive Dormitory Building Delivery | 40d | 2013-03-15 A | 2013-05-08 | MOB-TA-EED-100 FS+20d | 30% | 28d | 2013-03-21 | 2013-04-29 | 9d | 10d | Mobilizasyon Yeni WBS [320 h] | 6,400 |
| MOB-TA-EED-120 |  | Site Preperation-Earthworks for Employer Executive Dormitory Building | 7d | 2013-04-27 | 2013-05-03 | MOB-SP-GE-110 FS+7d |  |  |  |  | -2d | 0d | Mobilizasyon Yeni WBS [56 h] | 1,120 |
| MOB-TA-EED-130 |  | Concrete Foundation of Employer Executive Dormitory Building | 15d | 2013-05-09 | 2013-05-23 | MOB-TA-EED-120 FS+5d, MOB-TA-EED-110 FF+5d |  |  |  |  | -1d | 0d | Mobilizasyon Yeni WBS [120 h] | 2,400 |
| MOB-TA-EED-140 |  | Installation of Demounted Panels and Connection | 20d | 2013-05-27 | 2013-06-15 | MOB-TA-EED-130 FS+3d |  |  |  |  | -1d | 0d | Mobilizasyon Yeni WBS [160 h] | 3,200 |
| MOB-TA-EED-150 |  | Floor Covering for Executive Dormitory Building | 10d | 2013-06-16 | 2013-06-25 | MOB-TA-EED-140 |  |  |  |  | -1d | 0d | Mobilizasyon Yeni WBS [80 h] | 1,600 |
| MOB-TA-EED-160 |  | Electrical Cable Installation for Employer Executive Dormitory Building | 10d | 2013-06-16 | 2013-06-25 | MOB-TU-ELC-130 SS+20d, MOB-TA-EED-140 |  |  |  |  | -1d | 0d | Mobilizasyon Yeni WBS [80 h] | 1,600 |
| MOB-TA-EED-170 |  | Mounting Electrical Accessiories for Employer Executive Dormitory Building | 10d | 2013-06-21 | 2013-06-30 | MOB-TU-ELC-140 SS+20d, MOB-TA-EED-160 SS+5d |  |  |  |  | -1d | 28.38d | Mobilizasyon Yeni WBS [80 h] | 1,600 |
| MOB-TA-EED-180 |  | Installation of WC+Shower | 10d | 2013-06-21 | 2013-06-30 | MOB-TA-EED-150 SS+5d, MOB-TU-SE-140 SS+20d |  |  |  |  | -1d | 0d | Mobilizasyon Yeni WBS [80 h] | 1,600 |
| MOB-TA-EED-190 |  | Installation of Heating System | 10d | 2013-06-21 | 2013-06-30 | MOB-TA-EED-180 SS |  |  |  |  | -1d | 0d | Mobilizasyon Yeni WBS [80 h] | 1,600 |
|  | 2 | **Supervision and Others Accommodation** |  | 2013-01-20 | 2013-07-08 |  |  |  |  |  |  |  |  |  |
|  | 1 | **Site Containers (First Party Mobilization 1160 m2)** |  | 2013-01-20 | 2013-04-27 |  |  |  |  |  |  |  |  |  |
| MOB-TA-SC-100 |  | Design of Site Containers | 15d | 2013-01-20 A | 2013-02-05 A | MOB-ST-PR-0060 SS+10d | 100% |  | 2013-03-21 | 2013-04-04 |  |  | Mobilizasyon Yeni WBS [120 h] | 2,400 |
| MOB-TA-SC-110 |  | Site Containers Delivery to Site (Assembled) | 50d | 2013-02-14 A | 2013-04-25 | MOB-TA-SC-100 | 70% | 15d | 2013-03-21 | 2013-05-09 | 127d | 94.38d | Mobilizasyon Yeni WBS [400 h] | 8,000 |
| MOB-TA-SC-120 |  | Site Preperation-Earthworks for Siter Containers | 10d | 2013-04-01 A | 2013-04-10 A | MOB-TA-SC-110 FF-5d | 100% |  | 2013-03-27 | 2013-04-05 |  |  | Mobilizasyon Yeni WBS [80 h] | 1,600 |
| MOB-TA-SC-130 |  | Foundations for Site Containers | 10d | 2013-04-05 A | 2013-04-20 | MOB-TA-SC-120 |  | 10d | 2013-04-05 | 2013-04-15 | 34.88d | 99.38d | Mobilizasyon Yeni WBS [80 h] | 1,600 |
| MOB-TA-SC-140 |  | Installation of Site Containers | 15d | 2013-04-12 | 2013-04-27 | MOB-TA-SC-130 SS+7d |  |  |  |  | 34.88d | 64.25d | Mobilizasyon Yeni WBS [120 h] | 2,400 |
|  | 2 | **Engineer Dormitory (1616 m2)** |  | 2013-02-01 | 2013-06-28 |  |  |  |  |  |  |  |  |  |
| MOB-TA-ED-100 |  | Design for Engineer Dormitory Building | 20d | 2013-02-01 A | 2013-02-20 A | MOB-ST-PR-0060 SS+30d | 100% |  | 2013-03-21 | 2013-04-09 |  |  | Mobilizasyon Yeni WBS [160 h] | 3,200 |
| MOB-TA-ED-110 |  | Engineer Dormitory Building Delivery | 50d | 2013-03-05 A | 2013-05-08 | MOB-TA-ED-100 FS+20d | 44% | 28d | 2013-03-21 | 2013-05-09 | 12d | 11d | Mobilizasyon Yeni WBS [400 h] | 8,000 |
| MOB-TA-ED-120 |  | Site Preperation-Earthworks for Engineer Dormitory Building | 10d | 2013-04-25 | 2013-05-04 | MOB-SP-GE-110 FS+5d |  |  |  |  | 1d | 0d | Mobilizasyon Yeni WBS [80 h] | 1,600 |
| MOB-TA-ED-130 |  | Concrete Foundation of Engineer Dormitory Building | 15d | 2013-05-05 | 2013-05-19 | MOB-TA-ED-120, MOB-TA-ED-110 FF |  |  |  |  | 1d | 0d | Mobilizasyon Yeni WBS [120 h] | 2,400 |
| MOB-TA-ED-140 |  | Installation of Demounted Panels and Connection | 20d | 2013-05-23 | 2013-06-11 | MOB-TA-ED-130 FS+3d |  |  |  |  | 1d | 0d | Mobilizasyon Yeni WBS [160 h] | 3,200 |
| MOB-TA-ED-150 |  | Floor Covering for Engineer Dormitory Building | 7d | 2013-06-12 | 2013-06-18 | MOB-TA-ED-140 |  |  |  |  | 3d | 0d | Mobilizasyon Yeni WBS [56 h] | 1,120 |
| MOB-TA-ED-160 |  | Electrical Cable Installation for Engineer Dormitory Building | 10d | 2013-06-12 | 2013-06-21 | MOB-TA-ED-140, MOB-TU-ELC-130 SS+30d |  |  |  |  | 1d | 0d | Mobilizasyon Yeni WBS [80 h] | 1,600 |
| MOB-TA-ED-180 |  | Installation of WC+Shower | 10d | 2013-06-17 | 2013-06-26 | MOB-TU-SE-140 SS+20d, MOB-TA-ED-150 SS+5d |  |  |  |  | 3d | 0d | Mobilizasyon Yeni WBS [80 h] | 1,600 |
| MOB-TA-ED-190 |  | Installation of Heating System | 10d | 2013-06-17 | 2013-06-26 | MOB-TA-ED-180 SS |  |  |  |  | 3d | 4d | Mobilizasyon Yeni WBS [80 h] | 1,600 |
| MOB-TA-ED-170 |  | Mounting Electrical Accessiories for Manager Dormitory Building | 10d | 2013-06-19 | 2013-06-28 | MOB-TU-ELC-140 SS+15d, MOB-TA-ED-160 SS+7d |  |  |  |  | 1d | 30.38d | Mobilizasyon Yeni WBS [80 h] | 1,600 |

| ID | WBS | Activity | Duration | Start | Finish | Predecessors | Complete | Remaining | Planned start | Planned finish | Total float | Free float | Resources | Cost |
| --- | --- | --- | --- | --- | --- | --- | --- | --- | --- | --- | --- | --- | --- | --- |
|  | 3 | **Dormitory for Officer-Technician Part 1 (357 m2)** |  | 2013-02-01 | 2013-06-03 |  |  |  |  |  |  |  |  |  |
| MOB-TA-DOT-100 |  | Design for Dormitory Officer-Technician | 20d | 2013-02-01 A | 2013-02-20 A | MOB-ST-PR-0060 SS+20d | 100% |  | 2013-03-21 | 2013-04-09 |  |  | Mobilizasyon Yeni WBS [160 h] | 3,200 |
| MOB-TA-DOT-110 |  | Officer-Technician Dormitory Delivery | 40d | 2013-03-05 A | 2013-05-04 | MOB-TA-DOT-100 FS+15d | 40% | 24d | 2013-03-21 | 2013-04-29 | 4.62d | 0d | Mobilizasyon Yeni WBS [320 h] | 6,400 |
| MOB-TA-DOT-120 |  | Site Preperation-Earthworks for Officer-Technician Dormitory | 5d | 2013-04-23 | 2013-04-27 | MOB-SP-GE-110 FS+3d |  |  |  |  | 4.62d | 0d | Mobilizasyon Yeni WBS [40 h] | 800 |
| MOB-TA-DOT-130 |  | Concrete Foundation of Officer-Technician Dormitory | 7d | 2013-04-28 | 2013-05-04 | MOB-TA-DOT-120, MOB-TA-DOT-110 FF |  |  |  |  | 4.62d | 0d | Mobilizasyon Yeni WBS [56 h] | 1,120 |
| MOB-TA-DOT-140 |  | Installation of Demounted Panels and Connection | 12d | 2013-05-08 | 2013-05-19 | MOB-TA-DOT-130 FS+3d |  |  |  |  | 4.62d | 0d | Mobilizasyon Yeni WBS [96 h] | 1,920 |
| MOB-TA-DOT-150 |  | Floor Covering for Officer-Technician Dormitory | 7d | 2013-05-16 | 2013-05-22 | MOB-TA-DOT-140 FF+3d |  |  |  |  | 4.62d | 0d | Mobilizasyon Yeni WBS [56 h] | 1,120 |
| MOB-TA-DOT-160 |  | Electrical Cable Installation for Officer-Technician Dormitory | 10d | 2013-05-20 | 2013-05-29 | MOB-TU-ELC-130 SS+10d, MOB-TA-DOT-140 |  |  |  |  | 16d | 0d | Mobilizasyon Yeni WBS [80 h] | 1,600 |
| MOB-TA-DOT-180 |  | Installation of WC+Shower | 7d | 2013-05-21 | 2013-05-27 | MOB-TU-SE-140 SS, MOB-TA-DOT-150 SS+5d |  |  |  |  | 4.62d | 0d | Mobilizasyon Yeni WBS [56 h] | 1,120 |
| MOB-TA-DOT-190 |  | Installation of Heating System | 7d | 2013-05-21 | 2013-05-27 | MOB-TA-DOT-180 SS |  |  |  |  | 4.62d | 34d | Mobilizasyon Yeni WBS [56 h] | 1,120 |
| MOB-TA-DOT-170 |  | Mounting Electrical Accessiories for Officer-Technician Dormitory | 5d | 2013-05-30 | 2013-06-03 | MOB-TA-DOT-160, MOB-TU-ELC-130 SS |  |  |  |  | 26d | 55.38d | Mobilizasyon Yeni WBS [40 h] | 800 |
|  | 4 | **Dormitory for Officer-Technician Part 2 (714 m2)** |  | 2013-02-01 | 2013-06-11 |  |  |  |  |  |  |  |  |  |
| MOB-TA-DOT2-100 |  | Design for Dormitory Officer-Technician | 20d | 2013-02-01 A | 2013-02-20 A | MOB-ST-PR-0060 SS+20d | 100% |  | 2013-03-21 | 2013-04-09 |  |  | Mobilizasyon Yeni WBS [160 h] | 3,200 |
| MOB-TA-DOT2-110 |  | Officer-Technician Dormitory Delivery | 40d | 2013-03-05 A | 2013-05-04 | MOB-TA-DOT2-100 FS+15d | 40% | 24d | 2013-03-21 | 2013-04-29 | 1.62d | 0d | Mobilizasyon Yeni WBS [320 h] | 6,400 |
| MOB-TA-DOT2-120 |  | Site Preperation-Earthworks for Officer-Technician Dormitory | 5d | 2013-04-18 | 2013-04-23 | MOB-SP-GE-110 SS+15d, MOB-TA-DOT2-110 SS+45d |  |  |  |  | 2.88d | 1.25d | Mobilizasyon Yeni WBS [40 h] | 800 |
| MOB-TA-DOT2-130 |  | Concrete Foundation of Officer-Technician Dormitory | 10d | 2013-04-25 | 2013-05-04 | MOB-TA-DOT2-110 FF, MOB-TA-DOT2-120 |  |  |  |  | 1.62d | 0d | Mobilizasyon Yeni WBS [80 h] | 1,600 |
| MOB-TA-DOT2-140 |  | Installation of Demounted Panels and Connection | 15d | 2013-05-08 | 2013-05-22 | MOB-TA-DOT2-130 FS+3d |  |  |  |  | 1.62d | 0d | Mobilizasyon Yeni WBS [120 h] | 2,400 |
| MOB-TA-DOT2-150 |  | Floor Covering for Officer-Technician Dormitory | 7d | 2013-05-19 | 2013-05-25 | MOB-TA-DOT2-140 FF+3d |  |  |  |  | 1.62d | 0d | Mobilizasyon Yeni WBS [56 h] | 1,120 |
| MOB-TA-DOT2-160 |  | Electrical Cable Installation for Officer-Technician Dormitory | 10d | 2013-05-23 | 2013-06-01 | MOB-TA-DOT2-140, MOB-TU-ELC-130 SS+10d |  |  |  |  | 13d | 0d | Mobilizasyon Yeni WBS [80 h] | 1,600 |
| MOB-TA-DOT2-180 |  | Installation of WC+Shower | 7d | 2013-05-24 | 2013-05-30 | MOB-TA-DOT2-150 SS+5d, MOB-TU-SE-140 SS |  |  |  |  | 1.62d | 0d | Mobilizasyon Yeni WBS [56 h] | 1,120 |
| MOB-TA-DOT2-190 |  | Installation of Heating System | 7d | 2013-05-24 | 2013-05-30 | MOB-TA-DOT2-180 SS |  |  |  |  | 1.62d | 31d | Mobilizasyon Yeni WBS [56 h] | 1,120 |
| MOB-TA-DOT2-170 |  | Mounting Electrical Accessiories for Officer-Technician Dormitory | 10d | 2013-06-02 | 2013-06-11 | MOB-TU-ELC-130 SS, MOB-TA-DOT2-160 |  |  |  |  | 18d | 47.38d | Mobilizasyon Yeni WBS [80 h] | 1,600 |
|  | 5 | **Worker Dormitory Part 1 (1066 m2)** |  | 2013-02-01 | 2013-06-04 |  |  |  |  |  |  |  |  |  |
| MOB-TA-WD-100 |  | Design for Worker Dormitory | 20d | 2013-02-01 A | 2013-02-20 A |  | 100% |  | 2013-03-21 | 2013-04-09 |  |  | Mobilizasyon Yeni WBS [160 h] | 3,200 |
| MOB-TA-WD-110 |  | Worker Dormitory Building Delivery | 40d | 2013-03-01 A | 2013-04-30 | MOB-TA-WD-100 FS+15d | 50% | 20d | 2013-03-21 | 2013-04-29 | 4.62d | 0d | Mobilizasyon Yeni WBS [320 h] | 6,400 |
| MOB-TA-WD-120 |  | Site Preperation-Earthworks for Worker Dormitory Building | 10d | 2013-04-11 | 2013-04-20 | MOB-SP-GE-110 SS |  |  |  |  | 4.62d | 0d | Mobilizasyon Yeni WBS [80 h] | 1,600 |
| MOB-TA-WD-130 |  | Concrete Foundation of Worker Dormitory Building | 15d | 2013-04-16 | 2013-04-30 | MOB-TA-WD-110 FF, MOB-TA-WD-120 SS+5d |  |  |  |  | 4.62d | 0d | Mobilizasyon Yeni WBS [120 h] | 2,400 |
| MOB-TA-WD-140 |  | Installation of Demounted Panels and Connection | 25d | 2013-04-26 | 2013-05-20 | MOB-TA-WD-130 SS+10d |  |  |  |  | 4.62d | 0d | Mobilizasyon Yeni WBS [200 h] | 4,000 |
| MOB-TA-WD-150 |  | Floor Covering for Worker Dormitory Building | 10d | 2013-05-16 | 2013-05-25 | MOB-TA-WD-140 FF+5d |  |  |  |  | 4.62d | 0d | Mobilizasyon Yeni WBS [80 h] | 1,600 |
| MOB-TA-WD-160 |  | Electrical Cable Installation for Worker Dormitory Building | 10d | 2013-05-21 | 2013-05-30 | MOB-TA-WD-140, MOB-TU-ELC-130 SS+15d |  |  |  |  | 15d | 0d | Mobilizasyon Yeni WBS [80 h] | 1,600 |
| MOB-TA-WD-180 |  | Installation of WC+Shower | 7d | 2013-05-21 | 2013-05-27 | MOB-TA-WD-150 SS+5d, MOB-TU-SE-140 SS |  |  |  |  | 4.62d | 0d | Mobilizasyon Yeni WBS [56 h] | 1,120 |
| MOB-TA-WD-190 |  | Installation of Heating System | 7d | 2013-05-21 | 2013-05-27 | MOB-TA-WD-180 SS |  |  |  |  | 4.62d | 34d | Mobilizasyon Yeni WBS [56 h] | 1,120 |
| MOB-TA-WD-170 |  | Mounting Electrical Accessiories for Worker Dormitory Building | 10d | 2013-05-26 | 2013-06-04 | MOB-TU-ELC-140 SS, MOB-TA-WD-160 SS+5d |  |  |  |  | 25d | 54.38d | Mobilizasyon Yeni WBS [80 h] | 1,600 |

| ID | WBS | Activity | Duration | Start | Finish | Predecessors | Complete | Remaining | Planned start | Planned finish | Total float | Free float | Constraint | Resources | Cost |
| --- | --- | --- | --- | --- | --- | --- | --- | --- | --- | --- | --- | --- | --- | --- | --- |
|  | 6 | **Worker Dormitory Part 2 (5863 m2)** |  | 2013-02-01 | 2013-07-08 |  |  |  |  |  |  |  |  |  |  |
| MOB-TA-WDR-100 |  | Design for Worker Dormitory | 20d | 2013-02-01 A | 2013-02-20 A |  | 100% |  | 2013-03-21 | 2013-04-09 |  |  |  | Mobilizasyon Yeni WBS [160 h] | 3,200 |
| MOB-TA-WDR-110 |  | Worker Dormitory Building Delivery | 40d | 2013-03-01 A | 2013-04-30 | MOB-TA-WDR-100 FS+15d | 50% | 20d | 2013-03-21 | 2013-04-29 | -0.38d | 29d |  | Mobilizasyon Yeni WBS [320 h] | 6,400 |
| MOB-TA-WDR-120 |  | Site Preperation-Earthworks for Worker Dormitory Building | 10d | 2013-05-05 | 2013-05-14 | MOB-SP-GE-110 FS+15d |  |  | 2013-04-28 | 2013-05-07 | -29.38d | 0d | start on or after 2013-04-28 | Mobilizasyon Yeni WBS [80 h] | 1,600 |
| MOB-TA-WDR-130 |  | Concrete Foundation of Worker Dormitory Building | 20d | 2013-05-10 | 2013-05-29 | MOB-TA-WDR-110 FF, MOB-TA-WDR-120 SS+5d |  |  | 2013-05-03 | 2013-05-22 | -29.38d | 0d | start on or after 2013-05-03 | Mobilizasyon Yeni WBS [160 h] | 3,200 |
| MOB-TA-WDR-140 |  | Installation of Demounted Panels and Connection | 25d | 2013-05-30 | 2013-06-23 | MOB-TA-WDR-130 |  |  | 2013-05-23 | 2013-06-16 | -29.38d | 0d | start on or after 2013-05-23 | Mobilizasyon Yeni WBS [200 h] | 4,000 |
| MOB-TA-WDR-150 |  | Floor Covering for Worker Dormitory Building | 10d | 2013-06-19 | 2013-06-28 | MOB-TA-WDR-140 FF+5d |  |  | 2013-06-12 | 2013-06-21 | -29.38d | 0d | start on or after 2013-06-12 | Mobilizasyon Yeni WBS [80 h] | 1,600 |
| MOB-TA-WDR-160 |  | Electrical Cable Installation for Worker Dormitory Building | 10d | 2013-06-24 | 2013-07-03 | MOB-TU-ELC-130 SS+15d, MOB-TA-WDR-140 |  |  | 2013-06-17 | 2013-06-26 | -19d | 0d | start on or after 2013-06-17 | Mobilizasyon Yeni WBS [80 h] | 1,600 |
| MOB-TA-WDR-180 |  | Installation of WC+Shower | 7d | 2013-06-24 | 2013-06-30 | MOB-TU-SE-140 SS, MOB-TA-WDR-150 SS+5d |  |  | 2013-06-17 | 2013-06-23 | -29.38d | 0d | start on or after 2013-06-17 | Mobilizasyon Yeni WBS [56 h] | 1,120 |
| MOB-TA-WDR-190 |  | Installation of Heating System | 7d | 2013-06-24 | 2013-06-30 | MOB-TA-WDR-180 SS |  |  | 2013-06-17 | 2013-06-23 | -29.38d | 0d | start on or after 2013-06-17 | Mobilizasyon Yeni WBS [56 h] | 1,120 |
| MOB-TA-WDR-170 |  | Mounting Electrical Accessiories for Worker Dormitory Building | 10d | 2013-06-29 | 2013-07-08 | MOB-TU-ELC-140 SS, MOB-TA-WDR-160 SS+5d |  |  | 2013-06-20 | 2013-06-29 | -9d | 20.38d | start on or after 2013-06-20 | Mobilizasyon Yeni WBS [80 h] | 1,600 |
|  | 2 | **Offices** |  | 2013-02-01 | 2013-07-04 |  |  |  |  |  |  |  |  |  |  |
|  | 1 | **Alarko Office Building Type-I (408 m2)** |  | 2013-02-20 | 2013-06-29 |  |  |  |  |  |  |  |  |  |  |
| MOB-OF-AOB-100 |  | Design for Alarko Office Building Type-I | 20d | 2013-02-20 A | 2013-03-10 A | MOB-ST-PR-0060 SS+35d | 100% |  | 2013-03-21 | 2013-04-09 |  |  |  | Mobilizasyon Yeni WBS [160 h] | 3,200 |
| MOB-OF-AOB-110 |  | Alarko Office Building Type-I Delivery | 40d | 2013-03-15 A | 2013-05-14 | MOB-OF-AOB-100 FS+15d | 15% | 34d | 2013-03-21 | 2013-04-29 | 108d | 75.38d |  | Mobilizasyon Yeni WBS [320 h] | 6,400 |
| MOB-OF-AOB-120 |  | Site Preperation-Earthworks for Alarko Office Building Type-I | 10d | 2013-04-05 A | 2013-04-10 A | MOB-SP-GE-110 FS+10d, MOB-OF-AOB-110 FF+5d | 100% |  | 2013-04-24 | 2013-05-04 |  |  |  | Mobilizasyon Yeni WBS [80 h] | 1,600 |
| MOB-OF-AOB-130 |  | Concrete Foundation of Alarko Office Building Type-I | 15d | 2013-04-10 A | 2013-04-26 | MOB-OF-AOB-110, MOB-OF-AOB-120 |  | 15.25d | 2013-05-04 | 2013-05-19 | 31d | 94.12d |  | Mobilizasyon Yeni WBS [120 h] | 2,400 |
| MOB-OF-AOB-140 |  | Installation of Alarko Office Building Type-I | 25d | 2013-04-20 | 2013-05-14 | MOB-OF-AOB-130 SS+10d |  |  |  |  | 31d | 0d |  | Mobilizasyon Yeni WBS [200 h] | 4,000 |
| MOB-OF-AOB-150 |  | Floor Covering for Alarko Office Building Type-I | 10d | 2013-05-10 | 2013-05-19 | MOB-OF-AOB-140 FF+5d |  |  |  |  | 103d | 70.38d |  | Mobilizasyon Yeni WBS [80 h] | 1,600 |
| MOB-OF-AOB-160 |  | Electrical Cable Installation for Alarko Office Building Type-I | 10d | 2013-06-15 | 2013-06-24 | MOB-OF-AOB-140, MOB-TU-ELC-130 SS+40d |  |  |  |  | 0d |  |  | Mobilizasyon Yeni WBS [80 h] | 1,600 |
| MOB-OF-AOB-170 |  | Mounting Electrical Accessiories for Alarko Office Building Type-I | 10d | 2013-06-20 | 2013-06-29 | MOB-OF-AOB-160 SS+5d, MOB-TU-ELC-140 SS+30d |  |  |  |  | 0d |  |  | Mobilizasyon Yeni WBS [80 h] | 1,600 |
| MOB-OF-AOB-180 |  | Installation of Heating System | 7d | 2013-06-20 | 2013-06-26 | MOB-OF-AOB-160 SS+5d |  |  |  |  | 3d | 12d |  | Mobilizasyon Yeni WBS [56 h] | 1,120 |
|  | 2 | **Alarko Office Building Type-II (408 m2)** |  | 2013-02-01 | 2013-05-25 |  |  |  |  |  |  |  |  |  |  |
| MOB-OF-AOB-II-100 |  | Design for Alarko Office Building Type-II | 20d | 2013-02-01 A | 2013-02-20 A | MOB-ST-PR-0060 SS+25d | 100% |  | 2013-03-21 | 2013-04-09 |  |  |  | Mobilizasyon Yeni WBS [160 h] | 3,200 |
| MOB-OF-AOB-II-110 |  | Alarko Office Building Type-II Delivery | 35d | 2013-03-05 A | 2013-04-29 | MOB-OF-AOB-II-100 FS+15d | 46% | 19d | 2013-03-21 | 2013-04-24 | 123d | 90.38d |  | Mobilizasyon Yeni WBS [280 h] | 5,600 |
| MOB-OF-AOB-II-120 |  | Site Preperation-Earthworks for Alarko Office Building Type-II | 7d | 2013-04-05 A | 2013-04-10 A | MOB-SP-GE-110 SS+15d | 100% |  | 2013-03-27 | 2013-04-02 |  |  |  | Mobilizasyon Yeni WBS [56 h] | 1,120 |
| MOB-OF-AOB-II-130 |  | Concrete Foundation of Alarko Office Building Type-II | 7d | 2013-04-10 A | 2013-04-17 | MOB-OF-AOB-II-110 FS-10d, MOB-OF-AOB-II-120 |  | 7d | 2013-04-04 | 2013-04-11 | 25.88d | 0d |  | Mobilizasyon Yeni WBS [56 h] | 1,120 |
| MOB-OF-AOB-II-140 |  | Installation of Alarko Office Building Type-II | 10d | 2013-04-18 | 2013-04-27 | MOB-OF-AOB-II-130 |  |  |  |  | 25.88d | 0d |  | Mobilizasyon Yeni WBS [80 h] | 1,600 |
| MOB-OF-AOB-II-150 |  | Floor Covering for Alarko Office Building Type-II | 10d | 2013-04-23 | 2013-05-02 | MOB-OF-AOB-II-140 FF+5d |  |  |  |  | 58d | 87.38d |  | Mobilizasyon Yeni WBS [80 h] | 1,600 |
| MOB-OF-AOB-II-160 |  | Electrical Cable Installation for Alarko Office Building Type-II | 10d | 2013-05-06 | 2013-05-15 | MOB-TU-ELC-130 SS, MOB-OF-AOB-II-140 |  |  |  |  | 17.88d | 5d |  | Mobilizasyon Yeni WBS [80 h] | 1,600 |
| MOB-OF-AOB-II-170 |  | Mounting Electrical Accessiories for Alarko Office Building Type-II | 10d | 2013-05-16 | 2013-05-25 | MOB-OF-AOB-II-160 SS+5d, MOB-TU-ELC-140 SS |  |  |  |  | 12.88d | 0d |  | Mobilizasyon Yeni WBS [80 h] | 1,600 |
| MOB-OF-AOB-II-180 |  | Installation of Heating System | 7d | 2013-05-19 | 2013-05-25 | MOB-OF-AOB-II-160 SS+5d, MOB-OF-AOB-II-170 FF |  |  |  |  | 12.88d | 5d |  | Mobilizasyon Yeni WBS [56 h] | 1,120 |

| ID | WBS | Activity | Duration | Start | Finish | Predecessors | Complete | Remaining | Planned start | Planned finish | Total float | Free float | Constraint | Resources | Cost | Actual cost |
| --- | --- | --- | --- | --- | --- | --- | --- | --- | --- | --- | --- | --- | --- | --- | --- | --- |
|  | 3 | **Kazakhmys Office Buildings (2319 m2)** |  | 2013-02-20 | 2013-07-04 |  |  |  |  |  |  |  |  |  |  |  |
| MOB-OF-KOB-100 |  | Design for Kazakhmys Office Building | 20d | 2013-02-20 A | 2013-03-11 A | MOB-ST-PR-0060 SS+20d | 100% |  | 2013-03-21 | 2013-04-09 |  |  |  | Mobilizasyon Yeni WBS [160 h] | 3,200 |  |
| MOB-OF-KOB-120 |  | Site Preperation-Earthworks for Kazakhmys Office Building | 10d | 2013-04-07 A | 2013-04-11 A | MOB-SP-GE-110 FS+10d, MOB-OF-KOB-110 SS+20d | 100% |  | 2013-04-24 | 2013-05-04 |  |  |  | Mobilizasyon Yeni WBS [80 h] | 1,600 |  |
| MOB-OF-KOB-110 |  | Kazakhmys Office Building Delivery | 30d | 2013-04-11 | 2013-05-10 | MOB-OF-KOB-100 FS+25d |  |  | 2013-04-04 | 2013-05-03 | 15d | 0d |  | Mobilizasyon Yeni WBS [240 h] | 4,800 |  |
| MOB-OF-KOB-130 |  | Concrete Foundation of Kazakhmys Office Building | 15d | 2013-04-11 | 2013-04-25 | MOB-OF-KOB-120 |  |  | 2013-04-04 | 2013-04-18 | 30d | 15d |  | Mobilizasyon Yeni WBS [120 h] | 2,400 |  |
| MOB-OF-KOB-140 |  | Installation of Kazakhmys Office Building | 20d | 2013-05-11 | 2013-05-30 | MOB-OF-KOB-110, MOB-OF-KOB-130 |  |  | 2013-05-04 | 2013-05-23 | 15d | 0d | start on or after 2013-05-04 | Mobilizasyon Yeni WBS [160 h] | 3,200 |  |
| MOB-OF-KOB-150 |  | Floor Covering for Kazakhmys Office Building | 10d | 2013-05-26 | 2013-06-04 | MOB-OF-KOB-140 FF+5d |  |  | 2013-05-19 | 2013-05-28 | 25d | 54.38d | start on or after 2013-05-19 | Mobilizasyon Yeni WBS [80 h] | 1,600 |  |
| MOB-OF-KOB-160 |  | Electrical Cable Installation for Kazakhmys Office Building | 10d | 2013-06-05 | 2013-06-14 | MOB-TU-ELC-130 SS+30d, MOB-OF-KOB-140 |  |  | 2013-05-29 | 2013-06-07 | 10d | 15d | start on or after 2013-05-29 | Mobilizasyon Yeni WBS [80 h] | 1,600 |  |
| MOB-OF-KOB-170 |  | Mounting Electrical Accessiories for Kazakhmys Office Building | 10d | 2013-06-25 | 2013-07-04 | MOB-TU-ELC-140 SS+40d, MOB-OF-KOB-160 SS+5d |  |  | 2013-06-18 | 2013-06-27 | -5d | 0d | start on or after 2013-06-18 | Mobilizasyon Yeni WBS [80 h] | 1,600 |  |
| MOB-OF-KOB-180 |  | Installation of Heating System | 7d | 2013-06-28 | 2013-07-04 | MOB-OF-KOB-170 FF, MOB-OF-KOB-160 SS+5d |  |  | 2013-06-21 | 2013-06-27 | -5d | 0d | start on or after 2013-06-21 | Mobilizasyon Yeni WBS [56 h] | 1,120 |  |
|  | 4 | **Alarko Office Building Type-IV (808 m2)** |  | 2013-02-01 | 2013-05-30 |  |  |  |  |  |  |  |  |  |  |  |
| MOB-OF-AOB-IV-100 |  | Design for Alarko Office Building Type-IV | 20d | 2013-02-01 A | 2013-02-20 A | MOB-ST-PR-0060 SS+25d | 100% |  | 2013-03-21 | 2013-04-09 |  |  |  | Mobilizasyon Yeni WBS [160 h] | 3,200 |  |
| MOB-OF-AOB-IV-110 |  | Alarko Office Building Type-IV Delivery | 45d | 2013-03-05 A | 2013-05-03 | MOB-OF-AOB-IV-100 FS+15d | 49% | 23d | 2013-03-21 | 2013-05-04 | 7.88d | 0d |  | Mobilizasyon Yeni WBS [360 h] | 7,200 |  |
| MOB-OF-AOB-IV-120 |  | Site Preperation-Earthworks for Alarko Office Building Type-IV | 7d | 2013-04-05 A | 2013-04-10 A | MOB-SP-GE-110 FS+12d | 100% |  | 2013-04-16 | 2013-04-23 |  |  |  | Mobilizasyon Yeni WBS [56 h] | 1,120 |  |
| MOB-OF-AOB-IV-130 |  | Concrete Foundation of Alarko Office Building Type-IV | 10d | 2013-04-24 | 2013-05-03 | MOB-OF-AOB-IV-110 FS-10d, MOB-OF-AOB-IV-120 |  |  |  |  | 7.88d | 0d |  | Mobilizasyon Yeni WBS [80 h] | 1,600 |  |
| MOB-OF-AOB-IV-140 |  | Installation of Alarko Office Building Type-IV | 12d | 2013-05-04 | 2013-05-15 | MOB-OF-AOB-IV-130 |  |  |  |  | 7.88d | 0d |  | Mobilizasyon Yeni WBS [96 h] | 1,920 |  |
| MOB-OF-AOB-IV-150 |  | Floor Covering for Alarko Office Building Type-IV | 10d | 2013-05-11 | 2013-05-20 | MOB-OF-AOB-IV-140 FF+5d |  |  |  |  | 40d | 69.38d |  | Mobilizasyon Yeni WBS [80 h] | 1,600 |  |
| MOB-OF-AOB-IV-160 |  | Electrical Cable Installation for Alarko Office Building Type-IV | 10d | 2013-05-16 | 2013-05-25 | MOB-TU-ELC-130 SS, MOB-OF-AOB-IV-140 |  |  |  |  | 7.88d | 0d |  | Mobilizasyon Yeni WBS [80 h] | 1,600 |  |
| MOB-OF-AOB-IV-170 |  | Mounting Electrical Accessiories for Alarko Office Building Type-IV | 10d | 2013-05-21 | 2013-05-30 | MOB-TU-ELC-140 SS, MOB-OF-AOB-IV-160 SS+5d |  |  |  |  | 7.88d | 0d |  | Mobilizasyon Yeni WBS [80 h] | 1,600 |  |
| MOB-OF-AOB-IV-180 |  | Installation of Heating System | 7d | 2013-05-24 | 2013-05-30 | MOB-OF-AOB-IV-160 SS+5d, MOB-OF-AOB-IV-170 FF |  |  |  |  | 7.88d | 0d |  | Mobilizasyon Yeni WBS [56 h] | 1,120 |  |
|  | 3 | **Parking Areas** |  | 2013-02-21 | 2013-04-23 |  |  |  |  |  |  |  |  |  |  |  |
| MOB-TA-PA-100 |  | Parking space & ports for Mobilization | 30d | 2013-02-21 A | 2013-04-23 | MOB-ST-PR-0060 FS-20d | 58% | 12.5d | 2013-04-23 | 2013-05-23 | 67.5d | 96.88d |  | Mobilizasyon Yeni WBS [240 h] | 4,800 | 2,800 |
|  | 4 | **Service Facilities (Laundry 194 m2)** |  | 2013-02-20 | 2013-06-18 |  |  |  |  |  |  |  |  |  |  |  |
| MOB-OF-SF-100 |  | Design for Laundry Building | 20d | 2013-02-20 A | 2013-03-11 A |  | 100% |  | 2013-03-21 | 2013-04-09 |  |  |  | Mobilizasyon Yeni WBS [160 h] | 3,200 |  |
| MOB-OF-SF-110 |  | Laundry Building Delivery | 35d | 2013-04-11 | 2013-05-15 | MOB-OF-SF-100 FS+25d |  |  |  |  | 19d | 0d |  | Mobilizasyon Yeni WBS [280 h] | 5,600 |  |
| MOB-OF-SF-120 |  | Site Preperation-Earthworks for Laundry Building Delivery | 5d | 2013-05-01 | 2013-05-05 | MOB-SP-GE-110 FS+5d, MOB-OF-SF-110 SS+20d |  |  |  |  | 19d | 0d |  | Mobilizasyon Yeni WBS [40 h] | 800 |  |
| MOB-OF-SF-130 |  | Concrete Foundation of Laundry Building Delivery | 7d | 2013-05-11 | 2013-05-17 | MOB-OF-SF-120 FS+5d |  |  |  |  | 19d | 0d |  | Mobilizasyon Yeni WBS [56 h] | 1,120 |  |
| MOB-OF-SF-140 |  | Installation of Laundry Building Delivery | 10d | 2013-05-18 | 2013-05-27 | MOB-OF-SF-110, MOB-OF-SF-130 |  |  |  |  | 19d | 0d |  | Mobilizasyon Yeni WBS [80 h] | 1,600 |  |
| MOB-OF-SF-150 |  | Floor Covering for Laundry Building Delivery | 7d | 2013-05-26 | 2013-06-01 | MOB-OF-SF-140 FF+5d |  |  |  |  | 90d | 57.38d |  | Mobilizasyon Yeni WBS [56 h] | 1,120 |  |
| MOB-OF-SF-160 |  | Electrical Cable Installation for Laundry Building Delivery | 7d | 2013-05-31 | 2013-06-06 | MOB-TU-ELC-130 SS+25d, MOB-OF-SF-140 |  |  |  |  | 16d | 0d |  | Mobilizasyon Yeni WBS [56 h] | 1,120 |  |
| MOB-OF-SF-180 |  | Installation of Heating System | 7d | 2013-06-05 | 2013-06-11 | MOB-OF-SF-160 SS+5d |  |  |  |  | 18d | 47.38d |  | Mobilizasyon Yeni WBS [56 h] | 1,120 |  |
| MOB-OF-SF-170 |  | Mounting Electrical Accessiories for Laundry Building Delivery | 7d | 2013-06-10 | 2013-06-16 | MOB-TU-ELC-140 SS+25d, MOB-OF-SF-160 SS+5d |  |  |  |  | 11d | 0d |  | Mobilizasyon Yeni WBS [56 h] | 1,120 |  |
| MOB-OF-SF-190 |  | Installation of Laundry Equipments | 2d | 2013-06-17 | 2013-06-18 | MOB-TS-LS-110, MOB-OF-SF-170 |  |  |  |  | 11d | 40.38d |  | Mobilizasyon Yeni WBS [16 h] | 320 |  |

| ID | WBS | Activity | Duration | Start | Finish | Predecessors | Complete | Remaining | Planned start | Planned finish | Total float | Free float | Resources | Cost |
| --- | --- | --- | --- | --- | --- | --- | --- | --- | --- | --- | --- | --- | --- | --- |
|  | 5 | **Canteen and Kitchen** |  | 2013-02-11 | 2013-06-22 |  |  |  |  |  |  |  |  |  |
|  | 1 | **Canteen for Engineers (305 m2)** |  | 2013-02-20 | 2013-06-19 |  |  |  |  |  |  |  |  |  |
| MOB-OF-CE-100 |  | Design for Engineer Canteen Building | 20d | 2013-02-20 A | 2013-03-11 A |  | 100% |  | 2013-03-21 | 2013-04-09 |  |  | Mobilizasyon Yeni WBS [160 h] | 3,200 |
| MOB-OF-CE-110 |  | Engineer Canteen Building Delivery | 30d | 2013-04-01 A | 2013-05-10 | MOB-OF-CE-100 FS+25d |  | 30d | 2013-04-04 | 2013-05-04 | 10d | 0d | Mobilizasyon Yeni WBS [240 h] | 4,800 |
| MOB-OF-CE-190 |  | Procurement of Equipment/Furnitere for Worker Recreation | 10d | 2013-04-16 | 2013-04-25 | MOB-OF-CE-110 SS+15d |  |  |  |  | 10d | 0d | Mobilizasyon Yeni WBS [80 h] | 1,600 |
| MOB-OF-CE-120 |  | Site Preperation-Earthworks for Engineer Canteen Building | 5d | 2013-04-21 | 2013-04-25 | MOB-OF-CE-110 SS+20d |  |  |  |  | 34d | 0d | Mobilizasyon Yeni WBS [40 h] | 800 |
| MOB-OF-CE-130 |  | Concrete Foundation of Engineer Canteen Building | 7d | 2013-04-26 | 2013-05-02 | MOB-OF-CE-120 |  |  |  |  | 34d | 8d | Mobilizasyon Yeni WBS [56 h] | 1,120 |
| MOB-OF-CE-200 |  | Equipment/Furnitere Delivery to Site | 40d | 2013-04-26 | 2013-06-04 | MOB-OF-CE-190 |  |  |  |  | 10d | 0d | Mobilizasyon Yeni WBS [320 h] | 6,400 |
| MOB-OF-CE-140 |  | Installation of Engineer Canteen Building | 12d | 2013-05-11 | 2013-05-22 | MOB-OF-CE-110, MOB-OF-CE-130 |  |  |  |  | 26d | 0d | Mobilizasyon Yeni WBS [96 h] | 1,920 |
| MOB-OF-CE-150 |  | Floor Covering for Engineer Canteen Building | 7d | 2013-05-21 | 2013-05-27 | MOB-OF-CE-140 SS+10d |  |  |  |  | 95d | 62.38d | Mobilizasyon Yeni WBS [56 h] | 1,120 |
| MOB-OF-CE-160 |  | Electrical Cable Installation for Engineer Canteen Building | 10d | 2013-06-05 | 2013-06-14 | MOB-OF-CE-140, MOB-TU-ELC-130 SS+30d |  |  |  |  | 13d | 0d | Mobilizasyon Yeni WBS [80 h] | 1,600 |
| MOB-OF-CE-210 |  | Installation of Equipment/Furnitere | 10d | 2013-06-05 | 2013-06-14 | MOB-OF-CE-200 |  |  |  |  | 10d | 0d | Mobilizasyon Yeni WBS [80 h] | 1,600 |
| MOB-OF-CE-170 |  | Mounting Electrical Accessiories for Engineer Canteen Building | 7d | 2013-06-10 | 2013-06-16 | MOB-TU-ELC-140 SS+25d, MOB-OF-CE-160 SS+5d |  |  |  |  | 13d | 42.38d | Mobilizasyon Yeni WBS [56 h] | 1,120 |
| MOB-OF-CE-180 |  | Installation of Heating System | 7d | 2013-06-10 | 2013-06-16 | MOB-OF-CE-160 SS+5d |  |  |  |  | 13d | 5.75d | Mobilizasyon Yeni WBS [56 h] | 1,120 |
| MOB-OF-CE-220 |  | Test of Equipment/Furniture | 5d | 2013-06-15 | 2013-06-19 | MOB-OF-CE-210 |  |  |  |  | 10d | 2.75d | Mobilizasyon Yeni WBS [40 h] | 800 |
|  | 2 | **Dinning Hall (Kazakh and Turkish Worker 964 m2)** |  | 2013-02-11 | 2013-06-19 |  |  |  |  |  |  |  |  |  |
| MOB-OF-DH-100 |  | Design for Dinning Hall | 20d | 2013-02-11 A | 2013-02-25 A |  | 100% |  | 2013-03-21 | 2013-04-09 |  |  | Mobilizasyon Yeni WBS [160 h] | 3,200 |
| MOB-OF-DH-110 |  | Dinning Hall Delivery | 30d | 2013-03-05 A | 2013-04-24 | MOB-OF-DH-190, MOB-OF-DH-100 FS+10d | 53% | 14d | 2013-04-04 | 2013-05-04 | 26d | 0d | Mobilizasyon Yeni WBS [240 h] | 4,800 |
| MOB-OF-DH-190 |  | Procurement of Equipment/Furnitere for Worker Recreation | 20d | 2013-04-11 | 2013-04-30 |  |  |  |  |  | 10d | 0d | Mobilizasyon Yeni WBS [160 h] | 3,200 |
| MOB-OF-DH-120 |  | Site Preperation-Earthworks for Dinning Hall | 5d | 2013-04-20 | 2013-04-24 | MOB-OF-DH-110 SS+20d, MOB-SP-GE-110 |  |  |  |  | 26d | 0d | Mobilizasyon Yeni WBS [40 h] | 800 |
| MOB-OF-DH-130 |  | Concrete Foundation of Dinning Hall | 10d | 2013-04-25 | 2013-05-04 | MOB-OF-DH-110, MOB-OF-DH-120 |  |  |  |  | 26d | 0d | Mobilizasyon Yeni WBS [80 h] | 1,600 |
| MOB-OF-DH-200 |  | Equipment/Furnitere Delivery to Site | 35d | 2013-05-01 | 2013-06-04 | MOB-OF-DH-190 |  |  |  |  | 10d | 0d | Mobilizasyon Yeni WBS [280 h] | 5,600 |
| MOB-OF-DH-140 |  | Installation of Dinning Hall | 15d | 2013-05-05 | 2013-05-19 | MOB-OF-DH-110, MOB-OF-DH-130 |  |  |  |  | 26d | 0d | Mobilizasyon Yeni WBS [120 h] | 2,400 |
| MOB-OF-DH-150 |  | Floor Covering for Dinning Hall | 7d | 2013-05-20 | 2013-05-26 | MOB-OF-DH-140 |  |  |  |  | 34d | 63.38d | Mobilizasyon Yeni WBS [56 h] | 1,120 |
| MOB-OF-DH-160 |  | Electrical Cable Installation for Dinning Hall | 10d | 2013-05-20 | 2013-05-29 | MOB-OF-DH-140 |  |  |  |  | 26d | 0d | Mobilizasyon Yeni WBS [80 h] | 1,600 |
| MOB-OF-DH-170 |  | Mounting Electrical Accessiories for Dinning Hall | 5d | 2013-05-25 | 2013-05-29 | MOB-OF-DH-160 SS+5d, MOB-TU-ELC-140 SS |  |  |  |  | 31d | 60.38d | Mobilizasyon Yeni WBS [40 h] | 800 |
| MOB-OF-DH-180 |  | Installation of Heating System | 5d | 2013-05-30 | 2013-06-03 | MOB-OF-DH-160 |  |  |  |  | 26d | 18.75d | Mobilizasyon Yeni WBS [40 h] | 800 |
| MOB-OF-DH-210 |  | Installation of Equipment/Furnitere | 10d | 2013-06-05 | 2013-06-14 | MOB-OF-DH-200 |  |  |  |  | 10d | 0d | Mobilizasyon Yeni WBS [80 h] | 1,600 |
| MOB-OF-DH-220 |  | Test of Equipment/Furniture | 5d | 2013-06-15 | 2013-06-19 | MOB-OF-DH-210 |  |  |  |  | 10d | 2.75d | Mobilizasyon Yeni WBS [40 h] | 800 |

| ID | WBS | Activity | Duration | Start | Finish | Predecessors | Complete | Remaining | Planned start | Planned finish | Total float | Free float | Resources | Cost |
| --- | --- | --- | --- | --- | --- | --- | --- | --- | --- | --- | --- | --- | --- | --- |
|  | 3 | **Kitchen (601 m2)** |  | 2013-02-11 | 2013-06-22 |  |  |  |  |  |  |  |  |  |
| MOB-OF-KT-100 |  | Design of Kitchen | 20d | 2013-02-11 A | 2013-02-25 A | MOB-OF-DH-100 SS | 100% |  | 2013-03-21 | 2013-04-09 |  |  | Mobilizasyon Yeni WBS [160 h] | 3,200 |
| MOB-OF-KT-110 |  | Kitchen Delivery | 45d | 2013-03-05 A | 2013-05-03 | MOB-OF-KT-100 FS+10d | 49% | 23d | 2013-04-04 | 2013-05-19 | 7.25d | 1d | Mobilizasyon Yeni WBS [360 h] | 7,200 |
| MOB-OF-KT-190 |  | Procurement of Equipment/Furnitere for Worker Recreation | 10d | 2013-04-18 | 2013-04-28 | MOB-OF-KT-110 SS+45d |  |  |  |  | 7.25d | 0d | Mobilizasyon Yeni WBS [80 h] | 1,600 |
| MOB-OF-KT-200 |  | Equipment/Furnitere Delivery to Site | 40d | 2013-04-28 | 2013-06-07 | MOB-OF-KT-190 |  |  |  |  | 7.25d | 0d | Mobilizasyon Yeni WBS [320 h] | 6,400 |
| MOB-OF-KT-120 |  | Site Preperation-Earthworks for Kitchen | 5d | 2013-04-30 | 2013-05-04 | MOB-OF-KT-110 SS+20d, MOB-SP-GE-110 FS+10d |  |  |  |  | 26d | 0d | Mobilizasyon Yeni WBS [40 h] | 800 |
| MOB-OF-KT-130 |  | Concrete Foundation of Kitchen | 8d | 2013-05-05 | 2013-05-12 | MOB-OF-KT-110, MOB-OF-KT-120 |  |  |  |  | 26d | 0d | Mobilizasyon Yeni WBS [64 h] | 1,280 |
| MOB-OF-KT-140 |  | Installation of Kitchen | 12d | 2013-05-13 | 2013-05-24 | MOB-OF-KT-110, MOB-OF-KT-130 |  |  |  |  | 26d | 0d | Mobilizasyon Yeni WBS [96 h] | 1,920 |
| MOB-OF-KT-150 |  | Floor Covering for Kitchen | 5d | 2013-05-25 | 2013-05-29 | MOB-OF-KT-140 |  |  |  |  | 31d | 60.38d | Mobilizasyon Yeni WBS [40 h] | 800 |
| MOB-OF-KT-160 |  | Electrical Cable Installation for Kitchen | 7d | 2013-05-25 | 2013-05-31 | MOB-TU-ELC-130 SS, MOB-OF-KT-140 |  |  |  |  | 26d | 0d | Mobilizasyon Yeni WBS [56 h] | 1,120 |
| MOB-OF-KT-170 |  | Mounting Electrical Accessiories for Kitchen | 5d | 2013-05-30 | 2013-06-03 | MOB-OF-KT-160 SS+5d |  |  |  |  | 26d | 55.38d | Mobilizasyon Yeni WBS [40 h] | 800 |
| MOB-OF-KT-180 |  | Installation of Heating System | 5d | 2013-05-30 | 2013-06-03 | MOB-OF-KT-160 SS+5d |  |  |  |  | 26d | 18.75d | Mobilizasyon Yeni WBS [40 h] | 800 |
| MOB-OF-KT-210 |  | Installation of Equipment/Furnitere | 10d | 2013-06-07 | 2013-06-17 | MOB-OF-KT-200 |  |  |  |  | 7.25d | 0d | Mobilizasyon Yeni WBS [80 h] | 1,600 |
| MOB-OF-KT-220 |  | Test of Equipment/Furniture | 5d | 2013-06-17 | 2013-06-22 | MOB-OF-KT-210 |  |  |  |  | 7.25d | 0d | Mobilizasyon Yeni WBS [40 h] | 800 |
|  | 6 | **Medical Facilities (122 m2)** |  | 2013-02-25 | 2013-06-21 |  |  |  |  |  |  |  |  |  |
| MOB-OF-MF-100 |  | Design of First Aid Building | 20d | 2013-02-25 A | 2013-03-11 A | MOB-OF-KT-100 | 100% |  | 2013-03-21 | 2013-04-09 |  |  | Mobilizasyon Yeni WBS [160 h] | 3,200 |
| MOB-OF-MF-110 |  | First Aid Building Delivery | 35d | 2013-04-11 | 2013-05-15 | MOB-OF-MF-100 FS+25d |  |  |  |  | 16d | 0d | Mobilizasyon Yeni WBS [280 h] | 5,600 |
| MOB-OF-MF-120 |  | Site Preperation-Earthworks for First Aid Building | 7d | 2013-04-26 | 2013-05-02 | MOB-OF-MF-110 SS+15d, MOB-SP-GE-110 |  |  |  |  | 19d | 0d | Mobilizasyon Yeni WBS [56 h] | 1,120 |
| MOB-OF-MF-130 |  | Concrete Foundation of First Aid Building | 10d | 2013-05-03 | 2013-05-12 | MOB-OF-MF-120 |  |  |  |  | 19d | 3d | Mobilizasyon Yeni WBS [80 h] | 1,600 |
| MOB-OF-MF-140 |  | Installation of First Aid Building | 12d | 2013-05-16 | 2013-05-27 | MOB-OF-MF-130, MOB-OF-MF-110 |  |  |  |  | 16d | 0d | Mobilizasyon Yeni WBS [96 h] | 1,920 |
| MOB-OF-MF-150 |  | Floor Covering for First Aid Building | 5d | 2013-05-28 | 2013-06-01 | MOB-OF-MF-140 |  |  |  |  | 28d | 57.38d | Mobilizasyon Yeni WBS [40 h] | 800 |
| MOB-OF-MF-160 |  | Electrical Cable Installation for First Aid Building | 10d | 2013-06-05 | 2013-06-14 | MOB-OF-MF-140, MOB-TU-ELC-130 SS+30d |  |  |  |  | 8d | 0d | Mobilizasyon Yeni WBS [80 h] | 1,600 |
| MOB-OF-MF-170 |  | Mounting Electrical Accessiories for First Aid Building | 7d | 2013-06-15 | 2013-06-21 | MOB-OF-MF-160, MOB-TU-ELC-140 SS+20d |  |  |  |  | 8d | 37.38d | Mobilizasyon Yeni WBS [56 h] | 1,120 |
| MOB-OF-MF-180 |  | Installation of Heating System | 7d | 2013-06-15 | 2013-06-21 | MOB-OF-MF-160 |  |  |  |  | 8d | 37.38d | Mobilizasyon Yeni WBS [56 h] | 1,120 |

| ID | WBS | Activity | Duration | Start | Finish | Predecessors | Complete | Remaining | Planned start | Planned finish | Total float | Free float | Constraint | Resources | Cost | Actual cost | user_text7 |
| --- | --- | --- | --- | --- | --- | --- | --- | --- | --- | --- | --- | --- | --- | --- | --- | --- | --- |
|  | 7 | **Gym and Recreation Facilities** |  | 2013-02-25 | 2013-07-08 |  |  |  |  |  |  |  |  |  |  |  |  |
|  | 1 | **Worker Recreation ( Turkish and Kazakh Worker 990 m2)** |  | 2013-02-25 | 2013-07-08 |  |  |  |  |  |  |  |  |  |  |  |  |
| MOB-RF-WR-100 |  | Design of Worker Recreation Building | 20d | 2013-02-25 A | 2013-03-11 A | MOB-OF-KT-100 | 100% |  | 2013-03-21 | 2013-04-09 |  |  |  | Mobilizasyon Yeni WBS [160 h] | 3,200 |  |  |
| MOB-RF-WR-110 |  | Worker Recreation Building Delivery | 50d | 2013-03-20 A | 2013-05-29 | MOB-RF-WR-100 FS+10d | 20% | 40d | 2013-04-04 | 2013-05-24 | -9d | 0d |  | Mobilizasyon Yeni WBS [400 h] | 8,000 | 1,600 | baseline |
| MOB-RF-WR-200 |  | Procurement of Equipment/Furnitere for Worker Recreation | 15d | 2013-04-13 | 2013-04-28 | MOB-RF-WR-110 SS+25d |  |  | 2013-04-06 | 2013-04-20 | 7.25d | 0d |  | Mobilizasyon Yeni WBS [120 h] | 2,400 |  | baseline |
| MOB-RF-WR-120 |  | Site Preperation-Earthworks for Worker Recreation Building | 5d | 2013-04-28 | 2013-05-03 | MOB-RF-WR-110 SS+40d, MOB-SP-GE-110 |  |  | 2013-04-21 | 2013-04-25 | 10.25d | 0d | start on or after 2013-04-21 | Mobilizasyon Yeni WBS [40 h] | 800 |  | baseline |
| MOB-RF-WR-210 |  | Equipment/Furnitere Delivery to Site | 40d | 2013-04-28 | 2013-06-07 | MOB-RF-WR-200 |  |  | 2013-04-21 | 2013-05-30 | 7.25d | 16.25d | start on or after 2013-04-21 | Mobilizasyon Yeni WBS [320 h] | 6,400 |  | baseline |
| MOB-RF-WR-130 |  | Concrete Foundation of Worker Recreation Building | 7d | 2013-05-03 | 2013-05-10 | MOB-RF-WR-120 |  |  | 2013-04-26 | 2013-05-02 | 10.25d | 19.25d | start on or after 2013-04-26 | Mobilizasyon Yeni WBS [56 h] | 1,120 |  | baseline |
| MOB-RF-WR-140 |  | Installation of Worker Recreation Building | 10d | 2013-05-30 | 2013-06-08 | MOB-RF-WR-130, MOB-RF-WR-110 |  |  | 2013-05-23 | 2013-06-01 | -9d | 0d | start on or after 2013-05-23 | Mobilizasyon Yeni WBS [80 h] | 1,600 |  | baseline |
| MOB-RF-WR-150 |  | Floor Covering for Worker Recreation Building | 5d | 2013-06-09 | 2013-06-13 | MOB-RF-WR-140 |  |  | 2013-06-02 | 2013-06-06 | -9d | 0d | start on or after 2013-06-02 | Mobilizasyon Yeni WBS [40 h] | 800 |  | baseline |
| MOB-RF-WR-160 |  | Electrical Cable Installation for Worker Recreation Building | 8d | 2013-06-09 | 2013-06-16 | MOB-RF-WR-140, MOB-TU-ELC-130 SS+30d |  |  | 2013-06-02 | 2013-06-09 | 6d | 0d | start on or after 2013-06-02 | Mobilizasyon Yeni WBS [64 h] | 1,280 |  | baseline |
| MOB-RF-WR-190 |  | Installation of WC | 10d | 2013-06-14 | 2013-06-23 | MOB-RF-WR-150, MOB-TU-SE-140 SS |  |  | 2013-06-07 | 2013-06-16 | -9d | 0d | start on or after 2013-06-07 | Mobilizasyon Yeni WBS [80 h] | 1,600 |  | baseline |
| MOB-RF-WR-170 |  | Mounting Electrical Accessiories for Worker Recreation Building | 7d | 2013-06-17 | 2013-06-23 | MOB-RF-WR-160, MOB-TU-ELC-140 SS+30d |  |  | 2013-06-10 | 2013-06-16 | 6d | 35.38d | start on or after 2013-06-10 | Mobilizasyon Yeni WBS [56 h] | 1,120 |  | baseline |
| MOB-RF-WR-180 |  | Installation of Heating System | 7d | 2013-06-17 | 2013-06-23 | MOB-RF-WR-160 |  |  | 2013-06-10 | 2013-06-16 | 6d | 35.38d | start on or after 2013-06-10 | Mobilizasyon Yeni WBS [56 h] | 1,120 |  | baseline |
| MOB-RF-WR-220 |  | Installation of Equipment/Furnitere | 10d | 2013-06-24 | 2013-07-03 | MOB-RF-WR-190, MOB-RF-WR-210 |  |  | 2013-06-17 | 2013-06-26 | -9d | 0d | start on or after 2013-06-17 | Mobilizasyon Yeni WBS [80 h] | 1,600 |  | baseline |
| MOB-RF-WR-230 |  | Test of Equipment/Furniture | 5d | 2013-07-04 | 2013-07-08 | MOB-RF-WR-220 |  |  | 2013-06-25 | 2013-06-29 | -9d | 0d | start on or after 2013-06-25 | Mobilizasyon Yeni WBS [40 h] | 800 |  | baseline |
|  | 2 | **Engineer Recreation (372 m2)** |  | 2013-02-25 | 2013-06-30 |  |  |  |  |  |  |  |  |  |  |  |  |
| MOB-RF-ER-100 |  | Design of Engineer Recreation Building | 20d | 2013-02-25 A | 2013-03-11 A | MOB-OF-KT-100 | 100% |  | 2013-03-21 | 2013-04-09 |  |  |  | Mobilizasyon Yeni WBS [160 h] | 3,200 |  |  |
| MOB-RF-ER-110 |  | Engineer Recreation Building Delivery | 40d | 2013-03-15 A | 2013-05-14 | MOB-RF-ER-100 FS+5d | 15% | 34d | 2013-04-04 | 2013-05-14 | -1d | 0d |  | Mobilizasyon Yeni WBS [320 h] | 6,400 |  |  |
| MOB-RF-ER-200 |  | Procurement of Equipment/Furnitere for Worker Recreation | 15d | 2013-04-11 | 2013-04-25 | MOB-RF-ER-110 SS+25d |  |  |  |  | 10d | 0d |  | Mobilizasyon Yeni WBS [120 h] | 2,400 |  |  |
| MOB-RF-ER-120 |  | Site Preperation-Earthworks for Engineer Recreation Building | 7d | 2013-04-20 | 2013-04-26 | MOB-RF-ER-110 SS+30d, MOB-SP-GE-110 |  |  |  |  | 7d | 0d |  | Mobilizasyon Yeni WBS [56 h] | 1,120 |  |  |
| MOB-RF-ER-210 |  | Equipment/Furnitere Delivery to Site | 40d | 2013-04-26 | 2013-06-04 | MOB-RF-ER-200 |  |  |  |  | 10d | 11d |  | Mobilizasyon Yeni WBS [320 h] | 6,400 |  |  |
| MOB-RF-ER-130 |  | Concrete Foundation of Engineer Recreation Building | 10d | 2013-04-27 | 2013-05-06 | MOB-RF-ER-120 |  |  |  |  | 7d | 8d |  | Mobilizasyon Yeni WBS [80 h] | 1,600 |  |  |
| MOB-RF-ER-140 |  | Installation of Engineer Recreation Building | 15d | 2013-05-15 | 2013-05-29 | MOB-RF-ER-110, MOB-RF-ER-130 |  |  |  |  | -1d | 0d |  | Mobilizasyon Yeni WBS [120 h] | 2,400 |  |  |
| MOB-RF-ER-150 |  | Floor Covering for Engineer Recreation Building | 7d | 2013-05-30 | 2013-06-05 | MOB-RF-ER-140 |  |  |  |  | -1d | 0d |  | Mobilizasyon Yeni WBS [56 h] | 1,120 |  |  |
| MOB-RF-ER-160 |  | Electrical Cable Installation for Engineer Recreation Building | 10d | 2013-05-30 | 2013-06-08 | MOB-TU-ELC-130 SS+20d, MOB-RF-ER-140 |  |  |  |  | 11d | 0d |  | Mobilizasyon Yeni WBS [80 h] | 1,600 |  |  |
| MOB-RF-ER-190 |  | Installation of WC | 10d | 2013-06-06 | 2013-06-15 | MOB-TU-SE-140 SS, MOB-RF-ER-150 |  |  |  |  | -1d | 0d |  | Mobilizasyon Yeni WBS [80 h] | 1,600 |  |  |
| MOB-RF-ER-170 |  | Mounting Electrical Accessiories for Engineer Recreation Building | 10d | 2013-06-09 | 2013-06-18 | MOB-RF-ER-160, MOB-TU-ELC-140 SS+20d |  |  |  |  | 11d | 40.38d |  | Mobilizasyon Yeni WBS [80 h] | 1,600 |  |  |
| MOB-RF-ER-180 |  | Installation of Heating System | 7d | 2013-06-09 | 2013-06-15 | MOB-RF-ER-160 |  |  |  |  | 14d | 43.38d |  | Mobilizasyon Yeni WBS [56 h] | 1,120 |  |  |
| MOB-RF-ER-220 |  | Installation of Equipment/Furnitere | 10d | 2013-06-16 | 2013-06-25 | MOB-RF-ER-190, MOB-RF-ER-210 |  |  |  |  | -1d | 0d |  | Mobilizasyon Yeni WBS [80 h] | 1,600 |  |  |
| MOB-RF-ER-230 |  | Test of Equipment/Furniture | 5d | 2013-06-26 | 2013-06-30 | MOB-RF-ER-220 |  |  |  |  | -1d | 8d |  | Mobilizasyon Yeni WBS [40 h] | 800 |  |  |

| ID | WBS | Activity | Duration | Start | Finish | Predecessors | Complete | Remaining | Planned start | Planned finish | Total float | Free float | Resources | Cost |
| --- | --- | --- | --- | --- | --- | --- | --- | --- | --- | --- | --- | --- | --- | --- |
|  | 3 | **Social Facility (170 m2)** |  | 2013-02-25 | 2013-06-30 |  |  |  |  |  |  |  |  |  |
| MOB-RF-SF-100 |  | Design of Social Facility Building | 20d | 2013-02-25 A | 2013-03-11 A | MOB-WS-WWH-100, MOB-WS-WWH-170, MOB-WS-WHE-100, MOB-RF-ER-100 | 100% |  | 2013-03-21 | 2013-04-09 |  |  | Mobilizasyon Yeni WBS [160 h] | 3,200 |
| MOB-RF-SF-110 |  | Social Facility Building Delivery | 30d | 2013-04-01 A | 2013-05-10 | MOB-OF-CE-110 SS |  | 30d | 2013-04-04 | 2013-05-04 | 24d | 0d | Mobilizasyon Yeni WBS [240 h] | 4,800 |
| MOB-RF-SF-200 |  | Procurement of Equipment/Furnitere for Worker Recreation | 10d | 2013-04-11 | 2013-04-20 | MOB-RF-SC-110 SS+10d |  |  |  |  | 15d | 0d | Mobilizasyon Yeni WBS [80 h] | 1,600 |
| MOB-RF-SF-120 |  | Site Preperation-Earthworks for Social Facility Building | 5d | 2013-04-21 | 2013-04-25 | MOB-RF-SF-110 SS+20d, MOB-SP-GE-110 |  |  |  |  | 32d | 0d | Mobilizasyon Yeni WBS [40 h] | 800 |
| MOB-RF-SF-210 |  | Equipment/Furnitere Delivery to Site | 40d | 2013-04-21 | 2013-05-30 | MOB-RF-SF-200 |  |  |  |  | 15d | 16d | Mobilizasyon Yeni WBS [320 h] | 6,400 |
| MOB-RF-SF-130 |  | Concrete Foundation of Social Facility Building | 7d | 2013-04-26 | 2013-05-02 | MOB-RF-SF-120 |  |  |  |  | 32d | 8d | Mobilizasyon Yeni WBS [56 h] | 1,120 |
| MOB-RF-SF-140 |  | Installation of Social Facility Building | 12d | 2013-05-11 | 2013-05-22 | MOB-RF-SF-110, MOB-RF-SF-130 |  |  |  |  | 24d | 0d | Mobilizasyon Yeni WBS [96 h] | 1,920 |
| MOB-RF-SF-150 |  | Floor Covering for Social Facility Building | 10d | 2013-05-18 | 2013-05-27 | MOB-RF-SF-140 SS+7d |  |  |  |  | 28d | 0d | Mobilizasyon Yeni WBS [80 h] | 1,600 |
| MOB-RF-SF-190 |  | Installation of WC | 5d | 2013-05-28 | 2013-06-01 | MOB-TU-SE-140 SS, MOB-RF-SF-150 |  |  |  |  | 28d | 37d | Mobilizasyon Yeni WBS [40 h] | 800 |
| MOB-RF-SF-160 |  | Electrical Cable Installation for Social Facility Building | 7d | 2013-06-05 | 2013-06-11 | MOB-TU-ELC-130 SS+30d, MOB-RF-SF-140 |  |  |  |  | 11d | 0d | Mobilizasyon Yeni WBS [56 h] | 1,120 |
| MOB-RF-SF-170 |  | Mounting Electrical Accessiories for Social Facility Building | 7d | 2013-06-12 | 2013-06-18 | MOB-RF-SF-160, MOB-TU-ELC-140 SS+20d |  |  |  |  | 11d | 0d | Mobilizasyon Yeni WBS [56 h] | 1,120 |
| MOB-RF-SF-180 |  | Installation of Heating System | 5d | 2013-06-14 | 2013-06-18 | MOB-RF-SF-170 SS+2d |  |  |  |  | 11d | 40.38d | Mobilizasyon Yeni WBS [40 h] | 800 |
| MOB-RF-SF-220 |  | Installation of Equipment/Furnitere | 10d | 2013-06-16 | 2013-06-25 | MOB-RF-ER-190, MOB-RF-SF-210 |  |  |  |  | -1d | 0d | Mobilizasyon Yeni WBS [80 h] | 1,600 |
| MOB-RF-SF-230 |  | Test of Equipment/Furniture | 5d | 2013-06-26 | 2013-06-30 | MOB-RF-SF-220 |  |  |  |  | -1d | 8d | Mobilizasyon Yeni WBS [40 h] | 800 |
|  | 4 | **Social Club for Employer (484 m2)** |  | 2013-02-25 | 2013-06-26 |  |  |  |  |  |  |  |  |  |
| MOB-RF-SC-100 |  | Design of Employer Social Club Building | 20d | 2013-02-25 A | 2013-03-11 A | MOB-WS-WWH-170, MOB-WS-WWH-100, MOB-WS-WHE-100, MOB-RF-ER-100 | 100% |  | 2013-03-21 | 2013-04-09 |  |  | Mobilizasyon Yeni WBS [160 h] | 3,200 |
| MOB-RF-SC-110 |  | Employer Social Club Delivery | 40d | 2013-03-29 A | 2013-05-20 | MOB-OF-CE-100 FS+30d, MOB-OF-CE-110 SS |  | 40d | 2013-04-09 | 2013-05-19 | 3d | 0d | Mobilizasyon Yeni WBS [320 h] | 6,400 |
| MOB-RF-SC-200 |  | Procurement of Equipment/Furnitere for Worker Recreation | 10d | 2013-04-11 | 2013-04-20 | MOB-RF-SC-110 SS+10d |  |  |  |  | 15d | 0d | Mobilizasyon Yeni WBS [80 h] | 1,600 |
| MOB-RF-SC-120 |  | Site Preperation-Earthworks for Employer Social Club Building | 5d | 2013-04-20 | 2013-04-24 | MOB-SP-GE-110, MOB-RF-SC-110 SS+20d |  |  |  |  | 22d | 0d | Mobilizasyon Yeni WBS [40 h] | 800 |
| MOB-RF-SC-210 |  | Equipment/Furnitere Delivery to Site | 40d | 2013-04-21 | 2013-05-30 | MOB-RF-SC-200 |  |  |  |  | 15d | 12d | Mobilizasyon Yeni WBS [320 h] | 6,400 |
| MOB-RF-SC-130 |  | Concrete Foundation of Employer Social Club Building | 7d | 2013-04-25 | 2013-05-01 | MOB-RF-SC-120 |  |  |  |  | 22d | 19d | Mobilizasyon Yeni WBS [56 h] | 1,120 |
| MOB-RF-SC-140 |  | Installation of Employer Social Club Building | 12d | 2013-05-21 | 2013-06-01 | MOB-RF-SC-130, MOB-RF-SC-110 |  |  |  |  | 3d | 0d | Mobilizasyon Yeni WBS [96 h] | 1,920 |
| MOB-RF-SC-150 |  | Floor Covering for Employer Social Club Building | 7d | 2013-05-28 | 2013-06-03 | MOB-RF-SC-140 SS+7d |  |  |  |  | 3d | 0d | Mobilizasyon Yeni WBS [56 h] | 1,120 |
| MOB-RF-SC-190 |  | Installation of WC | 8d | 2013-06-04 | 2013-06-11 | MOB-RF-SC-150 |  |  |  |  | 3d | 0d | Mobilizasyon Yeni WBS [64 h] | 1,280 |
| MOB-RF-SC-160 |  | Electrical Cable Installation for Employer Social Club Building | 7d | 2013-06-05 | 2013-06-11 | MOB-TU-ELC-130 SS+30d, MOB-RF-SC-140 |  |  |  |  | 11d | 3d | Mobilizasyon Yeni WBS [56 h] | 1,120 |
| MOB-RF-SC-220 |  | Installation of Equipment/Furnitere | 10d | 2013-06-12 | 2013-06-21 | MOB-RF-SC-210, MOB-RF-SC-190 |  |  |  |  | 3d | 0d | Mobilizasyon Yeni WBS [80 h] | 1,600 |
| MOB-RF-SC-170 |  | Mounting Electrical Accessiories for Employer Social Club Building | 7d | 2013-06-15 | 2013-06-21 | MOB-RF-SC-160, MOB-TU-ELC-140 SS+30d |  |  |  |  | 8d | 0d | Mobilizasyon Yeni WBS [56 h] | 1,120 |
| MOB-RF-SC-180 |  | Installation of Heating System | 5d | 2013-06-17 | 2013-06-21 | MOB-RF-SC-170 SS+2d |  |  |  |  | 8d | 37.38d | Mobilizasyon Yeni WBS [40 h] | 800 |
| MOB-RF-SC-230 |  | Test of Equipment/Furniture | 5d | 2013-06-22 | 2013-06-26 | MOB-RF-SC-220 |  |  |  |  | 3d | 12d | Mobilizasyon Yeni WBS [40 h] | 800 |

| ID | WBS | Activity | Type | Duration | Start | Finish | Predecessors | Complete | Remaining | Planned start | Planned finish | Total float | Free float | Constraint | Resources | Cost | Actual cost | NOT | user_text7 |
| --- | --- | --- | --- | --- | --- | --- | --- | --- | --- | --- | --- | --- | --- | --- | --- | --- | --- | --- | --- |
|  | 11 | **Temporary Services** |  |  | 2013-01-07 | 2013-07-20 |  |  |  |  |  |  |  |  |  |  |  |  |  |
|  | 1 | **Food Services** |  |  | 2013-01-07 | 2013-02-28 |  |  |  |  |  |  |  |  |  |  |  |  |  |
| MOB-TS-FS-100 |  | Inquiry for Catering Sub-Contractor |  | 28d | 2013-01-07 A | 2013-02-07 A | MOB-ST-PR-0010 FS+30d | 100% |  | 2013-03-21 | 2013-04-17 |  |  |  | Mobilizasyon Yeni WBS [224 h] | 4,480 |  |  |  |
| MOB-TS-FS-110 |  | Approval and Contract Period |  | 15d | 2013-02-08 A | 2013-02-20 A | MOB-TS-FS-100 | 100% |  | 2013-03-14 | 2013-03-28 |  |  |  | Mobilizasyon Yeni WBS [120 h] | 2,400 |  |  |  |
| MOB-TS-FS-120 |  | Launch Food Services on Site | milestone | 0d | 2013-02-28 A | 2013-02-28 A | MOB-TS-FS-110 FS+7d | 100% |  |  |  |  |  |  |  |  |  |  |  |
|  | 2 | **Cleaning Services (room)** |  |  | 2013-03-20 | 2013-05-20 |  |  |  |  |  |  |  |  |  |  |  |  |  |
| MOB-TS-CS-100 |  | Inquiry for Cleaning Sub-Contractor |  | 20d | 2013-03-20 A | 2013-04-23 | MOB-ST-PR-0010 | 35% | 13d | 2013-03-21 | 2013-04-09 | 40d | 0d |  | Mobilizasyon Yeni WBS [160 h] | 3,200 | 1,120 | baþlangýcý 20 mart |  |
| MOB-TS-CS-110 |  | Approval and Contract Period |  | 20d | 2013-04-24 | 2013-05-13 | MOB-TS-CS-100 |  |  |  |  | 40d | 0d |  | Mobilizasyon Yeni WBS [160 h] | 3,200 |  |  |  |
| MOB-TS-CS-120 |  | Launch Cleaning Services on Site | milestone | 0d | 2013-05-20 | 2013-05-20 | MOB-TS-CS-110 FS+7d |  |  |  |  | 40d | 69.38d |  |  |  |  |  |  |
|  | 4 | **Laundry Services** |  |  | 2013-05-01 | 2013-06-09 |  |  |  |  |  |  |  |  |  |  |  |  |  |
| MOB-TS-LS-110 |  | Laundry Equipment Delivery |  | 30d | 2013-05-01 | 2013-05-30 | MOB-OF-SF-110 FS-15d |  |  |  |  | 20d | 0d |  | Mobilizasyon Yeni WBS [240 h] | 4,800 |  |  |  |
| MOB-TS-LS-120 |  | Launch Laundry Services | milestone | 0d | 2013-06-09 | 2013-06-09 | MOB-TS-LS-110 FS+10d |  |  |  |  | 20d | 49.38d |  |  |  |  |  |  |
|  | 5 | **Security Services** |  |  | 2013-03-20 | 2013-07-20 |  |  |  |  |  |  |  |  |  |  |  |  |  |
| MOB-TS-SS-100 |  | Inquiry for Security Service Sub-Contractor |  | 30d | 2013-03-20 A | 2013-05-03 | MOB-ST-PR-0010 FS+90d | 23% | 23d | 2013-03-21 | 2013-04-19 | 40d | 0d |  | Mobilizasyon Yeni WBS [240 h] | 4,800 | 1,120 | 20 mart baþlangýç |  |
| MOB-TS-SS-110 |  | Approval and Contract Period |  | 10d | 2013-05-04 | 2013-05-13 | MOB-TS-SS-100 |  |  |  |  | 40d | 0d |  | Mobilizasyon Yeni WBS [80 h] | 1,600 |  |  |  |
| MOB-TS-SS-120 |  | Launch Security Services on Site | milestone | 0d | 2013-05-20 | 2013-05-20 | MOB-TS-SS-110 FS+7d |  |  |  |  | 40d | 69.38d |  |  |  |  |  |  |
| MOB-TS-SS-130 |  | Installation of Fire Alarm System for Offices and Dormitories |  | 10d | 2013-07-11 | 2013-07-20 | MOB-TA-DOT-190 FS+10d, MOB-TA-WD-190 FS+10d, MOB-OF-AOB-II-180 FS+10d, MOB-TA-DOT2-190 FS+10d, MOB-OF-AOB-IV-180 FS+10d, MOB-TA-WDR-190 FS+10d |  |  | 2013-06-18 | 2013-06-27 | 41d | 8.38d | start on or after 2013-06-18 | Mobilizasyon Yeni WBS [80 h] | 1,600 |  | Dormitory'lerin bitiþine baðla | baseline |
|  | 12 | **Construction Facilities, Laydown Areas** |  |  | 2013-02-12 | 2013-07-03 |  |  |  |  |  |  |  |  |  |  |  |  |  |
|  | 1 | **Workshops** |  |  | 2013-05-15 | 2013-07-03 |  |  |  |  |  |  |  |  |  |  |  |  |  |
| MOB-CF-WS-100 |  | Earthworks |  | 4d | 2013-05-15 | 2013-05-19 | MOB-SP-GE-120 SS+3d, MOB-TA-EMD-120 FS+10d, MOB-TA-AMD-120 FS+10d, MOB-TA-EED-120 FS+10d, MOB-SP-GE-110 |  |  | 2013-05-08 | 2013-05-11 | -3.75d | 0d | start on or after 2013-05-08 | Mobilizasyon Yeni WBS [32 h] | 640 |  |  | baseline |
| MOB-CF-WS-110 |  | Foundation |  | 12d | 2013-05-19 | 2013-05-31 | MOB-CF-WS-100 |  |  | 2013-05-12 | 2013-05-23 | -0.75d | 3d | start on or after 2013-05-12 | Mobilizasyon Yeni WBS [96 h] | 1,920 |  |  | baseline |
| MOB-CF-WS-120 |  | Steel Structure Erection |  | 10d | 2013-06-08 | 2013-06-18 | MOB-CF-WS-110 FS+5d, MOB-TS-FS-140 |  |  | 2013-05-25 | 2013-06-03 | -3.75d | 0d | start on or after 2013-05-25 | Mobilizasyon Yeni WBS [80 h] | 1,600 |  |  | baseline |
| MOB-CF-WS-130 |  | Roofing & Cladding |  | 7d | 2013-06-20 | 2013-06-26 | MOB-CF-WS-150 SS, MOB-CF-WS-120 FF+2d |  |  | 2013-06-13 | 2013-06-19 | 3d | 32.38d | start on or after 2013-06-13 | Mobilizasyon Yeni WBS [56 h] | 1,120 |  |  | baseline |
| MOB-CF-WS-150 |  | Electrical Power Distribution |  | 10d | 2013-06-20 | 2013-06-29 | MOB-CF-WS-120, MOB-TU-ELC-130 SS+45d |  |  | 2013-06-13 | 2013-06-22 | -3d | 0d | start on or after 2013-06-13 | Mobilizasyon Yeni WBS [80 h] | 1,600 |  |  | baseline |
| MOB-CF-WS-140 |  | Lighting |  | 10d | 2013-06-23 | 2013-07-03 | MOB-CF-WS-120 FS+5d, MOB-CF-WS-150 SS |  |  | 2013-06-16 | 2013-06-25 | -3.75d | 25.62d | start on or after 2013-06-16 | Mobilizasyon Yeni WBS [80 h] | 1,600 |  |  | baseline |

| ID | WBS | Activity | Duration | Start | Finish | Predecessors | Complete | Remaining | Planned start | Planned finish | Total float | Free float | Constraint | Resources | Cost | Actual cost | user_text7 |
| --- | --- | --- | --- | --- | --- | --- | --- | --- | --- | --- | --- | --- | --- | --- | --- | --- | --- |
|  | 2 | **Fabrication Shops** |  | 2013-05-24 | 2013-07-02 |  |  |  |  |  |  |  |  |  |  |  |  |
| MOB-TS-FS-130 |  | Earthworks | 3d | 2013-05-24 | 2013-05-27 | MOB-SP-GE-120 SS+5d, MOB-SP-GE-110, MOB-CF-WS-100 FS+5d |  |  | 2013-05-17 | 2013-05-19 | -3.75d | 0d | start on or after 2013-05-17 | Mobilizasyon Yeni WBS [24 h] | 480 |  | baseline |
| MOB-TS-FS-140 |  | Foundation | 12d | 2013-05-27 | 2013-06-08 | MOB-TS-FS-130 |  |  | 2013-05-20 | 2013-05-31 | -3.75d | 0d | start on or after 2013-05-20 | Mobilizasyon Yeni WBS [96 h] | 1,920 |  | baseline |
| MOB-TS-FS-150 |  | Steel Structure Erection | 7d | 2013-06-13 | 2013-06-20 | MOB-TS-FS-140 FS+5d |  |  | 2013-06-06 | 2013-06-12 | -0.75d | 2.25d | start on or after 2013-06-06 | Mobilizasyon Yeni WBS [56 h] | 1,120 |  | baseline |
| MOB-TS-FS-160 |  | Roofing & Cladding | 5d | 2013-06-23 | 2013-06-27 | MOB-TS-FS-150, MOB-TS-FS-180 SS |  |  | 2013-06-16 | 2013-06-20 | 2d | 31.38d | start on or after 2013-06-16 | Mobilizasyon Yeni WBS [40 h] | 800 |  | baseline |
| MOB-TS-FS-170 |  | Lighting | 10d | 2013-06-23 | 2013-07-02 | MOB-TS-FS-150, MOB-TS-FS-180 SS |  |  | 2013-06-16 | 2013-06-25 | -3d | 26.38d | start on or after 2013-06-16 | Mobilizasyon Yeni WBS [80 h] | 1,600 |  | baseline |
| MOB-TS-FS-180 |  | Electrical Power Distribution | 10d | 2013-06-23 | 2013-07-02 | MOB-CF-WS-150 SS+3d, MOB-TS-FS-150 |  |  | 2013-06-16 | 2013-06-25 | -3d | 0d | start on or after 2013-06-16 | Mobilizasyon Yeni WBS [80 h] | 1,600 |  | baseline |
|  | 3 | **Rest Areas and Toilets** |  | 2013-02-12 | 2013-04-20 |  |  |  |  |  |  |  |  |  |  |  |  |
| MOB-TS-TO-100 |  | Delivery of Toilet Containers | 30d | 2013-02-12 A | 2013-03-15 A | MOB-ST-PR-0060 FS-30d | 100% |  | 2013-03-21 | 2013-04-19 |  |  |  | Mobilizasyon Yeni WBS [240 h] | 4,800 |  |  |
| MOB-TS-TO-110 |  | Site Preperation / Excavation for Site Toilet Containers | 7d | 2013-03-28 A | 2013-04-04 A | MOB-SP-GE-110 FS-5d | 100% |  | 2013-03-31 | 2013-04-06 |  |  |  | Mobilizasyon Yeni WBS [56 h] | 1,120 | 1,120 |  |
| MOB-TS-TO-120 |  | Foundation for Toilet Containers | 10d | 2013-04-05 A | 2013-04-10 A | MOB-TS-TO-110 | 100% |  | 2013-04-06 | 2013-04-16 |  |  |  | Mobilizasyon Yeni WBS [80 h] | 1,600 |  |  |
| MOB-TS-TO-130 |  | Installation of Site Toilet Containers | 10d | 2013-04-09 A | 2013-04-20 | MOB-TS-TO-120 FS+5d |  | 10d | 2013-04-09 | 2013-04-18 | 70d | 99.38d |  | Mobilizasyon Yeni WBS [80 h] | 1,600 |  |  |
|  | 4 | **Laydown Areas** |  | 2013-04-11 | 2013-06-25 |  |  |  |  |  |  |  |  |  |  |  |  |
| MOB-TS-LA-130 |  | Fencing | 1d | 2013-04-11 | 2013-04-11 |  |  |  |  |  | 141d | 108.38d |  | Mobilizasyon Yeni WBS [8 h] | 160 |  |  |
| MOB-TS-LA-100 |  | Earthworks | 3d | 2013-04-30 | 2013-05-02 | MOB-SP-GE-110 FS+10d |  |  |  |  | 48d | 0d |  | Mobilizasyon Yeni WBS [24 h] | 480 |  |  |
| MOB-TS-LA-110 |  | Concrete Works if necessary | 10d | 2013-05-03 | 2013-05-12 | MOB-TS-LA-100 |  |  |  |  | 48d | 77.38d |  | Mobilizasyon Yeni WBS [80 h] | 1,600 |  |  |
| MOB-TS-LA-120 |  | Lighting | 1d | 2013-06-25 | 2013-06-25 | MOB-TU-ELC-130 |  |  |  |  | 66d | 33.38d |  | Mobilizasyon Yeni WBS [8 h] | 160 |  |  |
|  | 13 | **Warehousing and Storage** |  | 2013-01-22 | 2013-06-14 |  |  |  |  |  |  |  |  |  |  |  |  |
|  | 4 | **Warehouse Establishment** |  | 2013-02-18 | 2013-06-14 |  |  |  |  |  |  |  |  |  |  |  |  |
|  | 1 | **Warehouse Without Heat Part 1 (1000 m2)** |  | 2013-02-18 | 2013-06-08 |  |  |  |  |  |  |  |  |  |  |  |  |
| MOB-WS-WWH-100 |  | Design of Warehouse Without Heat | 20d | 2013-02-18 A | 2013-03-11 A | MOB-OF-KT-100 | 100% |  | 2013-03-21 | 2013-04-09 |  |  |  | Mobilizasyon Yeni WBS [160 h] | 3,200 |  |  |
| MOB-WS-WWH-110 |  | Delivery of Warehouse Without Heat Delivery | 40d | 2013-03-15 A | 2013-05-14 | MOB-WS-WWH-100 FS+5d | 15% | 34d | 2013-04-04 | 2013-05-14 | 24d | 0d |  | Mobilizasyon Yeni WBS [320 h] | 6,400 |  |  |
| MOB-WS-WWH-120 |  | Site Preperation-Earthworks for Warehouse Without Heat | 5d | 2013-04-20 | 2013-04-24 | MOB-WS-WWH-110 SS+35d, MOB-SP-GE-110 |  |  |  |  | 34d | 0d |  | Mobilizasyon Yeni WBS [40 h] | 800 |  |  |
| MOB-WS-WWH-130 |  | Concrete Foundation of Warehouse Without Heat | 10d | 2013-04-25 | 2013-05-04 | MOB-WS-WWH-120 |  |  |  |  | 34d | 10d |  | Mobilizasyon Yeni WBS [80 h] | 1,600 |  |  |
| MOB-WS-WWH-140 |  | Installation of Warehouse Without Heat | 15d | 2013-05-15 | 2013-05-29 | MOB-WS-WWH-110, MOB-WS-WWH-130 |  |  |  |  | 24d | 0d |  | Mobilizasyon Yeni WBS [120 h] | 2,400 |  |  |
| MOB-WS-WWH-150 |  | Floor Covering for Warehouse Without Heat | 7d | 2013-05-30 | 2013-06-05 | MOB-WS-WWH-140 |  |  |  |  | 24d | 53.38d |  | Mobilizasyon Yeni WBS [56 h] | 1,120 |  |  |
| MOB-WS-WWH-160 |  | Electrical Cable Installation for Warehouse Without Heat | 10d | 2013-05-30 | 2013-06-08 | MOB-TU-ELC-130 SS+20d, MOB-WS-WWH-140 |  |  |  |  | 83d | 50.38d |  | Mobilizasyon Yeni WBS [80 h] | 1,600 |  |  |

| ID | WBS | Activity | Duration | Start | Finish | Predecessors | Complete | Remaining | Planned start | Planned finish | Total float | Free float | Resources | Cost | Actual cost |
| --- | --- | --- | --- | --- | --- | --- | --- | --- | --- | --- | --- | --- | --- | --- | --- |
|  | 2 | **Warehouse Without Heat Part 2 (1000 m2)** |  | 2013-02-25 | 2013-06-09 |  |  |  |  |  |  |  |  |  |  |
| MOB-WS-WWH-170 |  | Design of Warehouse Without Heat | 20d | 2013-02-25 A | 2013-03-11 A | MOB-OF-KT-100 | 100% |  | 2013-03-21 | 2013-04-09 |  |  | Mobilizasyon Yeni WBS [160 h] | 3,200 |  |
| MOB-WS-WWH-180 |  | Delivery of Warehouse Without Heat Delivery | 40d | 2013-03-15 A | 2013-05-14 | MOB-WS-WWH-170 FS+5d | 15% | 34d | 2013-04-04 | 2013-05-14 | 23.25d | 0.75d | Mobilizasyon Yeni WBS [320 h] | 6,400 |  |
| MOB-WS-WWH-190 |  | Site Preperation-Earthworks for Warehouse Without Heat | 7d | 2013-04-28 | 2013-05-05 | MOB-SP-GE-110, MOB-WS-WWH-180 SS+45d |  |  |  |  | 23.25d | 0d | Mobilizasyon Yeni WBS [56 h] | 1,120 |  |
| MOB-WS-WWH-200 |  | Concrete Foundation of Warehouse Without Heat | 10d | 2013-05-05 | 2013-05-15 | MOB-WS-WWH-190 |  |  |  |  | 23.25d | 0d | Mobilizasyon Yeni WBS [80 h] | 1,600 |  |
| MOB-WS-WWH-210 |  | Installation of Warehouse Without Heat | 15d | 2013-05-15 | 2013-05-30 | MOB-WS-WWH-200, MOB-WS-WWH-180 |  |  |  |  | 23.25d | 0d | Mobilizasyon Yeni WBS [120 h] | 2,400 |  |
| MOB-WS-WWH-220 |  | Floor Covering for Warehouse Without Heat | 7d | 2013-05-30 | 2013-06-06 | MOB-WS-WWH-210 |  |  |  |  | 23.25d | 52.62d | Mobilizasyon Yeni WBS [56 h] | 1,120 |  |
| MOB-WS-WWH-230 |  | Electrical Cable Installation for Warehouse Without Heat | 10d | 2013-05-30 | 2013-06-09 | MOB-TU-ELC-130 SS+20d, MOB-WS-WWH-210 |  |  |  |  | 82.25d | 49.62d | Mobilizasyon Yeni WBS [80 h] | 1,600 |  |
|  | 3 | **Warehouse With Heat (500 m2)** |  | 2013-02-25 | 2013-06-14 |  |  |  |  |  |  |  |  |  |  |
| MOB-WS-WHE-100 |  | Design of Warehouse Without Heat | 20d | 2013-02-25 A | 2013-03-11 A | MOB-OF-KT-100 | 100% |  | 2013-03-21 | 2013-04-09 |  |  | Mobilizasyon Yeni WBS [160 h] | 3,200 |  |
| MOB-WS-WHE-110 |  | Delivery of Warehouse Without Heat Delivery | 40d | 2013-03-15 A | 2013-05-14 | MOB-WS-WHE-100 FS+5d | 15% | 34d | 2013-04-04 | 2013-05-14 | 15.25d | 0.75d | Mobilizasyon Yeni WBS [320 h] | 6,400 |  |
| MOB-WS-WHE-120 |  | Site Preperation-Earthworks for Warehouse Without Heat | 7d | 2013-04-28 | 2013-05-05 | MOB-WS-WHE-110 SS+45d, MOB-SP-GE-110 |  |  |  |  | 15.25d | 0d | Mobilizasyon Yeni WBS [56 h] | 1,120 |  |
| MOB-WS-WHE-130 |  | Concrete Foundation of Warehouse Without Heat | 10d | 2013-05-05 | 2013-05-15 | MOB-WS-WHE-120 |  |  |  |  | 15.25d | 0d | Mobilizasyon Yeni WBS [80 h] | 1,600 |  |
| MOB-WS-WHE-140 |  | Installation of Warehouse Without Heat | 15d | 2013-05-15 | 2013-05-30 | MOB-WS-WHE-130, MOB-WS-WHE-110 |  |  |  |  | 15.25d | 0d | Mobilizasyon Yeni WBS [120 h] | 2,400 |  |
| MOB-WS-WHE-150 |  | Floor Covering for Warehouse Without Heat | 7d | 2013-05-30 | 2013-06-06 | MOB-WS-WHE-140 |  |  |  |  | 23.25d | 52.62d | Mobilizasyon Yeni WBS [56 h] | 1,120 |  |
| MOB-WS-WHE-160 |  | Electrical Cable Installation for Warehouse Without Heat | 10d | 2013-05-30 | 2013-06-09 | MOB-WS-WHE-140, MOB-TU-ELC-130 SS+20d |  |  |  |  | 15.25d | 0d | Mobilizasyon Yeni WBS [80 h] | 1,600 |  |
| MOB-WS-WHE-170 |  | Installation of Heating System | 15d | 2013-05-30 | 2013-06-14 | MOB-WS-WHE-160 SS |  |  |  |  | 15.25d | 44.62d | Mobilizasyon Yeni WBS [120 h] | 2,400 |  |
|  | 1 | **Warehouse** |  | 2013-01-22 | 2013-05-05 |  |  |  |  |  |  |  |  |  |  |
| MOB-WS-WH-140 |  | Advise Procurement of delivery address and contact details | 2.12d | 2013-01-22 A | 2013-01-23 A | MOB-ST-WH-0010 SS-21d | 100% |  | 2013-03-21 | 2013-03-23 |  |  | Mobilizasyon Yeni WBS [17 h] | 340 |  |
| MOB-ST-WH-0130 |  | Impliment Material Control Procedures | 19.62d | 2013-02-24 A | 2013-03-27 A | MOB-ST-WH-0050 SS-7d | 100% |  | 2013-03-21 | 2013-04-09 |  |  | Mobilizasyon Yeni WBS [157 h] | 3,140 | 3,140 |
| MOB-ST-WH-0140 |  | Impliment Stock Control Procedures | 19.62d | 2013-02-24 A | 2013-03-27 A | MOB-ST-WH-0130 SS | 100% |  | 2013-03-21 | 2013-04-09 |  |  | Mobilizasyon Yeni WBS [157 h] | 3,140 | 3,140 |
| MOB-ST-WH-0010 |  | Establish Warehouse facilities | 36.88d | 2013-03-02 A | 2013-04-24 | MOB-ST-PR-0060 FS-10d | 64% | 13.25d | 2013-03-21 | 2013-04-26 | -23.88d | 0d | Mobilizasyon Yeni WBS [295 h] | 5,900 |  |
| MOB-ST-WH-0120 |  | Maintenance and marking materials and small tools | 8.38d | 2013-03-27 A | 2013-04-03 A | MOB-WS-WH-180 SS | 100% |  | 2013-03-27 | 2013-04-04 |  |  | Mobilizasyon Yeni WBS [67 h] | 1,340 | 1,340 |
| MOB-ST-WH-0080 |  | Clean storage for intricate equipment | 8.38d | 2013-03-30 A | 2013-04-07 A | MOB-WS-OL-120 SS | 100% |  | 2013-03-27 | 2013-04-04 |  |  | Mobilizasyon Yeni WBS [67 h] | 1,340 | 1,340 |
| MOB-ST-MC-0050 |  | Implement material control systems - IT related or other | 12.12d | 2013-04-11 | 2013-04-23 | MOB-ST-WH-0130 |  |  |  |  | 55.75d | 0d | Mobilizasyon Yeni WBS [97 h] | 1,940 |  |
| MOB-ST-MC-0060 |  | Implement warehouse philosophies & responsibilities | 8.38d | 2013-04-11 | 2013-04-19 | MOB-ST-MC-0050 SS |  |  |  |  | 71.62d | 101d | Mobilizasyon Yeni WBS [67 h] | 1,340 |  |
| MOB-WS-WH-180 |  | Preservation fluids and coatings | 8.38d | 2013-04-11 | 2013-04-19 | MOB-ST-WH-0100 |  |  |  |  | 133.62d | 101d | Mobilizasyon Yeni WBS [67 h] | 1,340 |  |
| MOB-ST-WH-0030 |  | Communication link to site office | 3.38d | 2013-04-19 | 2013-04-22 | MOB-ST-WH-0010 FS-5d |  |  |  |  | -23.88d | 97.75d | Mobilizasyon Yeni WBS [27 h] | 540 |  |
| MOB-ST-MC-0200 |  | Implement issue systems | 12.12d | 2013-04-23 | 2013-05-05 | MOB-ST-MC-0050 |  |  |  |  | 55.75d | 85.12d | Mobilizasyon Yeni WBS [97 h] | 1,940 |  |

| ID | WBS | Activity | Type | Duration | Start | Finish | Predecessors | Complete | Planned start | Planned finish | Total float | Free float | Constraint | Resources | Cost | Actual cost | user_text7 | NOT |
| --- | --- | --- | --- | --- | --- | --- | --- | --- | --- | --- | --- | --- | --- | --- | --- | --- | --- | --- |
|  | 2 | **Off loading Docks / Platforms** |  |  | 2013-02-27 | 2013-04-08 |  |  |  |  |  |  |  |  |  |  |  |  |
| MOB-ST-WH-0050 |  | Handling equipment for materials |  | 8.38d | 2013-02-27 A | 2013-03-05 A | MOB-ST-WH-0010 SS+15d | 100% | 2013-03-21 | 2013-03-29 |  |  |  | Mobilizasyon Yeni WBS [67 h] | 1,340 |  |  |  |
| MOB-ST-WH-0060 |  | Pallets for storage & handling |  | 8.38d | 2013-02-27 A | 2013-03-05 A | MOB-ST-WH-0050 SS | 100% | 2013-03-21 | 2013-03-29 |  |  |  | Mobilizasyon Yeni WBS [67 h] | 1,340 |  |  |  |
| MOB-WS-OL-120 |  | Packing logs and weather tarpaulins |  | 8.38d | 2013-03-28 A | 2013-04-08 A | MOB-ST-WH-0060 | 100% | 2013-03-27 | 2013-04-04 |  |  |  | Mobilizasyon Yeni WBS [67 h] | 1,340 | 1,340 |  |  |
|  | 3 | **Weather Protection** |  |  | 2013-03-22 | 2013-04-10 |  |  |  |  |  |  |  |  |  |  |  |  |
| MOB-ST-WH-0090 |  | Inclement weather storage |  | 8.38d | 2013-03-22 A | 2013-03-31 A | MOB-ST-WH-0080 SS | 100% | 2013-03-22 | 2013-03-30 |  |  |  | Mobilizasyon Yeni WBS [67 h] | 1,340 | 1,340 |  |  |
| MOB-ST-WH-0100 |  | Moisture prevention - electric warmers etc |  | 8.38d | 2013-04-01 A | 2013-04-10 A | MOB-ST-WH-0090 | 100% | 2013-04-04 | 2013-04-12 |  |  |  | Mobilizasyon Yeni WBS [67 h] | 1,340 | 1,340 |  |  |
|  | 14 | **Security** |  |  | 2013-03-01 | 2013-07-22 |  |  |  |  |  |  |  |  |  |  |  |  |
|  | 1 | **Main Gate** |  |  | 2013-05-10 | 2013-06-19 |  |  |  |  |  |  |  |  |  |  |  |  |
| MOB-SE-MG-100 |  | Cut/Fill Works for Main Gate |  | 3d | 2013-05-10 | 2013-05-12 | MOB-SP-GE-110 FS+20d |  |  |  | -2d | 0d |  | Mobilizasyon Yeni WBS [24 h] | 480 |  |  |  |
| MOB-SE-MG-110 |  | Foundation of Main Gate |  | 5d | 2013-05-13 | 2013-05-17 | MOB-SE-MG-100 |  |  |  | -2d | 0d |  | Mobilizasyon Yeni WBS [40 h] | 800 |  |  |  |
| MOB-SE-MG-120 |  | Gate House Erection |  | 5d | 2013-05-21 | 2013-05-25 | MOB-SE-MG-110 FS+3d |  |  |  | -2d | 8.75d |  | Mobilizasyon Yeni WBS [40 h] | 800 |  |  |  |
| MOB-SE-MG-130 |  | Electricity |  | 10d | 2013-06-05 | 2013-06-14 | MOB-TU-ELC-130 SS+30d, MOB-SE-MG-120 |  |  |  | -12d | 0d |  | Mobilizasyon Yeni WBS [80 h] | 1,600 |  |  |  |
| MOB-SE-MG-140 |  | Installation of CCTV System |  | 5d | 2013-06-15 | 2013-06-19 | MOB-SE-MG-130 |  |  |  | 72d | 39.38d |  | Mobilizasyon Yeni WBS [40 h] | 800 |  |  |  |
|  | 7 | **Access Gates/Control** |  |  | 2013-04-14 | 2013-07-04 |  |  |  |  |  |  |  |  |  |  |  |  |
| MOB-SE-AG-100 |  | Design for Access Gates/Control |  | 20d | 2013-04-14 | 2013-05-04 | MOB-ST-PR-0060 FS+35d |  | 2013-04-07 | 2013-04-26 | -0.75d | 0d |  | Mobilizasyon Yeni WBS [80 h] | 1,600 |  | baseline | 15 mayýs dizayn baþlangýcý |
| MOB-SE-AG-110 |  | Material Delivery to Site |  | 30d | 2013-05-04 | 2013-06-03 | MOB-SE-AG-100 |  | 2013-04-27 | 2013-05-26 | -0.75d | 11.25d | start on or after 2013-04-27 | Mobilizasyon Yeni WBS [240 h] | 4,800 |  | baseline |  |
| MOB-SE-AG-120 |  | Installation of Access Control System |  | 20d | 2013-06-15 | 2013-07-04 | MOB-SE-AG-100, MOB-SE-AG-110, MOB-SE-MG-130 |  | 2013-06-08 | 2013-06-27 | -12d | 0d | start on or after 2013-06-08 | Mobilizasyon Yeni WBS [160 h] | 3,200 |  | baseline |  |
|  | 6 | **Personnel Control** |  |  | 2013-04-14 | 2013-07-11 |  |  |  |  |  |  |  |  |  |  |  |  |
| MOB-SE-PC-100 |  | Design for Personnel Control System |  | 15d | 2013-04-14 | 2013-04-29 | MOB-SE-AG-100 SS, MOB-SE-SI-100 SS |  |  |  | 11.25d | 0d |  | Mobilizasyon Yeni WBS [80 h] | 1,600 |  |  |  |
| MOB-SE-PC-110 |  | Material Delivery to Site |  | 30d | 2013-04-29 | 2013-05-29 | MOB-SE-PC-100 |  |  |  | 24.25d | 36.25d |  | Mobilizasyon Yeni WBS [240 h] | 4,800 |  |  |  |
| MOB-SE-PC-120 |  | Establisment of Personnel Control Card Reader System |  | 7d | 2013-07-05 | 2013-07-11 | MOB-SE-PC-110, MOB-SE-AG-120, MOB-SE-AG-100 |  | 2013-06-20 | 2013-06-26 | -12d | 17.38d | start on or after 2013-06-20 | Mobilizasyon Yeni WBS [56 h] | 1,120 |  | baseline |  |
|  | 5 | **Security Lighting** |  |  | 2013-05-31 | 2013-07-18 |  |  |  |  |  |  |  |  |  |  |  |  |
| MOB-SE-SL-100 |  | Adequate security lighting at stores/warehouse | resource dependent | 15.06d | 2013-05-31 | 2013-06-15 | MOB-TU-ELC-130 SS+25d, MOB-ST-WH-0010 SS+50d, MOB-ST-WH-0010 FS+10d |  |  |  | 14.94d | 44.31d |  | Mobilizasyon Yeni WBS [150 h] | 3,000 |  |  | baþlangýc 20 mayýs |
| MOB-SE-SL-120 |  | Adequate security lighting at camp area |  | 15d | 2013-07-04 | 2013-07-18 | MOB-TA-DOT-160, MOB-TA-WDR-160, MOB-TU-ELC-130 SS+25d, MOB-TA-DOT2-160, MOB-TA-WD-160 |  | 2013-06-15 | 2013-06-29 | -19d | 10.38d | start on or after 2013-06-15 | Mobilizasyon Yeni WBS [120 h] | 2,400 |  | baseline | baþlangýc 20 mayýs |

| ID | WBS | Activity | Type | Duration | Start | Finish | Predecessors | Complete | Planned start | Planned finish | Total float | Free float | Constraint | Resources | Cost | Actual cost | user_text7 | NOT |
| --- | --- | --- | --- | --- | --- | --- | --- | --- | --- | --- | --- | --- | --- | --- | --- | --- | --- | --- |
|  | 4 | **Fencing** |  |  | 2013-03-01 | 2013-07-22 |  |  |  |  |  |  |  |  |  |  |  |  |
| MOB-SE-FE-100 |  | Fencing Point Arrangemant & Design |  | 10d | 2013-03-01 A | 2013-03-10 A | MOB-ST-PR-0060 SS+40d, MOB-SE-TC-100 SS | 100% | 2013-03-21 | 2013-03-30 |  |  |  | Mobilizasyon Yeni WBS [80 h] | 1,600 |  |  |  |
| MOB-SE-FE-110 |  | Fencing of Camp Area |  | 7d | 2013-07-11 | 2013-07-17 | MOB-OF-AOB-II-180 FS+10d, MOB-SE-FE-100, MOB-OF-AOB-IV-180 FS+10d, MOB-TA-WD-190 FS+10d, MOB-TA-WDR-190 FS+10d |  | 2013-06-18 | 2013-06-24 | -23d | 0d | start on or after 2013-06-18 | Mobilizasyon Yeni WBS [56 h] | 1,120 |  | baseline |  |
| MOB-SE-FE-120 |  | Fencing & Security of Yard Areas |  | 5d | 2013-07-18 | 2013-07-22 | MOB-SE-FE-110 |  | 2013-06-25 | 2013-06-29 | -23d | 6.38d | start on or after 2013-06-25 | Mobilizasyon Yeni WBS [40 h] | 800 |  | baseline |  |
|  | 3 | **Signage** |  |  | 2013-04-14 | 2013-06-04 |  |  |  |  |  |  |  |  |  |  |  |  |
| MOB-SE-SI-100 |  | Camp Signage System Design |  | 20d | 2013-04-14 | 2013-05-04 | MOB-ST-PR-0060 FS+35d |  |  |  | 11.25d | 0d |  | Mobilizasyon Yeni WBS [80 h] | 1,600 |  |  | 15 nisan çek dizayný |
| MOB-SE-SI-110 |  | Camp Signage Delivery to Site |  | 30d | 2013-05-04 | 2013-06-03 | MOB-SE-SI-100 |  |  |  | 11.25d | 0d |  | Mobilizasyon Yeni WBS [240 h] | 4,800 |  |  |  |
| MOB-SE-SI-120 |  | Camp Signage Installation |  | 1d | 2013-06-03 | 2013-06-04 | MOB-SE-MG-120, MOB-SE-SI-100, MOB-SE-SI-110 |  |  |  | 11.25d | 0d |  | Mobilizasyon Yeni WBS [8 h] | 160 |  |  |  |
|  | 2 | **Traffic Control** |  |  | 2013-04-14 | 2013-06-18 |  |  |  |  |  |  |  |  |  |  |  |  |
| MOB-SE-TC-100 |  | Traffic Control System Design |  | 20d | 2013-04-14 | 2013-05-04 | MOB-ST-PR-0060 SS+40d, MOB-SE-PC-100 SS |  |  |  | 11.25d | 0d |  | Mobilizasyon Yeni WBS [80 h] | 1,600 |  |  | 1 mayýs |
| MOB-SE-TC-110 |  | Traffic Control System Material Delivery to Site |  | 30d | 2013-05-04 | 2013-06-03 | MOB-SE-TC-100 |  |  |  | 11.25d | 0d |  | Mobilizasyon Yeni WBS [240 h] | 4,800 |  |  |  |
| MOB-SE-TC-120 |  | Traffic Control System Installation |  | 15d | 2013-06-03 | 2013-06-18 | MOB-SE-SI-120 SS, MOB-SE-TC-100, MOB-SE-TC-110 |  |  |  | 11.25d | 40.62d |  | Mobilizasyon Yeni WBS [120 h] | 2,400 |  |  | material supply ekle hepsine |
|  | 15 | **Procurement Activities** |  |  | 2013-01-01 | 2013-05-25 |  |  |  |  |  |  |  |  |  |  |  |  |
|  | 5 | **HSE** |  |  | 2013-01-06 | 2013-03-15 |  |  |  |  |  |  |  |  |  |  |  |  |
| MOB-HS-HS-0030 |  | Purchase Order for Personal Protective (PPE) Material | resource dependent | 30d | 2013-01-06 A | 2013-02-04 A | MOB-ST-PR-0010 FS+20d | 100% |  |  |  |  |  | Mobilizasyon Yeni WBS [297 h] | 5,940 |  |  |  |
| MOB-HS-HS-0040 |  | Arrival of Personal Protective (PPE) Material to Site | resource dependent | 21d | 2013-02-15 A | 2013-03-15 A | MOB-HS-HS-0030 | 100% | 2013-02-05 | 2013-02-25 |  |  |  | Mobilizasyon Yeni WBS [207 h] | 4,140 | 4,140 |  |  |
|  | 1 | **Small Tools** |  |  | 2013-01-01 | 2013-02-08 |  |  |  |  |  |  |  |  |  |  |  |  |
| A1570 |  | Inquiry for Small Tools |  | 3d | 2013-01-01 A | 2013-01-05 A | MOB-ST-PR-0010 SS+30d | 100% | 2013-03-21 | 2013-03-23 |  |  |  | Mobilizasyon Yeni WBS [24 h] | 480 |  |  |  |
| A1680 |  | Procurement of Small Tools |  | 5d | 2013-01-06 A | 2013-01-11 A | A1570 | 100% | 2013-01-15 | 2013-01-19 |  |  |  | Mobilizasyon Yeni WBS [40 h] | 800 |  |  |  |
| A1690 |  | Delivery on Site |  | 30d | 2013-01-12 A | 2013-02-08 A | A1680 | 100% | 2013-03-21 | 2013-04-19 |  |  |  | Mobilizasyon Yeni WBS [240 h] | 4,800 |  |  |  |
|  | 2 | **Consumables** |  |  | 2013-01-01 | 2013-02-10 |  |  |  |  |  |  |  |  |  |  |  |  |
| MOB-PA-CO-110 |  | Procurement of Consumables |  | 5d | 2013-01-01 A | 2013-01-07 A | A1680 SS | 100% | 2013-03-21 | 2013-03-25 |  |  |  | Mobilizasyon Yeni WBS [40 h] | 800 |  |  |  |
| MOB-PA-CO-120 |  | Delivery on Site |  | 5d | 2013-01-10 A | 2013-02-10 A | MOB-PA-CO-110 | 100% | 2013-03-21 | 2013-03-25 |  |  |  | Mobilizasyon Yeni WBS [40 h] | 800 |  |  |  |
|  | 3 | **Furniture** |  |  | 2013-03-01 | 2013-05-25 |  |  |  |  |  |  |  |  |  |  |  |  |
| MOB-PA-FU-100 |  | Inquiry for Furniture |  | 31d | 2013-03-01 A | 2013-03-25 A | MOB-ST-PR-0060 FS-10d | 100% | 2013-03-21 | 2013-04-20 |  |  |  | Mobilizasyon Yeni WBS [248 h] | 4,960 | 4,960 |  | bitti |
| MOB-PA-FU-110 |  | Procurement of Furniture |  | 15d | 2013-04-11 | 2013-04-25 | MOB-PA-FU-100 FS+3d |  |  |  | 35d | 0d |  | Mobilizasyon Yeni WBS [120 h] | 2,400 |  |  |  |
| MOB-PA-FU-120 |  | Delivery on Site |  | 30d | 2013-04-26 | 2013-05-25 | MOB-PA-FU-110 |  |  |  | 35d | 64.38d |  | Mobilizasyon Yeni WBS [240 h] | 4,800 |  |  |  |

| ID | WBS | Activity | Type | Duration | Start | Finish | Predecessors | Complete | Remaining | Planned start | Planned finish | Total float | Free float | Resources | Cost | NOT |
| --- | --- | --- | --- | --- | --- | --- | --- | --- | --- | --- | --- | --- | --- | --- | --- | --- |
|  | 4 | **Office Equipment** |  |  | 2013-03-01 | 2013-05-13 |  |  |  |  |  |  |  |  |  |  |
| MOB-PA-OE100 |  | Inquiry for Office Equipment |  | 30d | 2013-03-01 A | 2013-04-20 | MOB-PA-FU-100 SS, MOB-ST-PR-0060 FS-15d | 67% | 10d | 2013-03-21 | 2013-04-19 | 47d | 0d | Mobilizasyon Yeni WBS [240 h] | 4,800 |  |
| MOB-PA-OE110 |  | Procurement of Office Equipment |  | 5d | 2013-04-24 | 2013-04-28 | MOB-PA-FU-110 SS+5d, MOB-PA-OE100 FS+3d |  |  |  |  | 47d | 0d | Mobilizasyon Yeni WBS [40 h] | 800 |  |
| MOB-PA-OE120 |  | Delivery on Site |  | 15d | 2013-04-29 | 2013-05-13 | MOB-PA-OE110 |  |  |  |  | 47d | 76.38d | Mobilizasyon Yeni WBS [120 h] | 2,400 |  |
|  | 16 | **Construction Equipment** |  |  | 2013-02-06 | 2013-07-03 |  |  |  |  |  |  |  |  |  |  |
|  | 1 | **Heavy Equipment** |  |  | 2013-02-07 | 2013-05-13 |  |  |  |  |  |  |  |  |  |  |
|  | 1 | **Dozer** |  |  | 2013-02-07 | 2013-02-23 |  |  |  |  |  |  |  |  |  |  |
| MOB-HE-DZR-120 |  | Delivery to Site |  | 20d | 2013-02-07 A | 2013-02-23 A | MOB-HE-DZR-100 | 100% |  | 2013-03-21 | 2013-04-09 |  |  | Mobilizasyon Yeni WBS [160 h] | 3,200 |  |
| MOB-HE-DZR-100 |  | Purchase Order | milestone | 0d | 2013-02-20 A | 2013-02-20 A | MOB-ST-PR-0060 SS+50d | 100% |  | 2013-03-21 | 2013-03-21 |  |  |  | 1 | ekipman wbs yapýlacak |
| MOB-HE-DZR-110 |  | Purchase Order Submission to Kazakhmys | milestone | 0d | 2013-02-22 A | 2013-02-22 A | MOB-HE-DZR-100 FS+15d | 100% |  | 2013-03-21 | 2013-03-21 |  |  |  | 1 |  |
|  | 2 | **Water Tanker** |  |  | 2013-03-22 | 2013-05-10 |  |  |  |  |  |  |  |  |  |  |
| MOB-HE-WT-100 |  | Purchase Order | milestone | 0d | 2013-03-22 A | 2013-03-22 A | MOB-ST-PR-0060 SS+70d | 100% |  | 2013-03-21 | 2013-03-21 |  |  |  | 1 |  |
| MOB-HE-WT-110 |  | Purchase Order Submission to Kazakhmys | milestone | 0d | 2013-03-26 A | 2013-03-26 A | MOB-HE-TFB-110 SS, MOB-HE-WT-100 SS+25d | 100% |  | 2013-03-21 | 2013-03-21 |  |  |  | 1 |  |
| MOB-HE-WT-120 |  | Water Tanker Delivery to Site |  | 30d | 2013-04-11 | 2013-05-10 | MOB-HE-WT-110 FS+6d |  |  |  |  | 50d | 0d | Mobilizasyon Yeni WBS [240 h] | 4,800 |  |
|  | 3 | **Trailor, Low Bed** |  |  | 2013-03-22 | 2013-05-10 |  |  |  |  |  |  |  |  |  |  |
| MOB-HE-TLB100 |  | Purchase Order | milestone | 0d | 2013-03-22 A | 2013-03-22 A | MOB-ST-PR-0060 FS+60d | 100% |  | 2013-03-27 | 2013-03-27 |  |  |  | 1 |  |
| MOB-HE-TLB110 |  | Purchase Order Submission to Kazakhmys | milestone | 0d | 2013-03-26 A | 2013-03-26 A | MOB-HE-TLB100 FS+25d, MOB-HE-TFB-110 SS | 100% |  | 2013-03-27 | 2013-03-27 |  |  |  | 1 |  |
| MOB-HE-TLB120 |  | Delivery to Site |  | 30d | 2013-04-11 | 2013-05-10 | MOB-HE-TLB110, MOB-HE-WT-120 SS |  |  |  |  | 112d | 79.38d | Mobilizasyon Yeni WBS [240 h] | 4,800 |  |
|  | 4 | **Trailor, Flat Bed** |  |  | 2013-03-22 | 2013-05-10 |  |  |  |  |  |  |  |  |  |  |
| MOB-HE-TFB-100 |  | Purchase Order | milestone | 0d | 2013-03-22 A | 2013-03-22 A | MOB-ST-PR-0060 SS+60d, MOB-HE-TLB100 SS | 100% |  | 2013-03-27 | 2013-03-27 |  |  |  | 1 |  |
| MOB-HE-TFB-110 |  | Purchase Order Submission to Kazakhmys | milestone | 0d | 2013-03-26 A | 2013-03-26 A | MOB-HE-TFB-100 FS+25d | 100% |  | 2013-03-27 | 2013-03-27 |  |  |  | 1 |  |
| MOB-HE-TFB-120 |  | Delivery to Site |  | 30d | 2013-04-11 | 2013-05-10 | MOB-HE-TFB-110 FS+6d |  |  |  |  | 50d | 79.38d | Mobilizasyon Yeni WBS [240 h] | 4,800 |  |
|  | 5 | **Wheel Loader** |  |  | 2013-02-11 | 2013-05-01 |  |  |  |  |  |  |  |  |  |  |
| MOB-HE-WL-100 |  | Purchase Order | milestone | 0d | 2013-02-11 A | 2013-02-11 A | MOB-ST-PR-0060 SS+40d | 100% |  | 2013-03-27 | 2013-03-27 |  |  |  | 1 |  |
| MOB-HE-WL-110 |  | Purchase Order Submission to Kazakhmys | milestone | 0d | 2013-02-13 A | 2013-02-13 A | MOB-HE-WL-100 SS+10d | 100% |  | 2013-03-27 | 2013-03-27 |  |  |  | 1 |  |
| MOB-HE-WL-120 |  | Delivery to Site |  | 32d | 2013-03-15 A | 2013-05-01 | MOB-HE-WL-110 FS+35d | 37% | 20.25d | 2013-03-27 | 2013-04-27 | 121.75d | 89.12d | Mobilizasyon Yeni WBS [256 h] | 5,120 |  |

Notes:
- MOB-HE-DZR-100: Expenses: (New Expense Item) 1
- MOB-HE-DZR-110: Expenses: (New Expense Item) 1
- MOB-HE-WT-100: Expenses: (New Expense Item) 1
- MOB-HE-WT-110: Expenses: (New Expense Item) 1
- MOB-HE-TLB100: Expenses: (New Expense Item) 1
- MOB-HE-TLB110: Expenses: (New Expense Item) 1
- MOB-HE-TFB-100: Expenses: (New Expense Item) 1
- MOB-HE-TFB-110: Expenses: (New Expense Item) 1
- MOB-HE-WL-100: Expenses: (New Expense Item) 1
- MOB-HE-WL-110: Expenses: (New Expense Item) 1

| ID | WBS | Activity | Type | Duration | Start | Finish | Predecessors | Complete | Remaining | Planned start | Planned finish | Total float | Free float | Resources | Cost |
| --- | --- | --- | --- | --- | --- | --- | --- | --- | --- | --- | --- | --- | --- | --- | --- |
|  | 6 | **Backhoe Loader** |  |  | 2013-02-10 | 2013-03-10 |  |  |  |  |  |  |  |  |  |
| MOB-HE-BL-120 |  | Delivery to Site |  | 30d | 2013-02-10 A | 2013-03-10 A | MOB-HE-BL-100 FS+5d | 100% |  | 2013-03-27 | 2013-04-25 |  |  | Mobilizasyon Yeni WBS [240 h] | 4,800 |
| MOB-HE-BL-100 |  | Purchase Order | milestone | 0d | 2013-02-11 A | 2013-02-11 A | MOB-HE-WL-100 SS | 100% |  | 2013-03-27 | 2013-03-27 |  |  |  | 1 |
| MOB-HE-BL-110 |  | Purchase Order Submission to Kazakhmys | milestone | 0d | 2013-02-13 A | 2013-02-13 A | MOB-HE-BL-100 FS+7d | 100% |  | 2013-03-27 | 2013-03-27 |  |  |  | 1 |
|  | 7 | **Crawler Excavator** |  |  | 2013-02-13 | 2013-05-13 |  |  |  |  |  |  |  |  |  |
| MOB-HE-CE-100 |  | Purchase Order Submission to Kazakhmys | milestone | 0d | 2013-02-13 A | 2013-02-13 A | MOB-ST-PR-0060 FS+50d, MOB-HE-BL-100 SS | 100% |  | 2013-03-27 | 2013-03-27 |  |  |  | 1 |
| MOB-HE-CE-110 |  | Delivery to Site |  | 30d | 2013-03-20 A | 2013-05-13 | MOB-HE-CE-100 FS+30d |  | 32.25d | 2013-03-20 | 2013-04-18 | 109.75d | 77.12d | Mobilizasyon Yeni WBS [240 h] | 4,800 |
|  | 8 | **Grader** |  |  | 2013-02-13 | 2013-04-04 |  |  |  |  |  |  |  |  |  |
| MOB-HE-GR-100 |  | Purchase Order Submission to Kazakhmys | milestone | 0d | 2013-02-13 A | 2013-02-13 A | MOB-HE-CE-100 | 100% |  | 2013-03-27 | 2013-03-27 |  |  |  | 1 |
| MOB-HE-GR-110 |  | Delivery to Site |  | 30d | 2013-03-04 A | 2013-04-04 A | MOB-HE-GR-100 FS+25d | 100% |  | 2013-03-27 | 2013-04-25 |  |  | Mobilizasyon Yeni WBS [240 h] | 4,800 |
|  | 9 | **Single Drum Roller** |  |  | 2013-02-13 | 2013-04-11 |  |  |  |  |  |  |  |  |  |
| MOB-HE-SDR-100 |  | Purchase Order Submission to Kazakhmys | milestone | 0d | 2013-02-13 A | 2013-02-13 A | MOB-HE-GR-100 | 100% |  | 2013-03-27 | 2013-03-27 |  |  |  | 1 |
| MOB-HE-SDR-110 |  | Delivery to Site |  | 30d | 2013-03-05 A | 2013-04-11 | MOB-HE-SDR-100 FS+25d | 100% | 0d | 2013-03-27 | 2013-04-25 | 80d | 109.38d | Mobilizasyon Yeni WBS [240 h] | 4,800 |
|  | 10 | **Concrete Batching Plant (120 m3)** |  |  | 2013-02-10 | 2013-04-09 |  |  |  |  |  |  |  |  |  |
| MOB-HE-CBP-100 |  | Purchase Order | milestone | 0d | 2013-02-10 A | 2013-02-10 A | MOB-ST-PR-0060 SS+45d | 100% |  | 2013-03-27 | 2013-03-27 |  |  |  | 1 |
| MOB-HE-CBP-110 |  | Delivery to Site |  | 30d | 2013-03-11 A | 2013-04-09 A | MOB-HE-CBP-100 FS+30d | 100% |  | 2013-03-27 | 2013-04-25 |  |  | Mobilizasyon Yeni WBS [240 h] | 4,800 |
|  | 12 | **Concrete Batching Plant (105 m3)** |  |  | 2013-02-10 | 2013-02-28 |  |  |  |  |  |  |  |  |  |
| MOB-HE-CBP-120 |  | Purchase Order | milestone | 0d | 2013-02-10 A | 2013-02-10 A | MOB-HE-CBP-100 SS | 100% |  | 2013-03-27 | 2013-03-27 |  |  |  | 1 |
| MOB-HE-CBP-130 |  | Delivery to Site |  | 30d | 2013-02-10 A | 2013-02-28 A | MOB-HE-CBP-110 SS | 100% |  | 2013-03-27 | 2013-04-25 |  |  | Mobilizasyon Yeni WBS [240 h] | 4,800 |
|  | 11 | **Screenig Plant** |  |  | 2013-03-15 | 2013-05-10 |  |  |  |  |  |  |  |  |  |
| MOB-HE-SP-100 |  | Purchase Order | milestone | 0d | 2013-03-15 A | 2013-03-15 A | MOB-ST-PR-0060 FS+80d | 100% |  | 2013-03-27 | 2013-03-27 |  |  |  | 1 |
| MOB-HE-SP-110 |  | Delivery to Site |  | 30d | 2013-04-11 | 2013-05-10 | MOB-HE-SP-100 FS+15d |  |  |  |  | 112d | 79.38d | Mobilizasyon Yeni WBS [240 h] | 4,800 |
|  | 2 | **Light Equipment** |  |  | 2013-02-22 | 2013-05-22 |  |  |  |  |  |  |  |  |  |
|  | 1 | **Forklift 5T** |  |  | 2013-02-22 | 2013-05-22 |  |  |  |  |  |  |  |  |  |
| MOB-LE-FL-100 |  | Purchase Order Submission to Kazakhmys | milestone | 0d | 2013-02-22 A | 2013-02-22 A | MOB-ST-PR-0060 SS+60d | 100% |  | 2013-03-27 | 2013-03-27 |  |  |  | 1 |
| MOB-LE-FL-110 |  | Delivery to Site |  | 40.25d | 2013-04-12 | 2013-05-22 | MOB-LE-FL-100 FS+50d |  |  |  |  | 38d | 0d | Mobilizasyon Yeni WBS [322 h] | 6,440 |

Notes:
- MOB-HE-BL-100: Expenses: (New Expense Item) 1
- MOB-HE-BL-110: Expenses: (New Expense Item) 1
- MOB-HE-CE-100: Expenses: (New Expense Item) 1
- MOB-HE-GR-100: Expenses: (New Expense Item) 1
- MOB-HE-SDR-100: Expenses: (New Expense Item) 1
- MOB-HE-CBP-100: Expenses: (New Expense Item) 1
- MOB-HE-CBP-120: Expenses: (New Expense Item) 1
- MOB-HE-SP-100: Expenses: (New Expense Item) 1
- MOB-LE-FL-100: Expenses: (New Expense Item) 1

| ID | WBS | Activity | Type | Duration | Start | Finish | Predecessors | Complete | Remaining | Planned start | Planned finish | Total float | Free float | Resources | Cost |
| --- | --- | --- | --- | --- | --- | --- | --- | --- | --- | --- | --- | --- | --- | --- | --- |
|  | 2 | **Forklift 8T** |  |  | 2013-02-22 | 2013-05-22 |  |  |  |  |  |  |  |  |  |
| MOB-LE-FL-120 |  | Purchase Order Submission to Kazakhmys | milestone | 0d | 2013-02-22 A | 2013-02-22 A | MOB-LE-FL-100 SS | 100% |  | 2013-03-27 | 2013-03-27 |  |  |  | 1 |
| MOB-LE-FL-130 |  | Delivery to Site |  | 40d | 2013-04-12 | 2013-05-22 | MOB-LE-FL-110 SS, MOB-LE-FL-120 FS+40d |  |  |  |  | 38.25d | 67.62d | Mobilizasyon Yeni WBS [320 h] | 6,400 |
|  | 3 | **Vehicles** |  |  | 2013-02-08 | 2013-05-01 |  |  |  |  |  |  |  |  |  |
|  | 1 | **Dump Truck** |  |  | 2013-02-22 | 2013-03-26 |  |  |  |  |  |  |  |  |  |
| MOB-VH-DT-110 |  | Delivery to Site |  | 30d | 2013-02-22 A | 2013-03-24 A | MOB-HE-BL-120 SS+10d | 100% |  | 2013-03-27 | 2013-04-25 |  |  | Mobilizasyon Yeni WBS [240 h] | 4,800 |
| MOB-VH-DT-100 |  | Purchase Order Submittion to Kazakhmys | milestone | 0d | 2013-03-26 A | 2013-03-26 A | MOB-VH-DT-110, MOB-ST-PR-0060 SS+90d | 100% |  | 2013-03-28 | 2013-03-28 |  |  |  | 1 |
|  | 2 | **Diesel Truck** |  |  | 2013-03-15 | 2013-05-01 |  |  |  |  |  |  |  |  |  |
| MOB-VH-DST-120 |  | Delivery to Site |  | 30d | 2013-03-15 A | 2013-05-01 | MOB-VH-DST-100 FS+15d | 32% | 20.25d | 2013-03-27 | 2013-04-25 | 121.75d | 89.12d | Mobilizasyon Yeni WBS [240 h] | 4,800 |
| MOB-VH-DST-100 |  | Purchase Order | milestone | 0d | 2013-03-22 A | 2013-03-22 A | MOB-HE-WT-100 SS+10d | 100% |  | 2013-03-27 | 2013-03-27 |  |  |  | 1 |
| MOB-VH-DST-110 |  | Purchase Order Submission to Kazakhmys | milestone | 0d | 2013-03-26 A | 2013-03-26 A | MOB-VH-DST-100 FS+25d | 100% |  | 2013-03-27 | 2013-03-27 |  |  |  | 1 |
|  | 3 | **Service Truck** |  |  | 2013-03-15 | 2013-05-01 |  |  |  |  |  |  |  |  |  |
| MOB-VH-ST-120 |  | Delivery to Site |  | 30d | 2013-03-15 A | 2013-05-01 | MOB-VH-DST-120 SS, MOB-VH-ST-110 | 32% | 20.25d | 2013-03-27 | 2013-04-25 | 59.75d | 89.12d | Mobilizasyon Yeni WBS [240 h] | 4,800 |
| MOB-VH-ST-100 |  | Purchase Order | milestone | 0d | 2013-03-22 A | 2013-03-22 A | MOB-VH-DST-100 | 100% |  | 2013-03-27 | 2013-03-27 |  |  |  | 1 |
| MOB-VH-ST-110 |  | Purchase Order Submission to Kazakhmys | milestone | 0d | 2013-03-26 A | 2013-03-26 A | MOB-VH-DST-110, MOB-VH-ST-100 | 100% |  | 2013-03-27 | 2013-03-27 |  |  |  | 1 |
|  | 4 | **4x4 Pickup** |  |  | 2013-02-08 | 2013-04-20 |  |  |  |  |  |  |  |  |  |
| MOB-VH-PU-100 |  | Purchase Order | milestone | 0d | 2013-02-08 A | 2013-02-08 A | MOB-ST-PR-0060 FS+40d | 100% |  | 2013-03-27 | 2013-03-27 |  |  |  | 1 |
| MOB-VH-PU-110 |  | Delivery to Site |  | 30d | 2013-03-05 A | 2013-04-20 | MOB-VH-PU-100 FS+30d | 67% | 10d | 2013-03-27 | 2013-04-25 | 40d | 0d | Mobilizasyon Yeni WBS [240 h] | 4,800 |
|  | 4 | **Cranes (Mobile and Fixed)** |  |  | 2013-02-06 | 2013-06-15 |  |  |  |  |  |  |  |  |  |
|  | 1 | **Crane 350 Tonnes** |  |  | 2013-02-06 | 2013-06-15 |  |  |  |  |  |  |  |  |  |
| MOB-VH-CR-100 |  | Purchase Order | milestone | 0d | 2013-02-06 A | 2013-02-06 A | MOB-ST-PR-0060 SS+40d | 100% |  | 2013-03-28 | 2013-03-28 |  |  |  | 1 |
| MOB-VH-CR-110 |  | Delivery to Site |  | 30.25d | 2013-05-16 | 2013-06-15 | MOB-VH-CR-100 FS+100d |  |  |  |  | 14d | 0d | Mobilizasyon Yeni WBS [242 h] | 4,840 |
|  | 2 | **Crane 200 Tonnes** |  |  | 2013-02-06 | 2013-06-15 |  |  |  |  |  |  |  |  |  |
| MOB-VH-CR-120 |  | Purchase Order | milestone | 0d | 2013-02-06 A | 2013-02-06 A |  | 100% |  | 2013-03-27 | 2013-03-27 |  |  |  | 1 |
| MOB-VH-CR-130 |  | Delivery to Site |  | 30.25d | 2013-05-16 | 2013-06-15 | MOB-VH-CR-110 SS, MOB-VH-CR-120 FS+90d |  |  |  |  | 14d | 43.38d | Mobilizasyon Yeni WBS [242 h] | 4,840 |

Notes:
- MOB-LE-FL-120: Expenses: (New Expense Item) 1
- MOB-VH-DT-100: Expenses: (New Expense Item) 1
- MOB-VH-DST-100: Expenses: (New Expense Item) 1
- MOB-VH-DST-110: Expenses: (New Expense Item) 1
- MOB-VH-ST-100: Expenses: (New Expense Item) 1
- MOB-VH-ST-110: Expenses: (New Expense Item) 1
- MOB-VH-PU-100: Expenses: (New Expense Item) 1
- MOB-VH-CR-100: Expenses: (New Expense Item) 1
- MOB-VH-CR-120: Expenses: (New Expense Item) 1

| ID | WBS | Activity | Type | Duration | Start | Finish | Predecessors | Complete | Planned start | Planned finish | Total float | Free float | Resources | Cost |
| --- | --- | --- | --- | --- | --- | --- | --- | --- | --- | --- | --- | --- | --- | --- |
|  | 3 | **Crane 90 Tonnes** |  |  | 2013-02-06 | 2013-05-16 |  |  |  |  |  |  |  |  |
| MOB-VH-CR-140 |  | Purchase Order | milestone | 0d | 2013-02-06 A | 2013-02-06 A | MOB-VH-CR-120 | 100% | 2013-03-27 | 2013-03-27 |  |  |  | 1 |
| MOB-VH-CR-150 |  | Delivery to Site |  | 30d | 2013-04-16 | 2013-05-16 | MOB-VH-CR-140 FS+70d |  |  |  | 44.25d | 73.62d | Mobilizasyon Yeni WBS [240 h] | 4,800 |
|  | 4 | **Crane 60 Tonnes** |  |  | 2013-02-06 | 2013-03-29 |  |  |  |  |  |  |  |  |
| MOB-VH-CR-160 |  | Purchase Order | milestone | 0d | 2013-02-06 A | 2013-02-06 A | MOB-VH-CR-140 SS | 100% | 2013-03-27 | 2013-03-27 |  |  |  | 1 |
| MOB-VH-CR-170 |  | Delivery to Site |  | 30d | 2013-03-17 A | 2013-03-29 A | MOB-VH-CR-160 FS+40d | 100% | 2013-03-27 | 2013-04-25 |  |  | Mobilizasyon Yeni WBS [240 h] | 4,800 |
|  | 5 | **HI-UP + 60 ton x m** |  |  | 2013-02-06 | 2013-05-16 |  |  |  |  |  |  |  |  |
| MOB-VH-HU-100 |  | Purchase Order | milestone | 0d | 2013-02-06 A | 2013-02-06 A | MOB-VH-CR-160 SS | 100% | 2013-03-27 | 2013-03-27 |  |  |  | 1 |
| MOB-VH-HU-110 |  | Delivery to Site |  | 35.25d | 2013-04-11 | 2013-05-16 | MOB-VH-CR-170, MOB-VH-HU-100 FS+40d |  |  |  | 44.75d | 74.12d | Mobilizasyon Yeni WBS [282 h] | 5,640 |
|  | 5 | **Existing Cranes on site (repair)** |  |  | 2013-05-11 | 2013-05-25 |  |  |  |  |  |  |  |  |
| MOB-CE-EC-130 |  | Existing Crane Repair ( if necessary) |  | 15d | 2013-05-11 | 2013-05-25 | MOB-ST-OE-0019 FS+30d |  |  |  | 35d | 64.38d | Mobilizasyon Yeni WBS [120 h] | 2,400 |
|  | 6 | **Construction Power** |  |  | 2013-02-13 | 2013-07-03 |  |  |  |  |  |  |  |  |
|  | 1 | **Generator 75 kVA** |  |  | 2013-02-13 | 2013-05-13 |  |  |  |  |  |  |  |  |
| MOB-CE-CP-200 |  | Purchase Order Submission to Kazakhmys | milestone | 0d | 2013-02-13 A | 2013-02-13 A | MOB-ST-PR-0060 SS+50d | 100% | 2013-03-27 | 2013-03-27 |  |  |  | 1 |
| MOB-CE-CP-210 |  | Delivery to Site |  | 32.25d | 2013-04-11 | 2013-05-13 | MOB-CE-CP-200 FS+45d |  |  |  | -3.25d | 0d | Mobilizasyon Yeni WBS [258 h] | 5,160 |
|  | 2 | **Generator 160 kVA** |  |  | 2013-02-13 | 2013-05-13 |  |  |  |  |  |  |  |  |
| MOB-CE-CP-220 |  | Purchase Order Submission to Kazakhmys | milestone | 0d | 2013-02-13 A | 2013-02-13 A | MOB-CE-CP-200 | 100% | 2013-03-27 | 2013-03-27 |  |  |  | 1 |
| MOB-CE-CP-230 |  | Delivery to Site |  | 32.25d | 2013-04-11 | 2013-05-13 | MOB-CE-CP-210 SS, MOB-CE-CP-220 FS+40d |  |  |  | -3.25d | 0d | Mobilizasyon Yeni WBS [258 h] | 5,160 |
|  | 3 | **Generator 300 kVA** |  |  | 2013-02-13 | 2013-05-13 |  |  |  |  |  |  |  |  |
| MOB-CE-CP-240 |  | Purchase Order Submission to Kazakhmys | milestone | 0d | 2013-02-13 A | 2013-02-13 A | MOB-CE-CP-220 SS | 100% | 2013-03-27 | 2013-03-27 |  |  |  | 1 |
| MOB-CE-CP-250 |  | Delivery to Site |  | 32.25d | 2013-04-11 | 2013-05-13 | MOB-CE-CP-230 SS, MOB-CE-CP-210 SS, MOB-CE-CP-240 FS+40d |  |  |  | -3.25d | 0d | Mobilizasyon Yeni WBS [258 h] | 5,160 |
|  | 4 | **Generator 400 kVA** |  |  | 2013-02-13 | 2013-05-13 |  |  |  |  |  |  |  |  |
| MOB-CE-CP-260 |  | Purchase Order Submission to Kazakhmys | milestone | 0d | 2013-02-13 A | 2013-02-13 A | MOB-CE-CP-240 | 100% | 2013-03-27 | 2013-03-27 |  |  |  | 1 |
| MOB-CE-CP-270 |  | Delivery to Site |  | 32.25d | 2013-04-11 | 2013-05-13 | MOB-CE-CP-260 FS+40d, MOB-CE-CP-250 SS |  |  |  | -3.25d | 0d | Mobilizasyon Yeni WBS [258 h] | 5,160 |

Notes:
- MOB-VH-CR-140: Expenses: (New Expense Item) 1
- MOB-VH-CR-160: Expenses: (New Expense Item) 1
- MOB-VH-HU-100: Expenses: (New Expense Item) 1
- MOB-CE-CP-200: Expenses: (New Expense Item) 1
- MOB-CE-CP-220: Expenses: (New Expense Item) 1
- MOB-CE-CP-240: Expenses: (New Expense Item) 1
- MOB-CE-CP-260: Expenses: (New Expense Item) 1

| ID | WBS | Activity | Type | Duration | Start | Finish | Predecessors | Complete | Planned start | Planned finish | Total float | Free float | Constraint | Resources | Cost | user_text7 |
| --- | --- | --- | --- | --- | --- | --- | --- | --- | --- | --- | --- | --- | --- | --- | --- | --- |
|  | 5 | **Generator 2200 kVA** |  |  | 2013-02-13 | 2013-07-03 |  |  |  |  |  |  |  |  |  |  |
| MOB-CE-CP-280 |  | Purchase Order Submission to Kazakhmys | milestone | 0d | 2013-02-13 A | 2013-02-13 A | MOB-CE-CP-260 | 100% | 2013-03-27 | 2013-03-27 |  |  |  |  | 1 |  |
| MOB-CE-CP-290 |  | Delivery to Site |  | 31d | 2013-06-02 | 2013-07-03 | MOB-CE-CP-280 FS+60d, MOB-CE-CP-270 FS+20d |  | 2013-05-30 | 2013-06-29 | -3.25d | 26.12d | start on or after 2013-05-30 | Mobilizasyon Yeni WBS [248 h] | 4,960 | baseline |
|  | 17 | **Personnel Mobilization** |  |  | 2013-05-30 | 2013-06-09 |  |  |  |  |  |  |  |  |  |  |
|  | 1 | **Busses (for site and to/from train station)** |  |  | 2013-05-30 | 2013-06-09 |  |  |  |  |  |  |  |  |  |  |
| MOB-PM-BU-130 |  | Shuttle Busses |  | 10d | 2013-05-30 | 2013-06-09 | MOB-PPB-PM-100 FS+75d |  |  |  | 20.76d | 50.14d |  | Mobilizasyon Yeni WBS [8 h] | 160 |  |

Notes:
- MOB-CE-CP-280: Expenses: (New Expense Item) 1
